# Plan de Ejecución del Programa

How a schedule from MS Project changed from version to version. A marks actual dates.

## Version 1 (saved 2016-09-29)

| ID | WBS | Task | Duration | Start | Finish | Predecessors | Total float |
| --- | --- | --- | --- | --- | --- | --- | --- |
| 1 |  | Inicio de la preparación del Programa de Saneamiento de los Distritos de Arraiján y La Chorrera - PSACH Fase I | 0d | 2016-04-04 | 2016-04-04 |  | 0d |
| 2 | 0 | **Actividades previas** | 263d | 2016-04-04 | 2017-04-05 |  | 0d |
| 3 |  | Misión de Identificación | 5d | 2016-04-04 | 2016-04-08 | 1 | 0d |
| 4 |  | Disponibilidad del Perfil del Proyecto | 1d | 2016-05-26 | 2016-05-26 | 3FS+33d | 0d |
| 5 |  | Misión de Orientación | 5d | 2016-06-06 | 2016-06-10 | 4FS+6d | 0d |
| 6 |  | Misión de Análisis | 4d | 2016-08-16 | 2016-08-19 | 5FS+46d | 0d |
| 7 |  | Propuesta de Préstamo al Directorio del BID | 1d | 2016-09-01 | 2016-09-01 | 6FS+8d | 0d |
| 8 |  | Negociación del contrato | 1d | 2016-10-14 | 2016-10-14 | 7FS+30d | 0d |
| 9 |  | Consejo Económico Nacional | 1d | 2016-11-16 | 2016-11-16 | 8FS+22d | 0d |
| 10 |  | Consejo de Gabinete | 1d | 2016-12-01 | 2016-12-01 | 9FS+10d | 0d |
| 11 |  | Refrendo de la CGR | 1d | 2017-01-03 | 2017-01-03 | 10FS+22d | 0d |
| 12 |  | Cumplimiento de Condiciones de Elegibilidad | 66d | 2017-01-04 | 2017-04-05 | 11 | 0d |
| 13 |  | Inicio de la ejecución del PSACH Fase I | 0d | 2017-04-06 | 2017-04-06 | 12FS+1d | 0d |
| 14 | 1 | **Componente 1. Inversiones prioritarias** | 1825d | 2016-01-04 | 2022-12-30 |  | 0d |
| 15 | 1.1 | **Producto 1: Primer Módulo de la PTAR construida** | 1539d | 2016-01-04 | 2021-11-25 |  | 0d |
| 16 | 1.1.1 | **Actividades de coordinación y seguimiento de acuerdos entre autoridades del MINSA y propietarios del terreno para su adquisición** | 345d | 2016-04-04 | 2017-07-28 | 1 | 50d |
| 17 |  | Adquisciones de terrenos | 345d | 2016-04-04 | 2017-07-28 |  | 50d |
| 18 | 1.1.2 | **LPI_1. Contratación de firma para el diseño y construcción de obras** | 1101d | 2017-07-31 | 2021-10-18 |  | 50d |
| 19 |  | Etapa previa | 80d | 2017-07-31 | 2017-11-17 | 36, 17 | 50d |
| 20 |  | Etapa de contratación | 95d | 2017-11-20 | 2018-03-30 | 19 | 50d |
| 21 |  | Formalización del contrato | 66d | 2018-04-02 | 2018-07-02 | 20 | 50d |
| 22 | 1.1.2.6 | **Ejecución de contrato** | 860d | 2018-07-03 | 2021-10-18 |  | 50d |
| 23 |  | Elaboración del diseño final | 300d | 2018-07-03 | 2019-08-26 | 21 | 50d |
| 24 |  | Diseño de la PTAR Caimito elaborado | 0d | 2019-08-26 | 2019-08-26 | 23 | 874d |
| 25 |  | Construcción de la PTAR | 800d | 2018-09-25 | 2021-10-18 | 23SS+60d | 50d |
| 26 |  | PTAR Caimito construida | 0d | 2021-10-18 | 2021-10-18 | 25 | 50d |
| 27 | 1.1.2.5 | **Pagos** | 860d | 2018-07-03 | 2021-10-18 |  | 314d |
| 28 |  | Pagos BID | 860d | 2018-07-03 | 2021-10-18 | 23SS | 314d |
| 29 |  | Pagos AECID | 860d | 2018-07-03 | 2021-10-18 | 28SS | 314d |
| 30 |  | Pago CAF | 860d | 2018-07-03 | 2021-10-18 | 29SS | 314d |
| 31 |  | Pago CL | 860d | 2018-07-03 | 2021-10-18 | 30SS | 314d |
| 32 | 1.1.3 | **SBCC_6. Contratación de firma consultora para la supervisión de diseños y obras** | 1539d | 2016-01-04 | 2021-11-25 |  | 0d |
| 33 |  | Etapa previa | 160d | 2016-01-04 | 2016-08-12 | 1FS-65d | 0d |
| 34 |  | Etapa de Expresión de interés | 45d | 2016-08-15 | 2016-10-14 | 33 | 50d |
| 35 |  | Etapa de contratación | 110d | 2016-10-17 | 2017-03-17 | 34 | 50d |
| 36 |  | Formalización del contrato | 95d | 2017-03-20 | 2017-07-28 | 35 | 50d |
| 37 |  | Ejecución de contrato | 1125d | 2017-08-04 | 2021-11-25 | 36FS+4d | 286d |
| 38 | 1.1.3.6 | **Pagos** | 1125d | 2017-08-04 | 2021-11-25 |  | 286d |
| 39 |  | Pagos BID | 1125d | 2017-08-04 | 2021-11-25 | 37SS | 286d |
| 40 |  | Pagos CL | 1125d | 2017-08-04 | 2021-11-25 | 39SS | 286d |
| 41 | 1.2 | **Producto 2: Interceptor construido** | 1125d | 2017-08-04 | 2021-11-25 |  | 286d |
| 42 | 1.2.1 | **LPI_1. Contratación de firma para el diseño y construcción de obras** | 800d | 2018-07-03 | 2021-07-26 |  | 374d |
| 43 | 1.2.1.1 | **Ejecución del contrato** | 800d | 2018-07-03 | 2021-07-26 |  | 374d |
| 44 |  | Elaboración del diseño final | 300d | 2018-07-03 | 2019-08-26 | 23SS | 374d |
| 45 |  | Diseño del interceptor elaborado | 0d | 2019-08-26 | 2019-08-26 | 44 | 874d |
| 46 |  | Construcción del interceptor | 740d | 2018-09-25 | 2021-07-26 | 25SS | 374d |
| 47 |  | Interceptor construido | 0d | 2021-07-26 | 2021-07-26 | 46 | 374d |
| 48 | 1.2.1.1.1 | **Pagos** | 800d | 2018-07-03 | 2021-07-26 |  | 374d |
| 49 |  | Pagos BID | 800d | 2018-07-03 | 2021-07-26 | 44SS | 374d |
| 50 |  | Pagos AECID | 800d | 2018-07-03 | 2021-07-26 | 49SS | 374d |
| 51 |  | Pago CL | 800d | 2018-07-03 | 2021-07-26 | 50SS | 374d |
| 52 | 1.2.2 | **SBCC_7. Contratación de firma consultora para la supervisión de diseños y obras** | 1125d | 2017-08-04 | 2021-11-25 |  | 286d |
| 53 | 1.2.2.1 | **Ejecución del contrato** | 1125d | 2017-08-04 | 2021-11-25 |  | 286d |
| 54 |  | Pagos BID | 1125d | 2017-08-04 | 2021-11-25 | 39SS | 286d |
| 55 |  | Pagos CL | 1125d | 2017-08-04 | 2021-11-25 | 54SS | 286d |
| 56 | 1.3 | **Producto 3: Colectoras construidas, rehabilitadas y/o ampliadas** | 1805d | 2016-02-01 | 2022-12-30 |  | 0d |
| 57 | 1.3.1 | **Colectoras construidas en las cuencas de la muestra: Prudente, Aguacate y Bernardino** | 910d | 2017-08-04 | 2021-01-28 |  | 501d |
| 58 | 1.3.1.1 | **LPI_1. Contratación de firma para el diseño y construcción de obras** | 650d | 2018-07-03 | 2020-12-28 |  | 524d |
| 59 | 1.3.1.1.1 | **Cuenca de Prudente** | 650d | 2018-07-03 | 2020-12-28 |  | 524d |
| 60 | 1.3.1.1.1.1 | **Ejecución del contrato** | 650d | 2018-07-03 | 2020-12-28 |  | 524d |
| 61 |  | Elaboración del diseño final | 200d | 2018-07-03 | 2019-04-08 | 44SS | 524d |
| 62 |  | Diseño de las colectoras elaborado | 0d | 2019-04-08 | 2019-04-08 | 61 | 524d |
| 63 |  | Construcción de las colectoras | 450d | 2019-04-09 | 2020-12-28 | 62 | 524d |
| 64 |  | Colectoras construidas | 0d | 2020-12-28 | 2020-12-28 | 63 | 524d |
| 65 | 1.3.1.1.1.1.5 | **Pagos** | 450d | 2018-07-03 | 2020-03-23 |  | 724d |
| 66 |  | Pagos BID | 450d | 2018-07-03 | 2020-03-23 | 61SS | 724d |
| 67 |  | Pagos BCIE | 450d | 2018-07-03 | 2020-03-23 | 66SS | 724d |
| 68 |  | Pagos CL | 450d | 2018-07-03 | 2020-03-23 | 67SS | 724d |
| 69 | 1.3.1.1.2 | **Cuenca de Aguacate** | 650d | 2018-07-03 | 2020-12-28 |  | 524d |
| 70 | 1.3.1.1.2.1 | **Ejecución del contrato** | 650d | 2018-07-03 | 2020-12-28 |  | 524d |

| ID | WBS | Task | Duration | Start | Finish | Predecessors | Total float |
| --- | --- | --- | --- | --- | --- | --- | --- |
| 71 |  | Elaboración del diseño final | 200d | 2018-07-03 | 2019-04-08 | 61SS | 524d |
| 72 |  | Diseño de las colectoras elaborado | 0d | 2019-04-08 | 2019-04-08 | 71 | 524d |
| 73 |  | Construcción de las colectoras | 450d | 2019-04-09 | 2020-12-28 | 72 | 524d |
| 74 |  | Colectoras construidas | 0d | 2020-12-28 | 2020-12-28 | 73 | 524d |
| 75 | 1.3.1.1.2.1.5 | **Pagos** | 650d | 2018-07-03 | 2020-12-28 |  | 524d |
| 76 |  | Pagos BID | 650d | 2018-07-03 | 2020-12-28 | 71SS | 524d |
| 77 |  | Pagos BCIE | 650d | 2018-07-03 | 2020-12-28 | 76SS | 524d |
| 78 |  | Pagos CL | 650d | 2018-07-03 | 2020-12-28 | 77SS | 524d |
| 79 | 1.3.1.1.3 | **Cuenca de Bernardino** | 645d | 2018-07-03 | 2020-12-21 |  | 529d |
| 80 |  | Elaboración del diseño final | 200d | 2018-07-03 | 2019-04-08 | 71SS | 529d |
| 81 |  | Diseño de las colectoras elaborado | 0d | 2019-04-08 | 2019-04-08 | 80 | 529d |
| 82 |  | Construcción de las colectoras | 430d | 2019-04-30 | 2020-12-21 | 81FS+15d | 529d |
| 83 |  | Colectoras construidas | 0d | 2020-12-21 | 2020-12-21 | 82 | 529d |
| 84 | 1.3.1.1.3.5 | **Pagos** | 645d | 2018-07-03 | 2020-12-21 |  | 529d |
| 85 |  | Pagos BID | 645d | 2018-07-03 | 2020-12-21 | 80SS | 529d |
| 86 |  | Pagos BEI | 645d | 2018-07-03 | 2020-12-21 | 85SS | 529d |
| 87 |  | Pagos CL | 645d | 2018-07-03 | 2020-12-21 | 86SS | 529d |
| 88 | 1.3.1.2 | **SBCC_6. Contratación de firma consultora para la supervisión de diseños y obras** | 910d | 2017-08-04 | 2021-01-28 |  | 501d |
| 89 | 1.3.1.2.1 | **Ejecución del contrato** | 910d | 2017-08-04 | 2021-01-28 |  | 501d |
| 90 |  | Pagos BID | 910d | 2017-08-04 | 2021-01-28 | 54SS | 501d |
| 91 |  | Pagos CL | 910d | 2017-08-04 | 2021-01-28 | 90SS | 501d |
| 92 | 1.3.2 | **Colectoras construidas en las cuencas de Martín Sánchez I y II, Rodeo, Cruce y Puerto Caimito** | 1565d | 2016-02-01 | 2022-01-28 |  | 0d |
| 93 | 1.3.2.1 | **LPI_2. Contratación de firma para el diseño y construcción de obras** | 1076d | 2017-11-14 | 2021-12-28 |  | 263d |
| 94 |  | Etapa previa | 65d | 2017-11-14 | 2018-02-12 | 135FS+36d | 263d |
| 95 |  | Etapa de contratación | 135d | 2018-02-13 | 2018-08-20 | 94 | 263d |
| 96 |  | Formalización del contrato | 90d | 2018-08-21 | 2018-12-24 | 95 | 263d |
| 97 | 1.3.2.1.4 | **Ejecución del contrato** | 785d | 2018-12-26 | 2021-12-28 |  | 263d |
| 98 | 1.3.2.1.4.1 | **Cuenca de Martín Sánchez I** | 785d | 2018-12-26 | 2021-12-28 |  | 263d |
| 99 |  | Elaboración del diseño final | 220d | 2018-12-26 | 2019-10-29 | 96FS+1d | 263d |
| 100 |  | Diseño de las colectoras elaborado | 0d | 2019-10-29 | 2019-10-29 | 99 | 828d |
| 101 |  | Construcción de las colectoras | 720d | 2019-03-27 | 2021-12-28 | 99SS+65d | 263d |
| 102 |  | Colectoras construidas | 0d | 2021-12-28 | 2021-12-28 | 101 | 263d |
| 103 | 1.3.2.1.4.1.5 | **Pagos** | 785d | 2018-12-26 | 2021-12-28 |  | 263d |
| 104 |  | Pagos BID | 785d | 2018-12-26 | 2021-12-28 | 99SS | 263d |
| 105 |  | Pagos CL | 785d | 2018-12-26 | 2021-12-28 | 104SS | 263d |
| 106 | 1.3.2.1.4.2 | **Cuenca de Martín Sánchez II** | 730d | 2019-03-13 | 2021-12-28 |  | 263d |
| 107 |  | Elaboración del diseño final | 200d | 2019-03-13 | 2019-12-17 | 99SS+55d | 263d |
| 108 |  | Diseño de las colectoras elaborado | 0d | 2019-12-17 | 2019-12-17 | 107 | 263d |
| 109 |  | Construcción de las colectoras | 530d | 2019-12-18 | 2021-12-28 | 108 | 263d |
| 110 |  | Colectoras construidas | 0d | 2021-12-28 | 2021-12-28 | 109 | 263d |
| 111 | 1.3.2.1.4.2.5 | **Pagos** | 730d | 2019-03-13 | 2021-12-28 |  | 263d |
| 112 |  | Pagos BID | 730d | 2019-03-13 | 2021-12-28 | 107SS | 263d |
| 113 |  | Pagos CL | 730d | 2019-03-13 | 2021-12-28 | 112SS | 263d |
| 114 | 1.3.2.1.4.3 | **Cuenca de Cruce y Puerto Caimito** | 450d | 2018-12-26 | 2020-09-15 |  | 428d |
| 115 |  | Elaboración del diseño final | 120d | 2018-12-26 | 2019-06-11 | 99SS | 428d |
| 116 |  | Diseño de las colectoras elaborado | 0d | 2019-06-11 | 2019-06-11 | 115 | 928d |
| 117 |  | Construcción de las colectoras | 330d | 2019-03-27 | 2020-06-30 | 115SS+65d | 653d |
| 118 |  | Colectoras construidas | 0d | 2020-06-30 | 2020-06-30 | 117 | 653d |
| 119 | 1.3.2.1.4.3.5 | **Pagos** | 450d | 2018-12-26 | 2020-09-15 |  | 598d |
| 120 |  | Pagos BEI | 450d | 2018-12-26 | 2020-09-15 | 115SS | 598d |
| 121 |  | Pagos CL | 450d | 2018-12-26 | 2020-09-15 | 120SS | 598d |
| 122 | 1.3.2.1.4.4 | **Cuenca de Rodeo** | 620d | 2018-12-26 | 2021-05-11 |  | 428d |
| 123 |  | Elaboración del diseño final | 200d | 2018-12-26 | 2019-10-01 | 115SS | 428d |
| 124 |  | Diseño de las colectoras elaborado | 0d | 2019-10-01 | 2019-10-01 | 123 | 848d |
| 125 |  | Construcción de las colectoras | 555d | 2019-03-27 | 2021-05-11 | 123SS+65d | 428d |
| 126 |  | Colectoras construidas | 0d | 2021-05-11 | 2021-05-11 | 125 | 428d |
| 127 | 1.3.2.1.4.4.5 | **Pagos** | 620d | 2018-12-26 | 2021-05-11 |  | 428d |
| 128 |  | Pagos BID | 620d | 2018-12-26 | 2021-05-11 | 123SS | 428d |
| 129 |  | Pagos CAF | 620d | 2018-12-26 | 2021-05-11 | 128SS | 428d |
| 130 |  | Pagos CL | 620d | 2018-12-26 | 2021-05-11 | 129SS | 428d |
| 131 | 1.3.2.2 | **SBCC_7. Contratación de firma consultora para la supervisión de diseños y obras** | 1565d | 2016-02-01 | 2022-01-28 |  | 0d |
| 132 |  | Etapa previa | 160d | 2016-02-01 | 2016-09-09 | 33SS+20d | 0d |
| 133 |  | Etapa de Expresión de interés | 45d | 2016-09-12 | 2016-11-11 | 132 | 240d |
| 134 |  | Etapa de contratación | 160d | 2016-11-14 | 2017-06-23 | 133 | 240d |
| 135 |  | Formalización del contrato | 65d | 2017-06-26 | 2017-09-22 | 134 | 240d |
| 136 |  | Ejecución del contrato | 1135d | 2017-09-25 | 2022-01-28 | 135 | 240d |
| 137 | 1.3.2.2.6 | **Pagos** | 1135d | 2017-09-25 | 2022-01-28 |  | 240d |
| 138 |  | Pagos BID | 1135d | 2017-09-25 | 2022-01-28 | 136SS | 240d |
| 139 |  | Pagos CL | 1135d | 2017-09-25 | 2022-01-28 | 138SS | 240d |
| 140 | 1.3.3 | **Colectoras construidas en las cuencas de Caimito I, Caimito II y Punta Piedras** | 1805d | 2016-02-01 | 2022-12-30 |  | 0d |

| ID | WBS | Task | Duration | Start | Finish | Predecessors | Total float |
| --- | --- | --- | --- | --- | --- | --- | --- |
| 141 | 1.3.3.1 | **LPI_3. Contratación de firma para el diseño y construcción de obras** | 1281d | 2018-01-03 | 2022-11-30 |  | 22d |
| 142 |  | Etapa previa | 65d | 2018-01-03 | 2018-04-03 | 173FS+72d | 22d |
| 143 |  | Etapa de contratación | 135d | 2018-04-04 | 2018-10-09 | 142 | 22d |
| 144 |  | Formalización del contrato | 90d | 2018-10-10 | 2019-02-12 | 143 | 22d |
| 145 | 1.3.3.1.4 | **Ejecución del contrato** | 991d | 2019-02-13 | 2022-11-30 |  | 22d |
| 146 | 1.3.3.1.4.1 | **Cuenca de Caimito I** | 955d | 2019-02-13 | 2022-10-11 |  | 22d |
| 147 |  | Elaboración del diseño final | 220d | 2019-02-13 | 2019-12-17 | 144 | 22d |
| 148 |  | Diseño de las colectoras elaborado | 0d | 2019-12-17 | 2019-12-17 | 147 | 793d |
| 149 |  | Construcción de las colectoras | 895d | 2019-05-08 | 2022-10-11 | 147SS+60d | 58d |
| 150 |  | Colectoras construidas | 0d | 2022-10-11 | 2022-10-11 | 149 | 58d |
| 151 | 1.3.3.1.4.1.5 | **Pagos** | 955d | 2019-02-13 | 2022-10-11 |  | 58d |
| 152 |  | Pagos BID | 955d | 2019-02-13 | 2022-10-11 | 147SS | 58d |
| 153 |  | Pagos CL | 955d | 2019-02-13 | 2022-10-11 | 152SS | 58d |
| 154 | 1.3.3.1.4.2 | **Cuenca de Caimito II** | 990d | 2019-02-13 | 2022-11-29 |  | 22d |
| 155 |  | Elaboración del diseño final | 220d | 2019-02-13 | 2019-12-17 | 147SS | 22d |
| 156 |  | Diseño de las colectoras elaborado | 0d | 2019-12-17 | 2019-12-17 | 155 | 793d |
| 157 |  | Construcción de las colectoras | 930d | 2019-05-08 | 2022-11-29 | 155SS+60d | 23d |
| 158 |  | Colectoras construidas | 0d | 2022-11-29 | 2022-11-29 | 157 | 23d |
| 159 | 1.3.3.1.4.2.5 | **Pagos** | 990d | 2019-02-13 | 2022-11-29 |  | 23d |
| 160 |  | Pagos BID | 990d | 2019-02-13 | 2022-11-29 | 155SS | 23d |
| 161 |  | Pagos CL | 990d | 2019-02-13 | 2022-11-29 | 160SS | 23d |
| 162 | 1.3.3.1.4.3 | **Cuenca de Punta Piedras** | 406d | 2021-05-12 | 2022-11-30 |  | 22d |
| 163 |  | Elaboración del diseño final | 120d | 2021-05-12 | 2021-10-26 | 155SS+585d | 22d |
| 164 |  | Diseño de las colectoras elaborado | 0d | 2021-10-26 | 2021-10-26 | 163 | 308d |
| 165 |  | Construcción de las colectoras | 286d | 2021-10-27 | 2022-11-30 | 163 | 22d |
| 166 |  | Colectoras construidas | 0d | 2022-11-30 | 2022-11-30 | 165 | 22d |
| 167 | 1.3.3.1.4.3.5 | **Pagos** | 405d | 2021-05-12 | 2022-11-29 |  | 23d |
| 168 |  | Pagos CL | 405d | 2021-05-12 | 2022-11-29 | 163SS | 23d |
| 169 | 1.3.3.2 | **SBCC_8. Contratación de firma consultora para la supervisión de diseños y obras** | 1805d | 2016-02-01 | 2022-12-30 |  | 0d |
| 170 |  | Etapa previa | 40d | 2016-02-01 | 2016-03-25 | 132SS | 0d |
| 171 |  | Expresión de interés | 60d | 2016-03-28 | 2016-06-17 | 170 | 1705d |
| 172 |  | Etapa de contratación | 200d | 2016-03-28 | 2016-12-30 | 170 | 0d |
| 173 |  | Formalización del contrato | 190d | 2017-01-02 | 2017-09-22 | 172 | 0d |
| 174 | 1.3.3.2.5 | **Ejecución de contrato** | 1375d | 2017-09-25 | 2022-12-30 |  | 0d |
| 175 |  | Pagos BID | 1375d | 2017-09-25 | 2022-12-30 | 173 | 0d |
| 176 |  | Pagos CL | 1375d | 2017-09-25 | 2022-12-30 | 175SS | 0d |
| 177 | 1.4 | **Producto 4: Redes de alcantarillado construidas** | 1411d | 2017-08-04 | 2022-12-30 |  | 0d |
| 178 | 1.4.1 | **Redes construidas en las cuencas de la muestra: Prudente, Aguacate y Bernardino** | 910d | 2017-08-04 | 2021-01-28 |  | 501d |
| 179 | 1.4.1.1 | **LPI_1. Contratación de firma para el diseño y construcción de obras** | 650d | 2018-07-03 | 2020-12-28 |  | 524d |
| 180 | 1.4.1.1.1 | **Cuenca de Prudente** | 650d | 2018-07-03 | 2020-12-28 |  | 524d |
| 181 | 1.4.1.1.1.1 | **Ejecución del contrato** | 650d | 2018-07-03 | 2020-12-28 |  | 524d |
| 182 |  | Elaboración del diseño final | 200d | 2018-07-03 | 2019-04-08 | 61SS | 524d |
| 183 |  | Diseño de redes elaborado | 0d | 2019-04-08 | 2019-04-08 | 182 | 524d |
| 184 |  | Construcción de las redes | 450d | 2019-04-09 | 2020-12-28 | 183 | 524d |
| 185 |  | Redes construidas | 0d | 2020-12-28 | 2020-12-28 | 184 | 524d |
| 186 | 1.4.1.1.1.1.5 | **Pagos** | 650d | 2018-07-03 | 2020-12-28 |  | 524d |
| 187 |  | Pagos BCIE | 650d | 2018-07-03 | 2020-12-28 | 182SS | 524d |
| 188 |  | Pagos CL | 650d | 2018-07-03 | 2020-12-28 | 187SS | 524d |
| 189 | 1.4.1.1.2 | **Cuenca de Aguacate** | 650d | 2018-07-03 | 2020-12-28 |  | 524d |
| 190 | 1.4.1.1.2.1 | **Ejecución del contrato** | 650d | 2018-07-03 | 2020-12-28 |  | 524d |
| 191 |  | Elaboración del diseño final | 200d | 2018-07-03 | 2019-04-08 | 71SS | 524d |
| 192 |  | Diseño de redes elaborado | 0d | 2019-04-08 | 2019-04-08 | 191 | 524d |
| 193 |  | Construcción de las redes | 450d | 2019-04-09 | 2020-12-28 | 192 | 524d |
| 194 |  | Redes construidas | 0d | 2020-12-28 | 2020-12-28 | 193 | 524d |
| 195 | 1.4.1.1.2.1.5 | **Pagos** | 650d | 2018-07-03 | 2020-12-28 |  | 524d |
| 196 |  | Pagos BCIE | 650d | 2018-07-03 | 2020-12-28 | 191SS | 524d |
| 197 |  | Pagos CL | 650d | 2018-07-03 | 2020-12-28 | 196SS | 524d |
| 198 | 1.4.1.1.3 | **Cuenca de Bernardino** | 645d | 2018-07-03 | 2020-12-21 |  | 529d |
| 199 |  | Elaboración del diseño final | 200d | 2018-07-03 | 2019-04-08 | 80SS | 529d |
| 200 |  | Diseño de las redes elaborado | 0d | 2019-04-08 | 2019-04-08 | 199 | 974d |
| 201 |  | Construcción de las redes | 430d | 2019-04-30 | 2020-12-21 | 82SS | 529d |
| 202 |  | Redes construidas | 0d | 2020-12-21 | 2020-12-21 | 201 | 529d |
| 203 | 1.4.1.1.3.5 | **Pagos** | 645d | 2018-07-03 | 2020-12-21 |  | 529d |
| 204 |  | Pagos BEI | 645d | 2018-07-03 | 2020-12-21 | 199SS | 529d |
| 205 |  | Pagos CL | 645d | 2018-07-03 | 2020-12-21 | 204SS | 529d |
| 206 | 1.4.1.2 | **SBCC_6. Contratación de firma consultora para la supervisión de diseños y obras** | 910d | 2017-08-04 | 2021-01-28 |  | 501d |
| 207 | 1.4.1.2.1 | **Ejecución del contrato** | 910d | 2017-08-04 | 2021-01-28 |  | 501d |
| 208 |  | Pagos BID | 910d | 2017-08-04 | 2021-01-28 | 90SS | 501d |
| 209 |  | Pagos CL | 910d | 2017-08-04 | 2021-01-28 | 208SS | 501d |
| 210 | 1.4.2 | **Redes construidas en las cuencas de Martín Sánchez I y II, Rodeo y Puerto Caimito** | 1135d | 2017-09-25 | 2022-01-28 |  | 240d |

| ID | WBS | Task | Duration | Start | Finish | Predecessors | Total float |
| --- | --- | --- | --- | --- | --- | --- | --- |
| 211 | 1.4.2.1 | **LPI_2. Contratación de firma para el diseño y construcción de obras** | 785d | 2018-12-26 | 2021-12-28 |  | 263d |
| 212 | 1.4.2.1.1 | **Cuenca de Martín Sánchez I** | 785d | 2018-12-26 | 2021-12-28 |  | 263d |
| 213 | 1.4.2.1.1.1 | **Ejecución del contrato** | 785d | 2018-12-26 | 2021-12-28 |  | 263d |
| 214 |  | Elaboración del diseño final | 220d | 2018-12-26 | 2019-10-29 | 99SS | 263d |
| 215 |  | Diseño de las redes elaborado | 0d | 2019-10-29 | 2019-10-29 | 214 | 828d |
| 216 |  | Construcción de las colectoras | 720d | 2019-03-27 | 2021-12-28 | 214SS+65d | 263d |
| 217 |  | Redes construidas | 0d | 2021-12-28 | 2021-12-28 | 216 | 263d |
| 218 | 1.4.2.1.1.1.5 | **Pagos** | 785d | 2018-12-26 | 2021-12-28 |  | 263d |
| 219 |  | Pagos CAF | 785d | 2018-12-26 | 2021-12-28 | 214SS | 263d |
| 220 |  | Pagos BCIE | 785d | 2018-12-26 | 2021-12-28 | 219SS | 263d |
| 221 |  | Pagos BEI | 785d | 2018-12-26 | 2021-12-28 | 220SS | 263d |
| 222 |  | Pagos CL | 785d | 2018-12-26 | 2021-12-28 | 221SS | 263d |
| 223 | 1.4.2.1.2 | **Cuenca de Martín Sánchez II** | 730d | 2019-03-13 | 2021-12-28 |  | 263d |
| 224 | 1.4.2.1.2.1 | **Ejecución del contrato** | 730d | 2019-03-13 | 2021-12-28 |  | 263d |
| 225 |  | Elaboración del diseño final | 200d | 2019-03-13 | 2019-12-17 | 214SS+55d | 263d |
| 226 |  | Diseño de las redes elaborado | 0d | 2019-12-17 | 2019-12-17 | 225 | 793d |
| 227 |  | Construcción de las colectoras | 530d | 2019-12-18 | 2021-12-28 | 225 | 263d |
| 228 |  | Redes construidas | 0d | 2021-12-28 | 2021-12-28 | 227 | 263d |
| 229 | 1.4.2.1.2.1.5 | **Pagos** | 730d | 2019-03-13 | 2021-12-28 |  | 263d |
| 230 |  | Pagos CAF | 730d | 2019-03-13 | 2021-12-28 | 225SS | 263d |
| 231 |  | Pagos BCIE | 730d | 2019-03-13 | 2021-12-28 | 230SS | 263d |
| 232 |  | Pagos CL | 730d | 2019-03-13 | 2021-12-28 | 231SS | 263d |
| 233 | 1.4.2.1.4 | **Cuenca de Puerto Caimito** | 450d | 2018-12-26 | 2020-09-15 |  | 598d |
| 234 | 1.4.2.1.4.1 | **Ejecución del contrato** | 450d | 2018-12-26 | 2020-09-15 |  | 598d |
| 235 |  | Elaboración del diseño final | 120d | 2018-12-26 | 2019-06-11 | 115SS | 598d |
| 236 |  | Diseño de las redes elaborado | 0d | 2019-06-11 | 2019-06-11 | 235 | 598d |
| 237 |  | Construcción de las colectoras | 330d | 2019-06-12 | 2020-09-15 | 236 | 598d |
| 238 |  | Redes construidas | 0d | 2020-09-15 | 2020-09-15 | 237 | 598d |
| 239 | 1.4.2.1.4.1.5 | **Pagos** | 450d | 2018-12-26 | 2020-09-15 |  | 598d |
| 240 |  | Pagos CL | 450d | 2018-12-26 | 2020-09-15 | 235SS | 598d |
| 241 | 1.4.2.1.3 | **Cuenca de Rodeo** | 620d | 2018-12-26 | 2021-05-11 |  | 428d |
| 242 | 1.4.2.1.3.1 | **Ejecución del contrato** | 620d | 2018-12-26 | 2021-05-11 |  | 428d |
| 243 |  | Elaboración del diseño final | 200d | 2018-12-26 | 2019-10-01 | 123SS | 428d |
| 244 |  | Diseño de las redes elaborado | 0d | 2019-10-01 | 2019-10-01 | 243 | 848d |
| 245 |  | Construcción de las colectoras | 555d | 2019-03-27 | 2021-05-11 | 243SS+65d | 428d |
| 246 |  | Redes construidas | 0d | 2021-05-11 | 2021-05-11 | 245 | 428d |
| 247 | 1.4.2.1.3.1.5 | **Pagos** | 620d | 2018-12-26 | 2021-05-11 |  | 428d |
| 248 |  | Pagos CAF | 620d | 2018-12-26 | 2021-05-11 | 243SS | 428d |
| 249 |  | Pagos BCIE | 620d | 2018-12-26 | 2021-05-11 | 248SS | 428d |
| 250 |  | Pagos CL | 620d | 2018-12-26 | 2021-05-11 | 249SS | 428d |
| 251 | 1.4.2.2 | **SBCC_7. Contratación de firma consultora para la supervisión de diseños y obras** | 1135d | 2017-09-25 | 2022-01-28 |  | 240d |
| 252 | 1.4.2.2.1 | **Ejecución de contrato** | 1135d | 2017-09-25 | 2022-01-28 |  | 240d |
| 253 |  | Pagos BID | 1135d | 2017-09-25 | 2022-01-28 | 138SS | 240d |
| 254 |  | Pagos CL | 1135d | 2017-09-25 | 2022-01-28 | 253SS | 240d |
| 255 | 1.4.3 | **Redes construidas en las cuencas de Caimito I y Caimito II** | 1375d | 2017-09-25 | 2022-12-30 |  | 0d |
| 256 | 1.4.3.1 | **LPI_3. Contratación de firma para el diseño y construcción de obras** | 990d | 2019-02-13 | 2022-11-29 |  | 23d |
| 257 | 1.4.3.1.1 | **Cuenca de Caimito I** | 955d | 2019-02-13 | 2022-10-11 |  | 58d |
| 258 | 1.4.3.1.1.1 | **Ejecución del contrato** | 955d | 2019-02-13 | 2022-10-11 |  | 58d |
| 259 |  | Elaboración del diseño final | 220d | 2019-02-13 | 2019-12-17 | 147SS | 58d |
| 260 |  | Diseño de las redes elaborado | 0d | 2019-12-17 | 2019-12-17 | 259 | 793d |
| 261 |  | Construcción de las colectoras | 895d | 2019-05-08 | 2022-10-11 | 259SS+60d | 58d |
| 262 |  | Redes construidas | 0d | 2022-10-11 | 2022-10-11 | 261 | 58d |
| 263 | 1.4.3.1.1.1.5 | **Pagos** | 955d | 2019-02-13 | 2022-10-11 |  | 58d |
| 264 |  | Pagos CL | 955d | 2019-02-13 | 2022-10-11 | 259SS | 58d |
| 265 | 1.4.3.1.2 | **Cuenca de Caimito II** | 990d | 2019-02-13 | 2022-11-29 |  | 23d |
| 266 | 1.4.3.1.2.1 | **Ejecución del contrato** | 990d | 2019-02-13 | 2022-11-29 |  | 23d |
| 267 |  | Elaboración del diseño final | 220d | 2019-02-13 | 2019-12-17 | 155SS | 793d |
| 268 |  | Diseño de las redes elaborado | 0d | 2019-12-17 | 2019-12-17 | 267 | 793d |
| 269 |  | Construcción de las colectoras | 930d | 2019-05-08 | 2022-11-29 | 157SS | 23d |
| 270 |  | Redes construidas | 0d | 2022-11-29 | 2022-11-29 | 269 | 23d |
| 271 | 1.4.3.1.2.1.5 | **Pagos** | 530d | 2019-02-13 | 2021-02-23 |  | 483d |
| 272 |  | Pagos CL | 530d | 2019-02-13 | 2021-02-23 | 264SS | 483d |
| 273 | 1.4.3.2 | **SBCC_8. Contratación de firma consultora para la supervisión de diseños y obras** | 1375d | 2017-09-25 | 2022-12-30 |  | 0d |
| 274 | 1.4.3.2.1 | **Ejecución de contrato** | 1375d | 2017-09-25 | 2022-12-30 |  | 0d |
| 275 |  | Pagos BID | 1375d | 2017-09-25 | 2022-12-30 | 175SS | 0d |
| 276 |  | Pagos CL | 1375d | 2017-09-25 | 2022-12-30 | 275SS | 0d |
| 277 | 1.5 | **Producto 5: Conexiones domiciliarias construidas** | 1411d | 2017-08-04 | 2022-12-30 |  | 0d |
| 278 | 1.5.1 | **Conexiones domiciliarias construidas en las cuencas de Prudente, Aguacate y Bernardino** | 910d | 2017-08-04 | 2021-01-28 |  | 501d |
| 279 | 1.5.1.1 | **LPI_1. Contratación de firma constructora para la instalación de conexiones domiciliarias** | 450d | 2019-04-09 | 2020-12-28 |  | 524d |
| 280 | 1.5.1.1.1 | **Cuenca de Prudente** | 450d | 2019-04-09 | 2020-12-28 |  | 524d |

| ID | WBS | Task | Duration | Start | Finish | Predecessors | Total float |
| --- | --- | --- | --- | --- | --- | --- | --- |
| 281 | 1.5.1.1.1.1 | **Ejecución del contrato** | 450d | 2019-04-09 | 2020-12-28 |  | 524d |
| 282 |  | Construcción de las conexiones domiciliarias | 450d | 2019-04-09 | 2020-12-28 | 184SS | 524d |
| 283 |  | Conexiones domiciliarias construidas | 0d | 2020-12-28 | 2020-12-28 | 282 | 524d |
| 284 | 1.5.1.1.1.1.3 | **Pagos** | 450d | 2019-04-09 | 2020-12-28 |  | 524d |
| 285 |  | Pagos BCIE | 450d | 2019-04-09 | 2020-12-28 | 282SS | 524d |
| 286 |  | Pagos CL | 450d | 2019-04-09 | 2020-12-28 | 285SS | 524d |
| 287 | 1.5.1.1.2 | **Cuenca de Aguacate** | 450d | 2019-04-09 | 2020-12-28 |  | 524d |
| 288 | 1.5.1.1.2.1 | **Ejecución del contrato** | 450d | 2019-04-09 | 2020-12-28 |  | 524d |
| 289 |  | Construcción de las conexiones domiciliarias | 450d | 2019-04-09 | 2020-12-28 | 193SS | 524d |
| 290 |  | Conexiones domiciliarias construidas | 0d | 2020-12-28 | 2020-12-28 | 289 | 524d |
| 291 | 1.5.1.1.2.1.3 | **Pagos** | 450d | 2019-04-09 | 2020-12-28 |  | 524d |
| 292 |  | Pagos BCIE | 450d | 2019-04-09 | 2020-12-28 | 289SS | 524d |
| 293 |  | Pagos CL | 450d | 2019-04-09 | 2020-12-28 | 292SS | 524d |
| 294 | 1.5.1.1.3 | **Cuenca de Bernardino** | 430d | 2019-04-30 | 2020-12-21 |  | 529d |
| 295 | 1.5.1.1.3.1 | **Ejecución del contrato** | 430d | 2019-04-30 | 2020-12-21 |  | 529d |
| 296 |  | Construcción de las conexiones domiciliarias | 430d | 2019-04-30 | 2020-12-21 | 201SS | 529d |
| 297 |  | Conexiones domiciliarias construidas | 0d | 2020-12-21 | 2020-12-21 | 296 | 529d |
| 298 | 1.5.1.1.3.1.3 | **Pagos** | 430d | 2019-04-30 | 2020-12-21 |  | 529d |
| 299 |  | Pagos BEI | 430d | 2019-04-30 | 2020-12-21 | 296SS | 529d |
| 300 |  | Pagos CL | 430d | 2019-04-30 | 2020-12-21 | 299SS | 529d |
| 301 | 1.5.1.2 | **SBCC_6. Contratación de firma consultora para la supervisión de diseños y obras** | 910d | 2017-08-04 | 2021-01-28 |  | 501d |
| 302 | 1.5.1.2.1 | **Ejecución del contrato** | 910d | 2017-08-04 | 2021-01-28 |  | 501d |
| 303 |  | Pagos BID | 910d | 2017-08-04 | 2021-01-28 | 208SS | 501d |
| 304 |  | Pagos CL | 910d | 2017-08-04 | 2021-01-28 | 303SS | 501d |
| 305 | 1.5.2 | **Conexiones domiciliarias construidas en las cuencas Martín Sánchez I, Martín Sánchez II, Rodeo y Puerto Caimito** | 1135d | 2017-09-25 | 2022-01-28 |  | 240d |
| 306 | 1.5.2.1 | **LPI_2. Contratación de firma constructora para la instalación de conexiones domiciliarias** | 720d | 2019-03-27 | 2021-12-28 |  | 263d |
| 307 | 1.5.2.1.1 | **Cuenca de Martín Sánchez I** | 720d | 2019-03-27 | 2021-12-28 |  | 263d |
| 308 | 1.5.2.1.1.1 | **Ejecución del contrato** | 720d | 2019-03-27 | 2021-12-28 |  | 263d |
| 309 |  | Construcción de conexiones domiciliarias | 720d | 2019-03-27 | 2021-12-28 | 216SS | 263d |
| 310 |  | Conexiones domiciliarias construidas | 0d | 2021-12-28 | 2021-12-28 | 309 | 263d |
| 311 | 1.5.2.1.1.1.3 | **Pagos** | 720d | 2019-03-27 | 2021-12-28 |  | 263d |
| 312 |  | Pagos CL | 720d | 2019-03-27 | 2021-12-28 | 309SS | 263d |
| 313 | 1.5.2.1.2 | **Cuenca de Martín Sánchez II** | 530d | 2019-12-18 | 2021-12-28 |  | 263d |
| 314 | 1.5.2.1.2.1 | **Ejecución del contrato** | 530d | 2019-12-18 | 2021-12-28 |  | 263d |
| 315 |  | Construcción de conexiones domiciliarias | 530d | 2019-12-18 | 2021-12-28 | 227SS | 263d |
| 316 |  | Conexiones domiciliarias construidas | 0d | 2021-12-28 | 2021-12-28 | 315 | 263d |
| 317 | 1.5.2.1.2.1.3 | **Pagos** | 530d | 2019-12-18 | 2021-12-28 |  | 263d |
| 318 |  | Pagos BCIE | 530d | 2019-12-18 | 2021-12-28 | 315SS | 263d |
| 319 |  | Pagos CL | 530d | 2019-12-18 | 2021-12-28 | 318SS | 263d |
| 320 | 1.5.2.1.3 | **Cuenca de Rodeo** | 555d | 2019-03-27 | 2021-05-11 |  | 428d |
| 321 | 1.5.2.1.3.1 | **Ejecución del contrato** | 555d | 2019-03-27 | 2021-05-11 |  | 428d |
| 322 |  | Construcción de conexiones domiciliarias | 555d | 2019-03-27 | 2021-05-11 | 245SS | 428d |
| 323 |  | Conexiones domiciliarias construidas | 0d | 2021-05-11 | 2021-05-11 | 322 | 428d |
| 324 | 1.5.2.1.3.1.3 | **Pagos** | 555d | 2019-03-27 | 2021-05-11 |  | 428d |
| 325 |  | Pagos BCIE | 555d | 2019-03-27 | 2021-05-11 | 322SS | 428d |
| 326 |  | Pagos CL | 555d | 2019-03-27 | 2021-05-11 | 325SS | 428d |
| 327 | 1.5.2.1.4 | **Cuenca de Puerto Caimito** | 330d | 2019-06-12 | 2020-09-15 |  | 598d |
| 328 | 1.5.2.1.4.1 | **Ejecución del contrato** | 330d | 2019-06-12 | 2020-09-15 |  | 598d |
| 329 |  | Construcción de conexiones domiciliarias | 330d | 2019-06-12 | 2020-09-15 | 237SS | 598d |
| 330 |  | Conexiones domiciliarias construidas | 0d | 2020-09-15 | 2020-09-15 | 329 | 598d |
| 331 | 1.5.2.1.4.1.3 | **Pagos** | 330d | 2019-06-12 | 2020-09-15 |  | 598d |
| 332 |  | Pagos CL | 330d | 2019-06-12 | 2020-09-15 | 329SS | 598d |
| 333 | 1.5.2.2 | **SBCC_7. Contratación de firma consultora para la supervisión de diseños y obras** | 1135d | 2017-09-25 | 2022-01-28 |  | 240d |
| 334 | 1.5.2.2.1 | **Ejecución de contrato** | 1135d | 2017-09-25 | 2022-01-28 |  | 240d |
| 335 |  | Pagos BID | 1135d | 2017-09-25 | 2022-01-28 | 253SS | 240d |
| 336 |  | Pagos CL | 1135d | 2017-09-25 | 2022-01-28 | 335SS | 240d |
| 337 | 1.5.3 | **Conexiones domiciliarias construidas en las cuencas de Caimito I y Caimito II** | 1375d | 2017-09-25 | 2022-12-30 |  | 0d |
| 338 | 1.5.3.1 | **LPI_3. Contratación de firma para el diseño y construcción de obras** | 930d | 2019-05-08 | 2022-11-29 |  | 23d |
| 339 | 1.5.3.1.1 | **Cuenca de Caimito I** | 895d | 2019-05-08 | 2022-10-11 |  | 58d |
| 340 | 1.5.3.1.1.1 | **Ejecución del contrato** | 895d | 2019-05-08 | 2022-10-11 |  | 58d |
| 341 |  | Construcción de conexiones domiciliarias | 895d | 2019-05-08 | 2022-10-11 | 261SS | 58d |
| 342 |  | Conexiones domiciliarias construidas | 0d | 2022-10-11 | 2022-10-11 | 341 | 58d |
| 343 | 1.5.3.1.1.1.3 | **Pagos** | 895d | 2019-05-08 | 2022-10-11 |  | 58d |
| 344 |  | Pagos CL | 895d | 2019-05-08 | 2022-10-11 | 341SS | 58d |
| 345 | 1.5.3.1.2 | **Cuenca de Caimito II** | 930d | 2019-05-08 | 2022-11-29 |  | 23d |
| 346 | 1.5.3.1.2.1 | **Ejecución del contrato** | 930d | 2019-05-08 | 2022-11-29 |  | 23d |
| 347 |  | Construcción de conexiones domiciliarias | 930d | 2019-05-08 | 2022-11-29 | 269SS | 23d |
| 348 |  | Conexiones domiciliarias construidas | 0d | 2022-11-29 | 2022-11-29 | 347 | 23d |
| 349 | 1.5.3.1.2.1.3 | **Pagos** | 930d | 2019-05-08 | 2022-11-29 |  | 23d |
| 350 |  | Pagos CL | 930d | 2019-05-08 | 2022-11-29 | 347SS | 23d |

| ID | WBS | Task | Duration | Start | Finish | Predecessors | Total float |
| --- | --- | --- | --- | --- | --- | --- | --- |
| 351 | 1.5.3.2 | **SBCC_8. Contratación de firma consultora para la supervisión de diseños y obras** | 1375d | 2017-09-25 | 2022-12-30 |  | 0d |
| 352 | 1.5.3.2.1 | **Ejecución de contrato** | 1375d | 2017-09-25 | 2022-12-30 |  | 0d |
| 353 |  | Pagos BID | 1375d | 2017-09-25 | 2022-12-30 | 275SS | 0d |
| 354 |  | Pagos CL | 1375d | 2017-09-25 | 2022-12-30 | 353SS | 0d |
| 355 | 1.6 | **Producto 6: Primer módulo de la PTAR e interceptor (Caimito) operando** | 260d | 2021-10-22 | 2022-10-21 |  | 50d |
| 356 | 1.6.1 | **LPI_1. Contratación de firma para la Operación y Mantenimiento de la PTAR Caimito** | 260d | 2021-10-22 | 2022-10-21 |  | 50d |
| 357 | 1.6.1.1 | **Ejecución del contrato** | 260d | 2021-10-22 | 2022-10-21 |  | 50d |
| 358 |  | Traspaso de obra para O&M | 0d | 2021-10-22 | 2021-10-22 | 26FS+4d | 50d |
| 359 |  | Ejecución de la O&M | 260d | 2021-10-25 | 2022-10-21 | 358 | 50d |
| 360 |  | O&M realizada | 0d | 2022-10-21 | 2022-10-21 | 359 | 50d |
| 361 | 1.6.1.1.4 | **Pagos** | 260d | 2021-10-25 | 2022-10-21 |  | 50d |
| 362 |  | Pagos CL | 260d | 2021-10-25 | 2022-10-21 | 359SS | 50d |
| 363 | 2 | **Componente 2: Fortalecimiento Institucional** | 1540d | 2017-02-06 | 2022-12-30 |  | 0d |
| 364 | 2.1 | **Producto 7: Actividades de capacitación en O&M e implementación del SIG desarrolladas** | 1470d | 2017-05-09 | 2022-12-26 |  | 4d |
| 365 | 2.1.1 | **CCIN_20. Consultoría individual para la elaboración del Plan de Capacitación para la UCP** | 150d | 2017-05-09 | 2017-12-04 |  | 4d |
| 366 |  | Etapa previa | 20d | 2017-05-09 | 2017-06-05 | 13FS+22d | 4d |
| 367 |  | Etapa de contratación | 45d | 2017-06-06 | 2017-08-07 | 366 | 4d |
| 368 |  | Formalización del contrato | 20d | 2017-08-08 | 2017-09-04 | 367 | 4d |
| 369 |  | Ejecución del contrato | 65d | 2017-09-05 | 2017-12-04 | 368 | 4d |
| 370 |  | Plan de capacitación elaborado | 0d | 2017-12-04 | 2017-12-04 | 369 | 1324d |
| 371 | 2.1.1.6 | **Pagos** | 65d | 2017-09-05 | 2017-12-04 |  | 1324d |
| 372 |  | Pagos BID | 65d | 2017-09-05 | 2017-12-04 | 369SS | 1324d |
| 373 |  | Pagos CAF | 65d | 2017-09-05 | 2017-12-04 | 372SS | 1324d |
| 374 |  | Pagos CL | 65d | 2017-09-05 | 2017-12-04 | 373SS | 1324d |
| 375 | 2.1.2 | **CP_24. Implementación del plan de capacitación para la UCP en temas de habilidades blandas y metodologías de gestión de proyectos** | 615d | 2017-12-05 | 2020-04-13 |  | 709d |
| 376 |  | Etapa previa | 20d | 2017-12-05 | 2018-01-01 | 369 | 709d |
| 377 |  | Etapa de contratación | 45d | 2018-01-02 | 2018-03-05 | 376 | 709d |
| 378 |  | Formalización del contrato | 20d | 2018-03-06 | 2018-04-02 | 377 | 709d |
| 379 |  | Ejecución del contrato | 530d | 2018-04-03 | 2020-04-13 | 378 | 709d |
| 380 | 2.1.2.5 | **Pagos** | 530d | 2018-04-03 | 2020-04-13 |  | 709d |
| 381 |  | Pagos BID | 530d | 2018-04-03 | 2020-04-13 | 379SS | 709d |
| 382 |  | Pagos CAF | 530d | 2018-04-03 | 2020-04-13 | 381SS | 709d |
| 383 |  | Pagos CL | 530d | 2018-04-03 | 2020-04-13 | 382SS | 709d |
| 384 |  | Desarrollo de otras actividades a definir | 1320d | 2017-12-05 | 2022-12-26 | 369 | 4d |
| 385 |  | Actividades de capacitación implementadas | 0d | 2022-12-26 | 2022-12-26 | 379, 384 | 4d |
| 386 | 2.2 | **Producto 8: Instrumento reglamentario del Convenio IDAAN – UCP aprobado** | 300d | 2017-02-06 | 2018-03-30 |  | 1240d |
| 387 | 2.2.1 | **SCC_9. Consultoría para la elaboración del instrumento reglamentario para la implementación del Convenio IDAAN/MINSA** | 300d | 2017-02-06 | 2018-03-30 |  | 1240d |
| 388 |  | Etapa previa | 20d | 2017-02-06 | 2017-03-03 | 13FS-44d | 1240d |
| 389 |  | Expresión de interés | 30d | 2017-03-06 | 2017-04-14 | 388 | 1240d |
| 390 |  | Etapa de contratación | 100d | 2017-04-17 | 2017-09-01 | 389 | 1240d |
| 391 |  | Formalización del contrato | 20d | 2017-09-04 | 2017-09-29 | 390 | 1240d |
| 392 |  | Ejecución del contrato | 130d | 2017-10-02 | 2018-03-30 | 391 | 1240d |
| 393 |  | Instrumento reglamentario elaborado | 0d | 2018-03-30 | 2018-03-30 | 392 | 1240d |
| 394 | 2.2.1.7 | **Pagos** | 130d | 2017-10-02 | 2018-03-30 |  | 1240d |
| 395 |  | Pagos BID | 130d | 2017-10-02 | 2018-03-30 | 392SS | 1240d |
| 396 |  | Pagos CL | 130d | 2017-10-02 | 2018-03-30 | 395SS | 1240d |
| 397 |  | Recursos adicionales | 130d | 2017-10-02 | 2018-03-30 | 396SS | 1240d |
| 398 | 2.3 | **Producto 9: Catastro técnico para verificación de los sistemas pluvial y sanitario existentes, realizada** | 730d | 2017-06-14 | 2020-03-31 |  | 718d |
| 399 | 2.3.1 | **SBCC_14. Consultoría para realizar el catastro técnico para verificación de los sistemas de saneamiento** | 730d | 2017-06-14 | 2020-03-31 |  | 718d |
| 400 |  | Etapa previa | 20d | 2017-06-14 | 2017-07-11 | 13FS+48d | 718d |
| 401 |  | Expresión de interés | 30d | 2017-07-12 | 2017-08-22 | 400 | 718d |
| 402 |  | Etapa de contratación | 130d | 2017-08-23 | 2018-02-20 | 401 | 718d |
| 403 |  | Formalización del contrato | 20d | 2018-02-21 | 2018-03-20 | 402 | 718d |
| 404 |  | Ejecución del contrato | 530d | 2018-03-21 | 2020-03-31 | 403 | 718d |
| 405 |  | Catastro técnico realizado - Año 2 | 0d | 2019-03-25 | 2019-03-25 | 404SS+264d | 984d |
| 406 |  | Catastro técnico realizado- Año 3 | 0d | 2020-03-31 | 2020-03-31 | 404 | 718d |
| 407 | 2.3.1.8 | **Pagos** | 530d | 2018-03-21 | 2020-03-31 |  | 718d |
| 408 |  | Pagos BID | 530d | 2018-03-21 | 2020-03-31 | 404SS | 718d |
| 409 |  | Pagos CAF | 530d | 2018-03-21 | 2020-03-31 | 408SS | 718d |
| 410 |  | Pagos CL | 530d | 2018-03-21 | 2020-03-31 | 409SS | 718d |
| 411 | 2.4 | **Producto 10: Programa de monitoreo de la calidad de agua de ríos y quebradas del PSACH** | 935d | 2019-06-03 | 2022-12-30 |  | 0d |
| 412 | 2.4.1 | **SBC_13. Consultoría para la realización de actividades del Programa de monitoreo de la calidad del agua** | 935d | 2019-06-03 | 2022-12-30 |  | 0d |
| 413 |  | Etapa previa | 20d | 2019-06-03 | 2019-06-28 | 13FS+561d | 0d |
| 414 |  | Expresión de interés | 30d | 2019-07-01 | 2019-08-09 | 413 | 0d |
| 415 |  | Etapa de contratación | 130d | 2019-08-12 | 2020-02-07 | 414 | 0d |
| 416 |  | Formalización del contrato | 20d | 2020-02-10 | 2020-03-06 | 415 | 0d |
| 417 |  | Ejecución del contrato | 735d | 2020-03-09 | 2022-12-30 | 416 | 0d |
| 418 |  | Hito 1: Línea de base actualizada | 0d | 2020-03-09 | 2020-03-09 | 417SS | 475d |
| 419 |  | Hito 2: Campaña de monitoreo realizada - Año 5 | 0d | 2021-03-05 | 2021-03-05 | 418FS+260d | 475d |
| 420 |  | Hito 2: Campaña de monitoreo realizada - Año 6 | 0d | 2022-12-30 | 2022-12-30 | 417 | 0d |

| ID | WBS | Task | Duration | Start | Finish | Predecessors | Total float |
| --- | --- | --- | --- | --- | --- | --- | --- |
| 421 | 2.4.1.9 | **Pagos** | 735d | 2020-03-09 | 2022-12-30 |  | 0d |
| 422 |  | Pagos BID | 735d | 2020-03-09 | 2022-12-30 | 417SS | 0d |
| 423 |  | Pagos CAF | 735d | 2020-03-09 | 2022-12-30 | 422SS | 0d |
| 424 |  | Pagos CL | 735d | 2020-03-09 | 2022-12-30 | 423SS | 0d |
| 425 |  | Recusos adicionales | 735d | 2020-03-09 | 2022-12-30 | 424SS | 0d |
| 426 | 2.5 | **Producto 11: Programa de monitoreo y control de descargas industriales al alcantarillado sanitario, implementado** | 730d | 2020-02-13 | 2022-11-30 |  | 22d |
| 427 | 2.5.1 | **SBCC_15. Consultoría para la elaboración del programa de monitoreo y control de descargas industriales** | 730d | 2020-02-13 | 2022-11-30 |  | 22d |
| 428 |  | Etapa previa | 20d | 2020-02-13 | 2020-03-11 | 13FS+744d | 22d |
| 429 |  | Expresión de interés | 30d | 2020-03-12 | 2020-04-22 | 428 | 22d |
| 430 |  | Etapa de contratación | 130d | 2020-04-23 | 2020-10-21 | 429 | 22d |
| 431 |  | Formalización del contrato | 20d | 2020-10-22 | 2020-11-18 | 430 | 22d |
| 432 |  | Ejecución del contrato | 530d | 2020-11-19 | 2022-11-30 | 431 | 22d |
| 433 |  | Hito 1: Actualización de grandes contaminantes de descargas de aguas residuales no domésticos realizada | 0d | 2020-02-13 | 2020-02-13 | 428SS | 224d |
| 434 |  | Hito 2: Programa de monitoreo diseñado | 0d | 2021-02-16 | 2021-02-16 | 433FS+264d | 224d |
| 435 |  | Hito 3: Campaña de monitoreo realizada - Año 5 | 0d | 2022-02-21 | 2022-02-21 | 434SS+264d | 224d |
| 436 |  | Hito 3: Campaña de monitoreo realizada - Año 6 | 0d | 2022-11-30 | 2022-11-30 | 432 | 22d |
| 437 | 2.5.1.10 | **Pagos** | 530d | 2020-11-19 | 2022-11-30 |  | 22d |
| 438 |  | Pagos BID | 530d | 2020-11-19 | 2022-11-30 | 432SS | 22d |
| 439 |  | Pagos CAF | 530d | 2020-11-19 | 2022-11-30 | 438SS | 22d |
| 440 |  | Pagos CL | 530d | 2020-11-19 | 2022-11-30 | 439SS | 22d |
| 441 | 2.6 | **Producto 12: Plan de Fortalecimiento de DISAPAS implementado** | 730d | 2020-02-13 | 2022-11-30 |  | 22d |
| 442 | 2.6.1 | **SBCC_10. Consultoría para la elaboración de un diagnóstico y de un plan de fortalecimiento para la DISAPAS, incluyendo la implementación** | 730d | 2020-02-13 | 2022-11-30 |  | 22d |
| 443 |  | Etapa previa | 20d | 2020-02-13 | 2020-03-11 | 428SS | 22d |
| 444 |  | Expresión de interés | 30d | 2020-03-12 | 2020-04-22 | 443 | 22d |
| 445 |  | Etapa de contratación | 130d | 2020-04-23 | 2020-10-21 | 444 | 22d |
| 446 |  | Formalización del contrato | 20d | 2020-10-22 | 2020-11-18 | 445 | 22d |
| 447 |  | Ejecución del contrato | 530d | 2020-11-19 | 2022-11-30 | 446 | 22d |
| 448 |  | Hito 1: Diagnóstico y plan diseñados | 0d | 2020-02-13 | 2020-02-13 | 443SS | 264d |
| 449 |  | Hito 2: Actividades del Plan desarrolladas - Año 4 | 0d | 2020-12-22 | 2020-12-22 | 448FS+224d | 264d |
| 450 |  | Hito 2: Actividades del Plan desarrolladas - Año 5 | 0d | 2021-12-27 | 2021-12-27 | 449FS+264d | 264d |
| 451 |  | Hito 2: Actividades del Plan desarrolladas - Año 6 | 0d | 2022-11-30 | 2022-11-30 | 447 | 22d |
| 452 | 2.6.1.10 | **Pagos** | 530d | 2020-11-19 | 2022-11-30 |  | 22d |
| 453 |  | Pagos BID | 530d | 2020-11-19 | 2022-11-30 | 447SS | 22d |
| 454 |  | Pagos CL | 530d | 2020-11-19 | 2022-11-30 | 453SS | 22d |
| 455 |  | Recursos adicionales | 530d | 2020-11-19 | 2022-11-30 | 454SS | 22d |
| 456 | 2.7 | **Producto 13: Actividades para fortalecer la sostenibilidad del sistema de saneamiento, implementadas** | 1081d | 2017-12-21 | 2022-02-10 |  | 231d |
| 457 | 2.7.1 | **SBCC_11. Consultoría para la elaboración e implementación de un plan de fortalecimiento para el sector saneamiento** | 730d | 2018-03-23 | 2021-01-07 |  | 231d |
| 458 |  | Etapa previa | 20d | 2018-03-23 | 2018-04-19 | 13FS+250d | 231d |
| 459 |  | Expresión de interés | 30d | 2018-04-20 | 2018-05-31 | 458 | 231d |
| 460 |  | Etapa de contratación | 130d | 2018-06-01 | 2018-11-29 | 459 | 231d |
| 461 |  | Formalización del contrato | 20d | 2018-11-30 | 2018-12-27 | 460 | 231d |
| 462 |  | Ejecución del contrato | 530d | 2018-12-28 | 2021-01-07 | 461 | 231d |
| 463 |  | Hito 1: Instrumento para reglamentar el funcionamiento del Comité elaborado | 0d | 2019-03-29 | 2019-03-29 | 462SS+66d | 231d |
| 464 |  | Hito 2: Actividades de transferencia de conocimientos- Año 3 | 0d | 2020-03-27 | 2020-03-27 | 463FS+260d | 720d |
| 465 |  | Hito 2: Actividades de transferencia de conocimientos - Año 4 | 0d | 2021-01-07 | 2021-01-07 | 462 | 516d |
| 466 | 2.7.1.9 | **Pagos** | 530d | 2018-12-28 | 2021-01-07 |  | 516d |
| 467 |  | Pagos BID | 530d | 2018-12-28 | 2021-01-07 | 462SS | 516d |
| 468 |  | Pagos CAF | 530d | 2018-12-28 | 2021-01-07 | 467SS | 516d |
| 469 |  | Pagos CL | 530d | 2018-12-28 | 2021-01-07 | 468SS | 516d |
| 470 | 2.7.2 | **CP_5. Realización de actividades complementarias del plan de fortalecimiento** | 485d | 2020-04-03 | 2022-02-10 |  | 231d |
| 471 |  | Etapa previa | 20d | 2020-04-03 | 2020-04-30 | 463FS+264d | 231d |
| 472 |  | Etapa de contratación | 45d | 2020-05-01 | 2020-07-02 | 471 | 231d |
| 473 |  | Formalización del contrato | 20d | 2020-07-03 | 2020-07-30 | 472 | 231d |
| 474 |  | Ejecución del contrato | 400d | 2020-07-31 | 2022-02-10 | 473 | 231d |
| 475 |  | Hito 2: Actividades de transferencia de conocimientos - Año 5 | 0d | 2022-02-10 | 2022-02-10 | 474 | 231d |
| 476 | 2.7.2.6 | **Pagos** | 400d | 2020-07-31 | 2022-02-10 |  | 231d |
| 477 |  | Pagos BID | 400d | 2020-07-31 | 2022-02-10 | 474SS | 231d |
| 478 |  | Pagos CAF | 400d | 2020-07-31 | 2022-02-10 | 477SS | 231d |
| 479 |  | Pagos CL | 400d | 2020-07-31 | 2022-02-10 | 478SS | 231d |
| 480 | 2.7.3 | **SCC_12. Elaboración de la propuesta de adecuación de la estructura y del nivel tarifario de los servicios de alcantarillado sanitario** | 260d | 2017-12-21 | 2018-12-19 |  | 1052d |
| 481 |  | Etapa previa | 20d | 2017-12-21 | 2018-01-17 | 458SS-66d | 1052d |
| 482 |  | Expresión de interés | 30d | 2018-01-18 | 2018-02-28 | 481 | 1052d |
| 483 |  | Etapa de contratación | 100d | 2018-03-01 | 2018-07-18 | 482 | 1052d |
| 484 |  | Formalización del contrato | 20d | 2018-07-19 | 2018-08-15 | 483 | 1052d |
| 485 |  | Ejecución del contrato | 90d | 2018-08-16 | 2018-12-19 | 484 | 1052d |
| 486 |  | Propuesta de estructura tarifaria aprobada | 0d | 2018-12-19 | 2018-12-19 | 485 | 1052d |
| 487 | 2.7.3.7 | **Pagos** | 90d | 2018-08-16 | 2018-12-19 |  | 1052d |
| 488 |  | Pagos BID | 90d | 2018-08-16 | 2018-12-19 | 485SS | 1052d |
| 489 |  | Pagos CL | 90d | 2018-08-16 | 2018-12-19 | 488SS | 1052d |
| 490 |  | Recursos adicionales | 785d | 2018-12-28 | 2021-12-30 | 462SS | 261d |

| ID | WBS | Task | Duration | Start | Finish | Predecessors | Total float |
| --- | --- | --- | --- | --- | --- | --- | --- |
| 491 | 3 | **Componente 3: Estudios y Acciones Complementarias** | 1824d | 2016-01-04 | 2022-12-29 |  | 1d |
| 492 | 3.1 | **Producto 14: Proyecto piloto de protección de servidumbre de alcantarillado que genere espacios recreativos en márgenes de ríos, implementado** | 1824d | 2016-01-04 | 2022-12-29 |  | 1d |
| 493 | 3.1.1 | **LPI_4. Contratación de firma para la elaboración del proyecto piloto y ejecución de las obras** | 690d | 2020-04-09 | 2022-11-30 |  | 1d |
| 494 |  | Etapa previa | 65d | 2020-04-09 | 2020-07-08 | 173FS+663d | 1d |
| 495 |  | Etapa de contratación | 135d | 2020-07-09 | 2021-01-13 | 494 | 22d |
| 496 |  | Formalización del contrato | 90d | 2021-01-14 | 2021-05-19 | 495 | 22d |
| 497 | 3.1.1.4 | **Ejecución del contrato** | 400d | 2021-05-20 | 2022-11-30 | 496 | 22d |
| 498 |  | Elaboración del diseño final del proyecto | 70d | 2021-05-20 | 2021-08-25 |  | 22d |
| 499 |  | Diseño del proyecto piloto elaborado | 0d | 2021-08-25 | 2021-08-25 | 498 | 22d |
| 500 |  | Construcción de obras para protección de servidumbres | 330d | 2021-08-26 | 2022-11-30 | 499 | 22d |
| 501 |  | Proyecto piloto de protección de servidumbre construido | 0d | 2022-11-30 | 2022-11-30 | 500 | 22d |
| 502 | 3.1.1.4.5 | **Pagos** | 400d | 2021-05-20 | 2022-11-30 |  | 22d |
| 503 |  | Pagos BID | 400d | 2021-05-20 | 2022-11-30 | 498SS | 22d |
| 504 |  | Pagos CAF | 400d | 2021-05-20 | 2022-11-30 | 503SS | 22d |
| 505 |  | Pagos CL | 400d | 2021-05-20 | 2022-11-30 | 504SS | 22d |
| 506 | 3.1.2 | **SBCC_14. Supervisión de obras** | 710d | 2020-04-09 | 2022-12-28 |  | 2d |
| 507 |  | Etapa previa | 20d | 2020-04-09 | 2020-05-06 | 494SS | 2d |
| 508 |  | Expresión de interés | 30d | 2020-05-07 | 2020-06-17 | 507 | 2d |
| 509 |  | Etapa de contratación | 130d | 2020-06-18 | 2020-12-16 | 508 | 2d |
| 510 |  | Formalización del contrato | 90d | 2020-12-17 | 2021-04-21 | 509 | 2d |
| 511 |  | Ejecución del contrato | 440d | 2021-04-22 | 2022-12-28 | 510 | 2d |
| 512 | 3.1.2.6 | **Pagos** | 440d | 2021-04-22 | 2022-12-28 |  | 2d |
| 513 |  | Pagos BID | 440d | 2021-04-22 | 2022-12-28 | 511SS | 2d |
| 514 |  | Pagos CAF | 440d | 2021-04-22 | 2022-12-28 | 513SS | 2d |
| 515 |  | Pagos CL | 440d | 2021-04-22 | 2022-12-28 | 514SS | 2d |
| 516 |  | Incorporación en los TDR de los supervisores la responsabilidad de monitorear las áreas de servidumbre durante la etapa de construcción | 22d | 2016-01-04 | 2016-02-02 | 33SS | 1803d |
| 517 | 3.1.4 | **Coordinación de actividades con autoridades competentes** | 710d | 2020-04-10 | 2022-12-29 |  | 1d |
| 518 |  | Actividades con el Municipio de Arraiján | 710d | 2020-04-10 | 2022-12-29 | 494SS+1d | 1d |
| 519 |  | Actividades con el Municipio de La Chorrera | 710d | 2020-04-10 | 2022-12-29 | 518SS | 1d |
| 520 | 3.2. | **Producto 15: Actividades de sensibilización y educación para el manejo adecuado de residuos sólidos, implementadas** | 1231d | 2017-07-10 | 2022-03-28 |  | 199d |
| 521 | 3.2.1 | **SCC_17. Diseño e implementación de un plan de sensibilización para el manejo adecuado de residuos sólidos** | 711d | 2017-07-10 | 2020-03-30 |  | 199d |
| 522 |  | Etapa previa | 20d | 2017-07-10 | 2017-08-04 | 13FS+66d | 199d |
| 523 |  | Expresión de interés | 30d | 2017-08-07 | 2017-09-15 | 522 | 199d |
| 524 |  | Etapa de contratación | 100d | 2017-09-18 | 2018-02-02 | 523 | 199d |
| 525 |  | Formalización del contrato | 20d | 2018-02-05 | 2018-03-02 | 524 | 199d |
| 526 | 3.2.1.5 | **Ejecución del contrato** | 541d | 2018-03-05 | 2020-03-30 |  | 199d |
| 527 |  | Diseño del plan de sensibilización | 66d | 2018-03-05 | 2018-06-04 | 525 | 199d |
| 528 |  | Plan de sensibilización diseñado | 0d | 2018-06-04 | 2018-06-04 | 527 | 199d |
| 529 |  | Implementación del plan de sensibilización | 475d | 2018-06-05 | 2020-03-30 | 528 | 199d |
| 530 |  | Actividades de sensibilización realizadas - Año 2 | 0d | 2019-03-25 | 2019-03-25 | 529SS+210d | 984d |
| 531 |  | Actividades de sensibilización realizadas - Año 3 | 0d | 2020-03-30 | 2020-03-30 | 529 | 719d |
| 532 | 3.2.1.6 | **Pagos** | 475d | 2018-06-05 | 2020-03-30 |  | 719d |
| 533 |  | Pagos BID | 475d | 2018-06-05 | 2020-03-30 | 529SS | 719d |
| 534 |  | Pagos CAF | 475d | 2018-06-05 | 2020-03-30 | 533SS | 719d |
| 535 |  | Pagos CL | 475d | 2018-06-05 | 2020-03-30 | 534SS | 719d |
| 536 |  | Otras actividades a definir | 520d | 2020-03-31 | 2022-03-28 | 529 | 199d |
| 537 |  | Actividades de sensibilización realizadas - Año 4 | 0d | 2021-03-29 | 2021-03-29 | 536SS+260d | 459d |
| 538 |  | Actividades de sensibilización realizadas - Año 5 | 0d | 2022-03-28 | 2022-03-28 | 536 | 199d |
| 539 | 4 | **Administración, Auditoría y Evaluación** | 1660d | 2016-08-22 | 2022-12-30 |  | 0d |
| 540 | 4.1 | **Administración del Programa** | 1660d | 2016-08-22 | 2022-12-30 |  | 0d |
| 541 | 4.1.1 | **Costos de funcionamiento de la UCPSP** | 1660d | 2016-08-22 | 2022-12-30 |  | 0d |
| 542 |  | Equipo de la UCPSP | 1495d | 2017-04-10 | 2022-12-30 | 13FS+1d | 0d |
| 543 | 4.1.1.2 | **Pagos** | 1495d | 2017-04-10 | 2022-12-30 |  | 0d |
| 544 |  | Pagos BID | 1495d | 2017-04-10 | 2022-12-30 | 542SS | 0d |
| 545 |  | Pagos AECID | 1495d | 2017-04-10 | 2022-12-30 | 544SS | 0d |
| 546 |  | Pagos CAF | 1495d | 2017-04-10 | 2022-12-30 | 545SS | 0d |
| 547 |  | Pagos BCIE | 1495d | 2017-04-10 | 2022-12-30 | 546SS | 0d |
| 548 |  | Pagos BEI | 1495d | 2017-04-10 | 2022-12-30 | 547SS | 0d |
| 549 |  | Pagos CL | 1495d | 2017-04-10 | 2022-12-30 | 547SS | 0d |
| 550 |  | Revisión de la estructura organizacional de la UCPSP | 95d | 2016-08-22 | 2016-12-30 | 6 | 1565d |
| 551 |  | Coordinación de acciones el MEF e informar permanentemente sobre los resultados y avances logrados por el Programa | 1495d | 2017-04-10 | 2022-12-30 | 542SS | 0d |
| 552 |  | Reuniones de coordinación con las autoridades de la CGR para socializar aspectos importantes del proyecto y solicitar apoyo requeirdo por parte de la entidad | 1495d | 2017-04-10 | 2022-12-30 | 551SS | 0d |
| 553 | 4.2 | **Auditoría del Programa** | 1495d | 2017-04-10 | 2022-12-30 |  | 0d |
| 554 | 4.2.1 | **SBCC_18. Contratación de firma para servicios de Auditoría Externa del Programa** | 1495d | 2017-04-10 | 2022-12-30 |  | 0d |
| 555 |  | Etapa previa | 20d | 2017-04-10 | 2017-05-05 | 542SS, 13 | 0d |
| 556 |  | Expresión de interés | 30d | 2017-05-08 | 2017-06-16 | 555 | 0d |
| 557 |  | Etapa de contratación | 100d | 2017-06-19 | 2017-11-03 | 556 | 0d |
| 558 |  | Formalización del contrato | 65d | 2017-11-06 | 2018-02-02 | 557 | 0d |
| 559 |  | Ejecución del contrato | 1280d | 2018-02-05 | 2022-12-30 | 558 | 0d |
| 560 | 4.2.1.6 | **Pagos** | 1280d | 2018-02-05 | 2022-12-30 |  | 0d |

| ID | WBS | Task | Duration | Start | Finish | Predecessors | Total float |
| --- | --- | --- | --- | --- | --- | --- | --- |
| 561 |  | Pagos BID | 1280d | 2018-02-05 | 2022-12-30 | 558 | 0d |
| 562 |  | Pagos CL | 1280d | 2018-02-05 | 2022-12-30 | 558 | 0d |
| 563 | 4.3 | **Evaluaciones del Programa** | 735d | 2020-03-05 | 2022-12-28 |  | 2d |
| 564 | 4.3.1 | **CCIN_21. Consultoría individual para evaluación intermedia del Programa** | 150d | 2020-03-05 | 2020-09-30 |  | 2d |
| 565 |  | Etapa previa | 20d | 2020-03-05 | 2020-04-01 | 542SS+758d | 2d |
| 566 |  | Etapa de contratación | 45d | 2020-04-02 | 2020-06-03 | 565 | 2d |
| 567 |  | Formalización del contrato | 20d | 2020-06-04 | 2020-07-01 | 566 | 2d |
| 568 |  | Ejecución del contrato | 65d | 2020-07-02 | 2020-09-30 | 567 | 2d |
| 569 | 4.3.1.5 | **Pagos** | 65d | 2020-07-02 | 2020-09-30 |  | 587d |
| 570 |  | Pagos BID | 65d | 2020-07-02 | 2020-09-30 | 567 | 587d |
| 571 |  | Pagos CL | 65d | 2020-07-02 | 2020-09-30 | 567 | 587d |
| 572 | 4.3.2 | **SCC_19. Consultoría para la evaluación final del programa** | 260d | 2021-12-30 | 2022-12-28 |  | 2d |
| 573 |  | Etapa previa | 20d | 2021-12-30 | 2022-01-26 | 568FS+325d | 2d |
| 574 |  | Expresión de interés | 30d | 2022-01-27 | 2022-03-09 | 573 | 2d |
| 575 |  | Etapa de contratación | 100d | 2022-03-10 | 2022-07-27 | 574 | 2d |
| 576 |  | Formalización del contrato | 20d | 2022-07-28 | 2022-08-24 | 575 | 2d |
| 577 |  | Ejecución del contrato | 90d | 2022-08-25 | 2022-12-28 | 576 | 2d |
| 578 | 4.3.2.6 | **Pagos** | 90d | 2022-08-25 | 2022-12-28 |  | 2d |
| 579 |  | Pagos BID | 90d | 2022-08-25 | 2022-12-28 | 576 | 2d |
| 580 |  | Pagos CL | 90d | 2022-08-25 | 2022-12-28 | 576 | 2d |
| 581 | 4.3.3 | **CCIN_22.Consultor individual para la evaluación ex post del Programa** | 175d | 2022-04-28 | 2022-12-28 |  | 2d |
| 582 |  | Etapa previa | 20d | 2022-04-28 | 2022-05-25 | 573SS+85d | 2d |
| 583 |  | Etapa de contratación | 45d | 2022-05-26 | 2022-07-27 | 582 | 2d |
| 584 |  | Formalización del contrato | 20d | 2022-07-28 | 2022-08-24 | 583 | 2d |
| 585 |  | Ejecución del contrato | 90d | 2022-08-25 | 2022-12-28 | 584 | 2d |
| 586 | 4.3.3.5 | **Pagos** | 90d | 2022-08-25 | 2022-12-28 |  | 2d |
| 587 |  | Pagos BID | 90d | 2022-08-25 | 2022-12-28 | 584 | 2d |
| 588 |  | Pagos CL | 90d | 2022-08-25 | 2022-12-28 | 584 | 2d |
| 589 |  | Recursos adicionales | 650d | 2020-07-02 | 2022-12-28 | 568SS | 2d |
| 590 |  | Fin de la ejecución del PSACH | 0d | 2022-12-30 | 2022-12-30 | 559 | 0d |

## Version 2 (saved 2016-10-10)

Last finish 2022-12-30 → 2021-05-19 (-590d).

Added:

| ID | Task | Duration | Start | Finish | Predecessors | Constraint |
| --- | --- | --- | --- | --- | --- | --- |
| 1 | **PLAN DE EJECUCIÓN DEL PROYECTO (HO-L1121): PROGRAMA DE INTEGRACIÓN VIAL REGIONAL II** | 1163d | 2016-08-15 | 2021-05-19 |  |  |
| 2 | **COMPONENTE 1: MEJORAMIENTO DE TRAMOS VIALES DE INTEGRACIóN** | 1068d | 2016-08-15 | 2021-01-06 |  |  |
| 4 | **Corredor Logístico Carretera CA-5 Norte, La Barca- Pimienta. Lote A: La Barca- Potrerillos (18 meses). Lote B: Potrerillos- Pimienta (12 meses).** | 679d | 2016-09-26 | 2019-07-11 |  |  |
| 5 | **Proceso de Contratación** | 161d | 2016-09-26 | 2017-05-30 |  |  |
| 7 | Envio de documento en borrador al BID | 3d | 2016-10-19 | 2016-10-21 | 6 |  |
| 8 | Respuesta del BID al borrador del Documento de Licitación | 5d | 2016-10-24 | 2016-10-28 | 7 |  |
| 9 | Incorporación observaciones al documentos de licitación | 3d | 2016-10-31 | 2016-11-02 | 8 |  |
| 15 | Evaluación de ofertas | 15d | 2017-01-19 | 2017-02-08 | 14 |  |
| 28 | Orden de Inicio lote A | 1d | 2017-05-30 | 2017-05-30 | 24, 121FS-70d |  |
| 30 | Ejecución Construcción lote A: La Barca- Potrerillos | 360d | 2017-05-31 | 2018-11-15 | 28 |  |
| 33 | Estimación 1 | 2d | 2017-07-10 | 2017-07-11 | 32FS+40d |  |
| 34 | Estimación 2 | 2d | 2017-08-09 | 2017-08-10 | 33FS+20d |  |
| 36 | Estimación 4 | 2d | 2017-10-18 | 2017-10-19 | 35FS+20d |  |
| 37 | Estimación 5 | 2d | 2017-11-17 | 2017-11-20 | 36FS+20d |  |
| 38 | Estimación 6 | 2d | 2018-01-23 | 2018-01-24 | 37FS+40d |  |
| 41 | Estimación 9 | 2d | 2018-05-03 | 2018-05-04 | 40FS+20d |  |
| 42 | Estimación 10 | 2d | 2018-06-04 | 2018-06-05 | 41FS+20d |  |
| 43 | Estimación 11 | 2d | 2018-07-04 | 2018-07-05 | 42FS+20d |  |
| 44 | Estimación 12 | 2d | 2018-08-03 | 2018-08-06 | 43FS+20d |  |
| 48 | Estimación 16 | 2d | 2019-01-17 | 2019-01-18 | 47FS+40d |  |
| 50 | Estimación 18 | 2d | 2019-05-09 | 2019-05-10 | 49FS+50d |  |
| 51 | Estimación 19 | 2d | 2019-06-10 | 2019-06-11 | 50FS+20d |  |
| 52 | Estimación 20 | 2d | 2019-07-10 | 2019-07-11 | 51FS+20d |  |
| 54 | **Estimaciones de Pago** | 306d | 2017-05-11 | 2018-08-06 |  |  |
| 68 | **Construcción de obras Corredor Turístico Libramiento El Progreso (siempre que cumpla con los criterios de elegibilidad)** | 675d | 2018-04-02 | 2021-01-06 |  |  |
| 69 | **Proceso de Contratación** | 154d | 2018-04-02 | 2018-11-09 |  |  |
| 70 | Preparación borrador documentos de licitación | 12d | 2018-04-02 | 2018-04-17 |  | start no earlier than 2018-04-02 |
| 71 | Envio de documento en borrador al BID | 3d | 2018-04-18 | 2018-04-20 | 70 |  |
| 76 | Convocatoria pública a participar (Llamado a Licitación) | 2d | 2018-05-16 | 2018-05-17 | 75 |  |
| 77 | Preparacion de ofertas | 32d | 2018-05-18 | 2018-07-02 | 76 |  |
| 84 | Publicación de la adjudicación y carta de adjudicacion | 2d | 2018-09-11 | 2018-09-12 | 83 |  |
| 90 | **Estimaciones de Pago** | 528d | 2018-11-01 | 2021-01-06 |  |  |
| 98 | Estimación 7 | 2d | 2019-09-27 | 2019-09-30 | 97FS+50d |  |
| 99 | Estimación 8 | 2d | 2019-11-04 | 2019-11-05 | 98FS+20d |  |
| 100 | Estimación 9 | 2d | 2019-12-04 | 2019-12-05 | 99FS+20d |  |
| 101 | Estimación 10 | 2d | 2020-01-14 | 2020-01-15 | 100FS+20d |  |
| 102 | Estimación 11 | 2d | 2020-02-13 | 2020-02-14 | 101FS+20d |  |
| 104 | Estimación 13 | 2d | 2020-04-23 | 2020-04-24 | 103FS+20d |  |
| 105 | Estimación 14 | 2d | 2020-05-26 | 2020-05-27 | 104FS+20d |  |
| 109 | Estimación 18 | 2d | 2021-01-05 | 2021-01-06 | 108FS+60d |  |
| 110 | **Firma para la implementación Plan de Reasentamiento La Barca - Pimienta** | 230d | 2016-09-19 | 2017-08-28 |  |  |
| 111 | **Proceso de Contratación** | 38d | 2016-09-19 | 2016-11-16 |  |  |
| 112 | Elaboración de TdeR y de presupuesto | 5d | 2016-09-19 | 2016-09-23 |  | start no earlier than 2016-09-19 |
| 114 | Evaluación de propuestas técnicas y de precio | 5d | 2016-10-10 | 2016-10-14 | 113 |  |
| 117 | Elaboración de la modificación de contrato | 2d | 2016-10-26 | 2016-10-27 | 116 |  |
| 118 | Solicitud de aprobación contrato a CD | 10d | 2016-10-28 | 2016-11-10 | 117 |  |
| 119 | Suscripción de modificación al contrato | 3d | 2016-11-11 | 2016-11-15 | 118 |  |
| 120 | Orden de Inicio | 1d | 2016-11-16 | 2016-11-16 | 119 |  |
| 121 | Ejecución de la consultoría | 80d | 2016-11-17 | 2017-03-15 | 120 |  |
| 126 | Pago No.4 | 2d | 2017-04-28 | 2017-05-02 | 125FS+40d |  |
| 127 | Pago No.5 | 2d | 2017-06-28 | 2017-06-29 | 126FS+40d |  |
| 136 | Análisis de expresiones de interés | 22d | 2017-06-09 | 2017-07-10 | 135 |  |
| 137 | Elaboración de lista corta | 3d | 2017-07-11 | 2017-07-13 | 136 |  |
| 138 | Solicitud de no objeción al BID de lista corta | 1d | 2017-07-14 | 2017-07-14 | 137 |  |
| 140 | Elaboración de SP, TdeR y de presupuesto | 10d | 2017-06-09 | 2017-06-22 | 135 |  |
| 141 | Solicitud de no objeción al BID SP y Presupuesto | 1d | 2017-06-23 | 2017-06-23 | 140 |  |
| 143 | Notificación de conformación de lista corta | 5d | 2017-07-03 | 2017-07-07 | 142 |  |
| 148 | No objeción del BID | 5d | 2017-09-20 | 2017-09-26 | 147 |  |
| 151 | Evaluación combinada de calidad y costo | 5d | 2017-10-11 | 2017-10-17 | 150 |  |
| 158 | Envío de contrato firmado al BID y formulario PRISM | 2d | 2017-11-10 | 2017-11-13 | 156 |  |
| 159 | Orden de Inicio | 1d | 2017-11-10 | 2017-11-10 | 156 |  |
| 160 | Ejecución de la consultoría | 220d | 2017-11-13 | 2018-10-08 | 159 |  |
| 162 | Anticipo | 2d | 2017-11-13 | 2017-11-14 | 159 |  |
| 166 | Pago No.4 | 2d | 2018-05-25 | 2018-05-28 | 165FS+40d |  |
| 167 | Pago No.5 | 2d | 2018-06-26 | 2018-06-27 | 166FS+20d |  |
| 168 | Pago No.6 | 2d | 2018-08-23 | 2018-08-24 | 167FS+40d |  |
| 169 | Pago No.7 | 2d | 2018-09-24 | 2018-09-25 | 168FS+20d |  |
| 170 | Pago No.8 | 2d | 2018-11-28 | 2018-11-29 | 169FS+40d |  |
| 171 | Pago No.9 | 1d | 2019-01-07 | 2019-01-07 | 170FS+20d |  |
| 172 | **Fideicomiso de apoyo a implementación de Planes de Reasentamiento La Barca-Pimienta** | 305d | 2016-10-31 | 2018-01-30 |  |  |
| 176 | Recepción de ofertas | 10d | 2016-11-16 | 2016-11-29 | 175 |  |
| 181 | Orden de inicio | 1d | 2017-01-20 | 2017-01-20 | 180 |  |
| 182 | Ejecución de consultoría | 250d | 2017-01-23 | 2018-01-30 | 181 |  |
| 184 | Pago 1 | 2d | 2017-02-20 | 2017-02-21 | 181FS+20d |  |
| 185 | Pago 2 | 2d | 2017-03-22 | 2017-03-23 | 184FS+20d |  |
| 201 | Suscripción de contrato | 5d | 2017-10-24 | 2017-10-30 | 200 |  |
| 210 | Pago 5 | 2d | 2018-09-06 | 2018-09-07 | 209FS+40d |  |
| 218 | **Pagos de Implementacion del Plan de Reasentamiento La Barca-Pimienta y las Obras del Corredor Turístico Libramiento El Progreso (siempre que cumpla con los criterios de elegibilidad)** | 818d | 2017-04-20 | 2020-08-20 |  |  |
| 220 | Pago 2 | 2d | 2017-06-20 | 2017-06-21 | 219FS+40d |  |
| 221 | Pago 3 | 2d | 2017-10-20 | 2017-10-23 | 220FS+80d |  |
| 224 | Pago 6 | 2d | 2019-05-15 | 2019-05-16 | 223FS+60d |  |
| 228 | Pago 10 | 2d | 2020-01-21 | 2020-01-22 | 227FS+40d |  |
| 229 | Pago 11 | 2d | 2020-03-19 | 2020-03-20 | 228FS+40d |  |
| 230 | Pago 12 | 2d | 2020-08-19 | 2020-08-20 | 229FS+100d |  |
| 236 | Revisión aprobada | 5d | 2016-08-31 | 2016-09-06 | 235 |  |
| 239 | Análisis de expresiones de interés | 22d | 2016-09-23 | 2016-10-31 | 238 |  |
| 242 | Revisión aprobada | 5d | 2016-11-07 | 2016-11-11 | 241 |  |
| 243 | Elaboración de SP, TdeR y de presupuesto | 10d | 2016-11-14 | 2016-11-25 | 242 |  |
| 244 | Solicitud de revisión | 1d | 2016-11-28 | 2016-11-28 | 243 |  |
| 245 | Revisión aprobada | 5d | 2016-11-29 | 2016-12-05 | 244 |  |
| 246 | Notificación de conformación de lista corta | 5d | 2016-12-06 | 2016-12-12 | 245 |  |
| 247 | Remisión de SP a integrantes de la lista corta | 2d | 2016-12-13 | 2016-12-14 | 246 |  |
| 248 | Presentación de propuesta | 22d | 2016-12-15 | 2017-01-20 | 247 |  |
| 249 | Evaluación de propuestas técnicas | 15d | 2017-01-23 | 2017-02-10 | 248 |  |
| 250 | Solicitud de revisión | 2d | 2017-02-13 | 2017-02-14 | 249 |  |
| 251 | Revisión aprobada | 5d | 2017-02-15 | 2017-02-21 | 250 |  |
| 252 | Notificación de resultados a los participantes (Evaluación técnica) | 2d | 2017-02-22 | 2017-02-23 | 251 |  |
| 253 | Apertura de propuestas de precios | 3d | 2017-02-24 | 2017-02-28 | 252 |  |
| 254 | Evaluación combinada de calidad y costo | 5d | 2017-03-01 | 2017-03-07 | 253 |  |
| 255 | Negociación del contrato | 5d | 2017-03-08 | 2017-03-14 | 254 |  |
| 256 | Solicitud de No Objeción al BID a Evaluación combinada y a borrador del contrato negociado | 2d | 2017-03-15 | 2017-03-16 | 255 |  |
| 257 | No objeción | 5d | 2017-03-17 | 2017-03-23 | 256 |  |
| 258 | Publicación de la adjudicación y notificacion al ganador | 2d | 2017-03-24 | 2017-03-27 | 257 |  |
| 259 | Suscripción del contrato | 3d | 2017-05-02 | 2017-05-04 | 258, 599 |  |
| 260 | Presentación de garantía bancarias | 15d | 2017-05-05 | 2017-05-25 | 259 |  |
| 261 | Envío de contrato firmado al BID y formulario PRISM | 2d | 2017-05-05 | 2017-05-08 | 259 |  |
| 262 | Orden de Inicio | 1d | 2017-05-05 | 2017-05-05 | 259, 28SS-18d |  |
| 271 | Pago No.7 | 4d | 2017-12-04 | 2017-12-07 | 270FS+20d |  |
| 272 | Pago No.8 | 4d | 2018-01-12 | 2018-01-17 | 271FS+20d |  |
| 273 | Pago No.9 | 4d | 2018-02-15 | 2018-02-20 | 272FS+20d |  |
| 274 | Pago No.10 | 4d | 2018-02-15 | 2018-02-20 | 272FS+20d |  |
| 275 | Pago No.11 | 4d | 2018-03-21 | 2018-04-02 | 274FS+20d |  |
| 276 | Pago No.12 | 4d | 2018-05-02 | 2018-05-07 | 275FS+20d |  |
| 277 | Pago No.13 | 4d | 2018-06-05 | 2018-06-08 | 276FS+20d |  |
| 278 | Pago No.14 | 4d | 2018-07-09 | 2018-07-12 | 277FS+20d |  |
| 294 | Análisis de expresiones de interés | 22d | 2018-02-16 | 2018-03-19 | 293 |  |
| 295 | Elaboración de lista corta | 3d | 2018-03-20 | 2018-03-22 | 294 |  |
| 296 | Solicitud de no objeción al BID de lista corta | 1d | 2018-03-23 | 2018-03-23 | 295 |  |
| 305 | Solicitud de no objeción del BID | 2d | 2018-07-12 | 2018-07-13 | 304 |  |
| 308 | Apertura de propuestas de precios | 3d | 2018-07-25 | 2018-07-27 | 307 |  |
| 311 | Solicitud de No Objeción al BID a Evaluación combinada y a borrador del contrato negociado | 5d | 2018-08-20 | 2018-08-24 | 310 |  |
| 314 | Suscripción del contrato | 5d | 2018-09-05 | 2018-09-11 | 313 |  |
| 315 | Presentación de garantía bancarias | 15d | 2018-09-12 | 2018-10-09 | 314 |  |
| 320 | Pago No.1 | 2d | 2018-11-07 | 2018-11-08 | 317FS+20d |  |
| 323 | Pago No.4 | 2d | 2019-02-15 | 2019-02-18 | 322FS+20d |  |
| 326 | Pago No.7 | 2d | 2019-05-28 | 2019-05-29 | 325FS+20d |  |
| 328 | Pago No.9 | 2d | 2019-07-29 | 2019-07-30 | 327FS+20d |  |
| 329 | Pago No.10 | 2d | 2019-08-28 | 2019-08-29 | 328FS+20d |  |
| 330 | Pago No.11 | 2d | 2019-09-27 | 2019-09-30 | 329FS+20d |  |
| 331 | Pago No.12 | 2d | 2019-11-04 | 2019-11-05 | 330FS+20d |  |
| 332 | Pago No.13 | 2d | 2019-12-04 | 2019-12-05 | 331FS+20d |  |
| 333 | Pago No.14 | 2d | 2020-01-14 | 2020-01-15 | 332FS+20d |  |
| 334 | Pago No.15 | 2d | 2020-02-13 | 2020-02-14 | 333FS+20d |  |
| 335 | Pago No.16 | 2d | 2020-03-16 | 2020-03-17 | 334FS+20d |  |
| 336 | Pago No.17 | 2d | 2020-04-23 | 2020-04-24 | 335FS+20d |  |
| 337 | Pago No.18 | 2d | 2020-05-26 | 2020-05-27 | 336FS+20d |  |
| 338 | Pago No.19 | 2d | 2020-06-25 | 2020-06-26 | 337FS+20d |  |
| 339 | Pago No.20 | 2d | 2020-07-27 | 2020-07-28 | 338FS+20d |  |
| 340 | **Estudios Técnicos** | 321d | 2018-02-05 | 2019-05-30 |  |  |
| 341 | **Estudios Técnicos, Económicos y Socioambientales** | 321d | 2018-02-05 | 2019-05-30 |  |  |
| 348 | Análisis de expresiones de interés | 10d | 2018-03-07 | 2018-03-20 | 347 |  |
| 354 | Remisión de SP a integrantes de la lista corta | 2d | 2018-05-10 | 2018-05-11 | 353 |  |
| 355 | Presentación de propuesta | 22d | 2018-05-14 | 2018-06-12 | 354 |  |
| 356 | Evaluación de propuestas técnicas | 15d | 2018-06-13 | 2018-07-03 | 355 |  |
| 357 | Solicitud de no objeción del BID | 2d | 2018-07-04 | 2018-07-05 | 356 |  |
| 361 | Evaluación combinada de calidad y costo | 5d | 2018-07-20 | 2018-07-26 | 360 |  |
| 362 | Negociación del contrato | 5d | 2018-07-27 | 2018-08-02 | 361 |  |
| 363 | Solicitud de No Objeción al BID a Evaluación combinada y a borrador del contrato negociado | 2d | 2018-08-03 | 2018-08-06 | 362 |  |
| 370 | Ejecución del diseño | 132d | 2018-09-12 | 2019-03-29 | 369 |  |
| 376 | Pago 5 | 2d | 2019-05-29 | 2019-05-30 | 375FS+40d |  |
| 383 | No Objeción | 5d | 2017-04-20 | 2017-04-26 | 382 |  |
| 384 | Publicación / Invitación Proceso | 1d | 2017-04-27 | 2017-04-27 | 383 |  |
| 385 | Presentación de ofertas | 22d | 2017-04-28 | 2017-05-30 | 384 |  |
| 392 | Pago 1 | 2d | 2017-07-21 | 2017-07-24 | 389FS+10d |  |
| 402 | Presentación de ofertas | 22d | 2018-10-11 | 2018-11-09 | 401 |  |
| 406 | Suscripción de Contrato | 5d | 2018-12-12 | 2018-12-18 | 405 |  |
| 424 | Ejecucion | 230d | 2017-11-24 | 2018-11-02 | 423 |  |
| 428 | **COMPONENTE 2: FORTALECIMIENTO INSTITUCIONAL INSEP** | 333d | 2017-05-30 | 2018-10-08 |  |  |
| 429 | **Capacitación de recursos humanos** | 149d | 2017-05-30 | 2018-01-08 |  |  |
| 448 | No Objeción | 5d | 2017-10-27 | 2017-11-02 | 447 |  |
| 449 | Publicación / Invitación Proceso | 1d | 2017-11-03 | 2017-11-03 | 448 |  |
| 452 | Solicitud de no objeción del BID | 2d | 2018-01-03 | 2018-01-04 | 451 |  |
| 457 | **Adquisición de software** | 133d | 2018-03-21 | 2018-10-08 |  |  |
| 464 | Presentación de ofertas | 22d | 2018-05-22 | 2018-06-20 | 463 |  |
| 486 | **Proceso de Contratación LPN** | 87d | 2018-03-21 | 2018-07-27 |  |  |
| 487 | Elaboración especificaciones técnicas | 20d | 2018-03-21 | 2018-04-24 | 599FS+220d |  |
| 488 | Elaboración documento de licitación | 10d | 2018-04-25 | 2018-05-09 | 487 |  |
| 489 | Solicitud de No Objeción | 2d | 2018-05-10 | 2018-05-11 | 488 |  |
| 490 | No Objeción | 5d | 2018-05-14 | 2018-05-18 | 489 |  |
| 494 | Solicitud de no objeción del BID | 2d | 2018-07-12 | 2018-07-13 | 493 |  |
| 498 | Pagos | 2d | 2018-09-28 | 2018-10-08 | 497 |  |
| 500 | **Gestión del Programa** | 917d | 2017-08-16 | 2021-05-19 |  |  |
| 503 | Ejecución año 2 | 230d | 2018-02-15 | 2019-01-25 | 502FS+10d |  |
| 509 | Revisión interna de TdeR y Presupuesto | 5d | 2020-06-15 | 2020-06-19 | 508 |  |
| 510 | Solicitud de no objeción al BID | 2d | 2020-06-22 | 2020-06-23 | 509 |  |
| 511 | No objeción del BID | 5d | 2020-06-24 | 2020-06-30 | 510 |  |
| 512 | Presentación de hojas de vida | 15d | 2020-07-01 | 2020-07-21 | 511 |  |
| 513 | Evaluación y calificación de hojas de vida | 15d | 2020-07-22 | 2020-08-11 | 512 |  |
| 514 | Solicitud de no objeción del BID | 2d | 2020-08-12 | 2020-08-13 | 513 |  |
| 515 | No objeción del BID | 5d | 2020-08-14 | 2020-08-20 | 514 |  |
| 516 | Negociación del contrato | 15d | 2020-08-21 | 2020-09-10 | 515 |  |
| 517 | Suscripción del contrato | 5d | 2020-09-11 | 2020-09-18 | 516 |  |
| 518 | Envío de contrato firmado al BID | 2d | 2020-09-21 | 2020-09-22 | 517 |  |
| 519 | Orden de Inicio | 2d | 2020-09-21 | 2020-09-22 | 517 |  |
| 530 | Preparacion de ofertas | 22d | 2017-11-23 | 2017-12-22 | 529 |  |
| 531 | Recepción de ofertas y apertura | 1d | 2018-01-01 | 2018-01-01 | 530 |  |
| 533 | Solicitud de No Objeción al BID(Informe de Evaluación) | 2d | 2018-01-23 | 2018-01-24 | 532 |  |
| 534 | No Objeción del BID | 5d | 2018-01-25 | 2018-01-31 | 533 |  |
| 535 | Notificación a oferentes y negociación de contrato | 2d | 2018-02-01 | 2018-02-02 | 534 |  |
| 536 | Solicitud no objeción al BID al borrador del contrato | 15d | 2018-02-05 | 2018-02-23 | 535 |  |
| 537 | No Objeción del BID | 5d | 2018-02-26 | 2018-03-02 | 536 |  |
| 538 | Suscripción del contrato | 2d | 2018-03-05 | 2018-03-06 | 537 |  |
| 539 | Envío de contrato firmado y registro PRISM al BID | 1d | 2018-03-07 | 2018-03-07 | 538 |  |
| 540 | Orden de Inicio | 1d | 2018-03-07 | 2018-03-07 | 538 |  |
| 543 | Auditoria anual 2018 | 40d | 2019-04-01 | 2019-06-03 | 542FS+120d |  |
| 544 | Auditoría intermedia 2019 | 40d | 2019-08-13 | 2019-10-11 | 543FS+50d |  |
| 545 | Auditoria anual 2019 | 40d | 2020-04-16 | 2020-06-11 | 544FS+120d |  |
| 546 | Auditoría intermedia 2020 | 40d | 2020-08-07 | 2020-10-02 | 545FS+40d |  |
| 547 | Auditoria anual 2020 | 20d | 2021-04-20 | 2021-05-17 | 546FS+130d |  |
| 550 | Auditoría intermedia 2018 | 2d | 2018-09-28 | 2018-10-08 | 542 |  |
| 554 | Auditoría intermedia 2020 | 2d | 2020-10-12 | 2020-10-13 | 546 |  |
| 559 | Informe segundo semestre 2017 | 22d | 2018-01-02 | 2018-01-31 | 558FS+120d |  |
| 564 | Informe primer semestre 2020 | 22d | 2020-05-27 | 2020-06-25 | 563FS+80d |  |
| 565 | Informe segundo semestre 2020 | 22d | 2020-12-21 | 2021-01-27 | 564FS+120d |  |
| 571 | **Plan de Adquisiciones** | 669d | 2017-05-16 | 2020-02-07 |  |  |
| 572 | Plan de adquisiciones actualizado 2017 | 10d | 2017-05-16 | 2017-05-29 | 600 |  |
| 573 | Plan de adquisiciones actualizado 2018 | 10d | 2018-02-01 | 2018-02-14 | 559 |  |
| 577 | Negociación de contrato | 2d | 2016-10-10 | 2016-10-11 |  | start no earlier than 2016-10-10 |
| 578 | Aprobación del Contrato por parte del Directorio del BID | 31d | 2016-10-12 | 2016-11-23 | 577 |  |
| 586 | Publicación en La Gaceta | 2d | 2017-03-06 | 2017-03-07 | 585 |  |
| 588 | Envío de Gaceta a SEFIN | 9d | 2017-03-08 | 2017-03-20 | 587 |  |
| 589 | Elaboración de Dictamen Jurídico | 24d | 2017-03-21 | 2017-04-28 | 588 |  |
| 591 | **Condiciones generales** | 57d | 2017-03-08 | 2017-06-02 |  |  |
| 592 | Envío de Informe Jurídico al BID | 0d | 2017-04-28 | 2017-04-28 | 589 |  |
| 593 | Designar firmas de funcionarios responsables | 24d | 2017-03-08 | 2017-04-17 | 586 |  |
| 596 | **Condicionales especiales** | 107d | 2016-12-01 | 2017-05-15 |  |  |
| 598 | Incorporación de programa en el SIAFI y UEPEX | 22d | 2017-03-08 | 2017-04-06 | 586 |  |
| 600 | Fecha de primer desembolso | 10d | 2017-05-02 | 2017-05-15 | 599 |  |

Removed: 15 Producto 1: Primer Módulo de la PTAR construida; 16 Actividades de coordinación y seguimiento de acuerdos entre autoridades del MINSA y propietarios del terreno para su adquisición; 17 Adquisciones de terrenos; 18 LPI_1. Contratación de firma para el diseño y construcción de obras; 19 Etapa previa; 20 Etapa de contratación; 22 Ejecución de contrato; 23 Elaboración del diseño final; 25 Construcción de la PTAR; 26 PTAR Caimito construida; 32 SBCC_6. Contratación de firma consultora para la supervisión de diseños y obras; 33 Etapa previa; 35 Etapa de contratación; 39 Pagos BID; 40 Pagos CL; 41 Producto 2: Interceptor construido; 42 LPI_1. Contratación de firma para el diseño y construcción de obras; 49 Pagos BID; 50 Pagos AECID; 51 Pago CL; 56 Producto 3: Colectoras construidas, rehabilitadas y/o ampliadas; 60 Ejecución del contrato; 61 Elaboración del diseño final; 62 Diseño de las colectoras elaborado; 63 Construcción de las colectoras; 64 Colectoras construidas; 71 Elaboración del diseño final; 72 Diseño de las colectoras elaborado; 73 Construcción de las colectoras; 74 Colectoras construidas; 81 Diseño de las colectoras elaborado; 82 Construcción de las colectoras; 83 Colectoras construidas; 99 Elaboración del diseño final; 105 Pagos CL; 112 Pagos BID; 113 Pagos CL; 118 Colectoras construidas; 123 Elaboración del diseño final; 124 Diseño de las colectoras elaborado; 126 Colectoras construidas; 135 Formalización del contrato; 140 Colectoras construidas en las cuencas de Caimito I, Caimito II y Punta Piedras; 144 Formalización del contrato; 147 Elaboración del diseño final; 153 Pagos CL; 156 Diseño de las colectoras elaborado; 157 Construcción de las colectoras; 158 Colectoras construidas; 160 Pagos BID; 161 Pagos CL; 168 Pagos CL; 169 SBCC_8. Contratación de firma consultora para la supervisión de diseños y obras; 170 Etapa previa; 173 Formalización del contrato; 203 Pagos; 224 Ejecución del contrato; 230 Pagos CAF; 234 Ejecución del contrato; 236 Diseño de las redes elaborado; 237 Construcción de las colectoras; 238 Redes construidas; 242 Ejecución del contrato; 243 Elaboración del diseño final; 244 Diseño de las redes elaborado; 245 Construcción de las colectoras; 246 Redes construidas; 260 Diseño de las redes elaborado; 279 LPI_1. Contratación de firma constructora para la instalación de conexiones domiciliarias; 287 Cuenca de Aguacate; 299 Pagos BEI; 300 Pagos CL; 303 Pagos BID; 321 Ejecución del contrato; 326 Pagos CL; 329 Construcción de conexiones domiciliarias; 330 Conexiones domiciliarias construidas; 334 Ejecución de contrato; 335 Pagos BID; 336 Pagos CL; 337 Conexiones domiciliarias construidas en las cuencas de Caimito I y Caimito II; 338 LPI_3. Contratación de firma para el diseño y construcción de obras; 348 Conexiones domiciliarias construidas; 352 Ejecución de contrato; 355 Producto 6: Primer módulo de la PTAR e interceptor (Caimito) operando; 372 Pagos BID; 374 Pagos CL; 380 Pagos; 382 Pagos CAF; 383 Pagos CL; 402 Etapa de contratación; 405 Catastro técnico realizado - Año 2; 407 Pagos; 410 Pagos CL; 420 Hito 2: Campaña de monitoreo realizada - Año 6; 435 Hito 3: Campaña de monitoreo realizada - Año 5; 450 Hito 2: Actividades del Plan desarrolladas - Año 5; 451 Hito 2: Actividades del Plan desarrolladas - Año 6; 458 Etapa previa; 459 Expresión de interés; 460 Etapa de contratación; 461 Formalización del contrato; 462 Ejecución del contrato; 463 Hito 1: Instrumento para reglamentar el funcionamiento del Comité elaborado; 464 Hito 2: Actividades de transferencia de conocimientos- Año 3; 465 Hito 2: Actividades de transferencia de conocimientos - Año 4; 466 Pagos; 467 Pagos BID; 468 Pagos CAF; 469 Pagos CL; 471 Etapa previa; 472 Etapa de contratación; 473 Formalización del contrato; 474 Ejecución del contrato; 475 Hito 2: Actividades de transferencia de conocimientos - Año 5; 476 Pagos; 477 Pagos BID; 478 Pagos CAF; 479 Pagos CL; 481 Etapa previa; 482 Expresión de interés; 483 Etapa de contratación; 484 Formalización del contrato; 485 Ejecución del contrato; 486 Propuesta de estructura tarifaria aprobada; 487 Pagos; 488 Pagos BID; 489 Pagos CL; 490 Recursos adicionales; 494 Etapa previa; 495 Etapa de contratación; 496 Formalización del contrato; 497 Ejecución del contrato; 498 Elaboración del diseño final del proyecto; 499 Diseño del proyecto piloto elaborado; 500 Construcción de obras para protección de servidumbres; 501 Proyecto piloto de protección de servidumbre construido; 502 Pagos; 503 Pagos BID; 504 Pagos CAF; 505 Pagos CL; 507 Etapa previa; 508 Expresión de interés; 509 Etapa de contratación; 510 Formalización del contrato; 511 Ejecución del contrato; 512 Pagos; 513 Pagos BID; 514 Pagos CAF; 515 Pagos CL; 518 Actividades con el Municipio de Arraiján; 519 Actividades con el Municipio de La Chorrera; 522 Etapa previa; 523 Expresión de interés; 524 Etapa de contratación; 525 Formalización del contrato; 526 Ejecución del contrato; 527 Diseño del plan de sensibilización; 528 Plan de sensibilización diseñado; 529 Implementación del plan de sensibilización; 530 Actividades de sensibilización realizadas - Año 2; 531 Actividades de sensibilización realizadas - Año 3; 532 Pagos; 533 Pagos BID; 534 Pagos CAF; 535 Pagos CL; 537 Actividades de sensibilización realizadas - Año 4; 538 Actividades de sensibilización realizadas - Año 5; 543 Pagos; 544 Pagos BID; 545 Pagos AECID; 546 Pagos CAF; 547 Pagos BCIE; 548 Pagos BEI; 549 Pagos CL; 555 Etapa previa; 556 Expresión de interés; 557 Etapa de contratación; 558 Formalización del contrato; 559 Ejecución del contrato; 560 Pagos; 561 Pagos BID; 562 Pagos CL; 565 Etapa previa; 566 Etapa de contratación; 567 Formalización del contrato; 568 Ejecución del contrato; 569 Pagos; 570 Pagos BID; 571 Pagos CL; 573 Etapa previa; 574 Expresión de interés; 575 Etapa de contratación; 576 Formalización del contrato; 577 Ejecución del contrato; 578 Pagos; 579 Pagos BID; 580 Pagos CL; 582 Etapa previa; 583 Etapa de contratación; 584 Formalización del contrato; 585 Ejecución del contrato; 586 Pagos; 587 Pagos BID; 588 Pagos CL; 589 Recursos adicionales; 590 Fin de la ejecución del PSACH

Changed:

| ID | Task | Start | Finish | Duration | Total float | Predecessors | Other |
| --- | --- | --- | --- | --- | --- | --- | --- |
| 3 | **Obras** | 2019-05-08 → 2016-09-19 (-961d) | 2022-10-11 → 2021-01-06 (-643d) | 895d → 1043d | 58d → 95d |  | was named Cuenca de Caimito I |
| 6 | Preparación borrador documentos de licitación | 2017-09-25 → 2016-09-26 (-364d) | 2022-12-30 → 2016-10-18 (-2264d) | 1375d → 12d | 0d → 244d | none → 234SS+30d | was named SBCC_8. Contratación de firma consultora para la supervisión de diseños y obras; constraint none → start no earlier than 2016-09-19 |
| 10 | Solicitud de revisión | 2017-09-25 → 2016-11-03 (-326d) | 2022-12-30 → 2016-11-07 (-2244d) | 1375d → 3d | 0d → 244d | none → 9 | was named Ejecución de contrato |
| 11 | Revisión aprobada | 2017-09-25 → 2016-11-08 (-321d) | 2022-12-30 → 2016-11-14 (-2237d) | 1375d → 5d | 0d → 244d | 580SS → 10 | was named Pagos BID |
| 12 | Convocatoria pública a participar (Llamado a Licitación) | 2017-09-25 → 2016-11-15 (-314d) | 2022-12-30 → 2016-11-16 (-2235d) | 1375d → 2d | 0d → 244d | 11SS → 11 | was named Pagos CL |
| 13 | Preparacion de ofertas | 2017-03-20 → 2016-11-17 (-123d) | 2017-07-28 → 2017-01-17 (-192d) | 95d → 39d | 50d → 244d | Etapa de contratación → 12 | was named Formalización del contrato |
| 14 | Recepción de ofertas y apertura de sobres | 2022-10-21 → 2017-01-18 (-2102d) | 2022-10-21 → 2017-01-18 (-2102d) | 0d → 1d | 50d → 244d | 375 → 13 | was named O&M realizada |
| 16 | Solicitud de no objeción (Informe de Evaluación) | 2018-07-03 → 2017-02-09 (-509d) | 2020-12-21 → 2017-02-15 (-1405d) | 645d → 5d | 529d → 244d | 17SS → 15 | was named Pagos CL |
| 17 | No objeción del BID | 2018-07-03 → 2017-02-16 (-502d) | 2020-12-21 → 2017-02-22 (-1398d) | 645d → 5d | 529d → 244d | 18SS → 16 | was named Pagos BEI |
| 18 | Notificación a oferentes | 2018-07-03 → 2017-02-23 (-495d) | 2020-12-21 → 2017-03-03 (-1389d) | 645d → 7d | 529d → 244d | 19SS → 17 | was named Pagos BID |
| 19 | Negociacion de Contrato | 2018-07-03 → 2017-03-06 (-484d) | 2019-04-08 → 2017-03-17 (-752d) | 200d → 10d | 529d → 244d | Elaboración del diseño finalSS → 18 | was named Elaboración del diseño final |
| 20 | Publicación de la adjudicación lote A | 2018-07-03 → 2017-03-20 (-470d) | 2021-10-18 → 2017-03-21 (-1672d) | 860d → 2d | 314d → 244d | Elaboración del diseño finalSS → 19 | was named Pagos BID |
| 21 | Publicación de la adjudicación lote B | 2019-04-09 → 2017-03-20 (-750d) | 2020-12-28 → 2017-03-21 (-1378d) | 450d → 2d | 524d → 596d | 67 → 19 | was named Construcción de las redes |
| 22 | Suscripción del contrato lote A | 2018-07-03 → 2017-05-02 (-427d) | 2021-10-18 → 2017-05-08 (-1624d) | 860d → 5d | 314d → 221d | 20SS → 20, 599 | was named Pagos AECID |
| 23 | Suscripción del contrato lote B | 2020-12-28 → 2017-05-02 (-1336d) | 2020-12-28 → 2017-05-08 (-1330d) | 0d → 5d | 524d → 573d | 21 → 599, 21 | was named Redes construidas |
| 24 | Solicitud y aprobacion de garantías lote A | 2018-07-03 → 2017-05-09 (-420d) | 2021-10-18 → 2017-05-29 (-1603d) | 860d → 15d | 314d → 221d | 22SS → 22 | was named Pago CAF |
| 25 | Solicitud y aprobacion de garantías lote B | 2019-04-09 → 2017-05-09 (-700d) | 2020-12-28 → 2017-05-29 (-1309d) | 450d → 15d | 524d → 573d | none → 23 | was named Ejecución del contrato |
| 26 | Envío de contrato firmado al BID lote A | 2018-07-03 → 2017-05-09 (-420d) | 2021-10-18 → 2017-05-10 (-1622d) | 860d → 2d | 314d → 986d | 24SS → 22 | was named Pago CL |
| 27 | Envío de contrato firmado al BID lote B | 2019-04-09 → 2017-05-09 (-700d) | 2020-12-28 → 2017-05-10 (-1328d) | 450d → 2d | 524d → 986d | 21SS → 23 | was named Construcción de las conexiones domiciliarias |
| 29 | Orden de Inicio lote B | 2020-12-28 → 2017-05-30 (-1308d) | 2020-12-28 → 2017-05-30 (-1308d) | 0d → 1d | 524d → 573d | 27 → 121FS-70d, 25 | was named Conexiones domiciliarias construidas |
| 31 | **Estimaciones de Pago** | 2018-07-03 → 2017-05-11 (-418d) | 2020-12-28 → 2019-07-11 (-536d) | 650d → 532d | 524d → 0d |  | was named LPI_1. Contratación de firma para el diseño y construcción de obras |
| 32 | Pago del anticipo | 2018-07-03 → 2017-05-11 (-418d) | 2020-12-28 → 2017-05-12 (-1326d) | 650d → 2d | 524d → none |  | was named Cuenca de Prudente |
| 35 | Estimación 3 | 2019-08-26 → 2017-09-08 (-717d) | 2019-08-26 → 2017-09-11 (-714d) | 0d → 2d | 874d → none | Elaboración del diseño final → 34FS+20d | was named Diseño de la PTAR Caimito elaborado |
| 39 | Estimación 7 | 2016-04-04 → 2018-02-22 (+689d) | 2016-04-04 → 2018-02-23 (+690d) | 0d → 2d | 0d → 454d | none → 38FS+20d | was named Inicio de la preparación del Programa de Saneamiento de los Distritos de Arraiján y La Chorrera - PSACH Fase I |
| 40 | Estimación 8 |  | 2018-07-02 → 2018-04-03 (-90d) | 66d → 2d | 50d → 454d | Etapa de contratación → 39FS+20d | was named Formalización del contrato |
| 45 | Estimación 13 | 2017-08-04 → 2018-09-04 (+396d) | 2021-01-28 → 2018-09-05 (-876d) | 910d → 2d | 501d → 454d | none → 44FS+20d | was named Colectoras construidas en las cuencas de la muestra: Prudente, Aguacate y Bernardino |
| 46 | Estimación 14 | 2018-07-03 → 2018-10-11 (+100d) | 2020-12-28 → 2018-10-12 (-808d) | 650d → 2d | 524d → 454d | none → 45FS+20d | was named Cuenca de Aguacate |
| 47 | Estimación 15 | 2018-07-03 → 2018-11-12 (+132d) | 2020-12-28 → 2018-11-13 (-776d) | 650d → 2d | 524d → 454d | none → 46FS+20d | was named Ejecución del contrato |
| 49 | Estimación 17 | 2017-08-04 → 2019-02-18 (+563d) | 2022-12-30 → 2019-02-19 (-1410d) | 1411d → 2d | 0d → 454d | none → 48FS+20d | was named Producto 4: Redes de alcantarillado construidas |
| 53 | Ejecución Construcción lote B: Potrerillos- Pimienta | 2020-12-21 → 2017-05-31 (-1300d) | 2020-12-21 → 2018-05-31 (-935d) | 0d → 245d | 529d → 573d | 310 → 29 | was named Redes construidas |
| 55 | Pago del anticipo | 2018-07-03 → 2017-05-11 (-418d) | 2019-04-08 → 2017-05-12 (-696d) | 200d → 2d | 529d → none | 19SS → none | was named Elaboración del diseño final |
| 56 | Estimación 1 | 2019-04-08 → 2017-07-10 (-637d) | 2019-04-08 → 2017-07-11 (-636d) | 0d → 2d | 974d → none | 55 → 55FS+40d | was named Diseño de las redes elaborado |
| 57 | Estimación 2 | 2018-07-03 → 2017-08-09 (-328d) | 2020-12-28 → 2017-08-10 (-1236d) | 650d → 2d | 524d → none | none → 56FS+20d | was named Ejecución del contrato |
| 58 | Estimación 3 | 2018-07-03 → 2017-09-08 (-298d) | 2019-04-08 → 2017-09-11 (-574d) | 200d → 2d | 524d → none | Elaboración del diseño finalSS → 57FS+20d | was named Elaboración del diseño final |
| 59 | Estimación 4 | 2019-04-08 → 2017-10-18 (-537d) | 2019-04-08 → 2017-10-19 (-536d) | 0d → 2d | 524d → 680d | 58 → 58FS+20d | was named Diseño de redes elaborado |
| 60 | Estimación 5 | 2020-12-28 → 2017-11-17 (-1137d) | 2020-12-28 → 2017-11-20 (-1134d) | 0d → 2d | 524d → 680d | 61 → 59FS+20d | was named Redes construidas |
| 61 | Estimación 6 | 2019-04-09 → 2018-01-23 (-441d) | 2020-12-28 → 2018-01-24 (-1069d) | 450d → 2d | 524d → 680d | 59 → 60FS+40d | was named Construcción de las redes |
| 62 | Estimación 7 | 2020-12-28 → 2018-02-22 (-1040d) | 2020-12-28 → 2018-02-23 (-1039d) | 0d → 2d | 524d → 680d | 63 → 61FS+20d | was named Conexiones domiciliarias construidas |
| 63 | Estimación 8 | 2019-04-09 → 2018-04-02 (-372d) | 2020-12-28 → 2018-04-03 (-1000d) | 450d → 2d | 524d → 680d | 61SS → 62FS+20d | was named Construcción de las conexiones domiciliarias |
| 64 | Estimación 9 | 2019-04-09 → 2018-05-03 (-341d) | 2020-12-28 → 2018-05-04 (-969d) | 450d → 2d | 524d → 680d | none → 63FS+20d | was named Ejecución del contrato |
| 65 | Estimación 10 | 2018-07-03 → 2018-06-04 (-29d) | 2020-12-28 → 2018-06-05 (-937d) | 650d → 2d | 524d → 680d | none → 64FS+20d | was named Ejecución del contrato |
| 66 | Estimación 11 | 2018-07-03 → 2018-07-04 (+1d) | 2019-04-08 → 2018-07-05 (-277d) | 200d → 2d | 524d → 680d | Elaboración del diseño finalSS → 65FS+20d | was named Elaboración del diseño final |
| 67 | Estimación 12 | 2019-04-08 → 2018-08-03 (-248d) | 2019-04-08 → 2018-08-06 (-245d) | 0d → 2d | 524d → 680d | 66 → 66FS+20d | was named Diseño de redes elaborado |
| 72 | Respuesta del BID al borrador del Documento de Licitación | 2018-07-03 → 2018-04-23 (-71d) | 2020-12-21 → 2018-04-27 (-969d) | 645d → 5d | 529d → 61d | none → 71 | was named Cuenca de Bernardino |
| 73 | Incorporación observaciones al documentos de licitación | 2016-02-01 → 2018-04-30 (+819d) | 2022-01-28 → 2018-05-03 (-1366d) | 1565d → 3d | 0d → 61d | none → 72 | was named Colectoras construidas en las cuencas de Martín Sánchez I y II, Rodeo, Cruce y Puerto Caimito |
| 74 | Solicitud de no objeción al BID | 2017-11-14 → 2018-05-04 (+171d) | 2021-12-28 → 2018-05-08 (-1330d) | 1076d → 3d | 263d → 61d | none → 73 | was named LPI_2. Contratación de firma para el diseño y construcción de obras |
| 75 | No objeción del BID | 2018-12-26 → 2018-05-09 (-231d) | 2021-12-28 → 2018-05-15 (-1323d) | 785d → 5d | 263d → 61d | none → 74 | was named Cuenca de Martín Sánchez I |
| 78 | Recepción de ofertas y apertura de sobres | 2018-12-26 → 2018-07-03 (-176d) | 2021-05-11 → 2018-07-03 (-1043d) | 620d → 1d | 428d → 61d | none → 77 | was named Cuenca de Rodeo |
| 79 | Evaluación de ofertas | 2017-06-14 → 2018-07-04 (+385d) | 2020-03-31 → 2018-08-02 (-607d) | 730d → 22d | 718d → 61d | none → 78 | was named SBCC_14. Consultoría para realizar el catastro técnico para verificación de los sistemas de saneamiento |
| 80 | Solicitud de no objeción (Informe de Evaluación) | 2020-02-13 → 2018-08-03 (-559d) | 2022-11-30 → 2018-08-09 (-1574d) | 730d → 5d | 22d → 61d | none → 79 | was named Producto 11: Programa de monitoreo y control de descargas industriales al alcantarillado sanitario, implementado |
| 81 | No objeción del BID | 2016-01-04 → 2018-08-10 (+949d) | 2022-12-29 → 2018-08-16 (-1596d) | 1824d → 5d | 1d → 61d | none → 80 | was named Componente 3: Estudios y Acciones Complementarias |
| 82 | Notificación a oferentes | 2016-01-04 → 2018-08-17 (+956d) | 2022-12-29 → 2018-08-27 (-1585d) | 1824d → 7d | 1d → 61d | none → 81 | was named Producto 14: Proyecto piloto de protección de servidumbre de alcantarillado que genere espacios recreativos en márgenes de ríos, implementado |
| 83 | Negociacion de Contrato | 2020-04-09 → 2018-08-28 (-590d) | 2022-11-30 → 2018-09-10 (-1542d) | 690d → 10d | 1d → 61d | none → 82 | was named LPI_4. Contratación de firma para la elaboración del proyecto piloto y ejecución de las obras |
| 85 | Suscripción del contrato | 2020-04-09 → 2018-09-13 (-574d) | 2022-12-28 → 2018-09-19 (-1561d) | 710d → 5d | 2d → 61d | none → 84 | was named SBCC_14. Supervisión de obras |
| 86 | Solicitud y aprobacion de garantías | 2016-01-04 → 2018-09-20 (+990d) | 2016-02-02 → 2018-10-17 (+988d) | 22d → 15d | 1803d → 61d | Etapa previaSS → 85 | was named Incorporación en los TDR de los supervisores la responsabilidad de monitorear las áreas de servidumbre durante la etapa de construcción |
| 87 | Envío de contrato firmado al BID | 2020-04-10 → 2018-09-13 (-575d) | 2022-12-29 → 2018-09-14 (-1567d) | 710d → 2d | 1d → 651d | none → 84 | was named Coordinación de actividades con autoridades competentes |
| 88 | Orden de Inicio | 2017-07-10 → 2018-11-09 (+487d) | 2022-03-28 → 2018-11-09 (-1235d) | 1231d → 1d | 199d → 45d | none → 86, 317FS+22d | was named Producto 15: Actividades de sensibilización y educación para el manejo adecuado de residuos sólidos, implementadas |
| 89 | Ejecución Construcción | 2017-07-10 → 2018-11-12 (+490d) | 2020-03-30 → 2020-05-22 (+53d) | 711d → 370d | 199d → 45d | none → 88, 28 | was named SCC_17. Diseño e implementación de un plan de sensibilización para el manejo adecuado de residuos sólidos |
| 91 | Pago del anticipo | 2020-03-31 → 2018-11-01 (-516d) | 2022-03-28 → 2018-11-02 (-1242d) | 520d → 2d | 199d → 95d | Implementación del plan de sensibilización → 86FS+10d, 24FS+10d | was named Otras actividades a definir |
| 92 | Estimación 1 | 2016-08-22 → 2019-01-08 (+869d) | 2022-12-30 → 2019-01-09 (-1451d) | 1660d → 2d | 0d → 95d | none → 91FS+40d | was named Administración, Auditoría y Evaluación |
| 93 | Estimación 2 | 2016-08-22 → 2019-02-07 (+899d) | 2022-12-30 → 2019-02-08 (-1421d) | 1660d → 2d | 0d → 95d | none → 92FS+20d | was named Administración del Programa |
| 94 | Estimación 3 | 2016-08-22 → 2019-03-11 (+931d) | 2022-12-30 → 2019-03-12 (-1389d) | 1660d → 2d | 0d → 95d | none → 93FS+20d | was named Costos de funcionamiento de la UCPSP |
| 95 | Estimación 4 | 2017-04-10 → 2019-04-10 (+730d) | 2022-12-30 → 2019-04-11 (-1359d) | 1495d → 2d | 0d → 95d | 352FS+1d → 94FS+20d | was named Equipo de la UCPSP |
| 96 | Estimación 5 | 2016-08-22 → 2019-05-20 (+1001d) | 2016-12-30 → 2019-05-21 (+872d) | 95d → 2d | 1565d → 95d | 346 → 95FS+20d | was named Revisión de la estructura organizacional de la UCPSP |
| 97 | Estimación 6 | 2020-02-13 → 2019-07-17 (-211d) | 2022-11-30 → 2019-07-18 (-1231d) | 730d → 2d | 22d → 95d | none → 96FS+40d | was named SBCC_15. Consultoría para la elaboración del programa de monitoreo y control de descargas industriales |
| 103 | Estimación 12 | 2019-03-13 → 2020-03-16 (+369d) | 2021-12-28 → 2020-03-17 (-651d) | 730d → 2d | 263d → 95d | none → 102FS+20d | was named Cuenca de Martín Sánchez II |
| 106 | Estimación 15 | 2016-02-01 → 2020-07-23 (+1634d) | 2022-01-28 → 2020-07-24 (-553d) | 1565d → 2d | 0d → 95d | none → 105FS+40d | was named SBCC_7. Contratación de firma consultora para la supervisión de diseños y obras |
| 107 | Estimación 16 | 2016-02-01 → 2020-08-24 (+1666d) | 2016-09-09 → 2020-08-25 (+1446d) | 160d → 2d | 0d → 95d | Etapa previaSS+20d → 106FS+20d | was named Etapa previa |
| 108 | Estimación 17 | 2016-11-14 → 2020-09-24 (+1410d) | 2017-06-23 → 2020-09-25 (+1190d) | 160d → 2d | 240d → 95d | 471 → 107FS+20d | was named Etapa de contratación |
| 113 | Presentación de propuesta | 2018-07-03 → 2016-09-26 (-645d) | 2021-07-26 → 2016-09-30 (-1760d) | 800d → 5d | 374d → 338d | none → 112 | was named Ejecución del contrato |

| ID | Task | Start | Finish | Duration | Total float | Predecessors | Other |
| --- | --- | --- | --- | --- | --- | --- | --- |
| 115 | Invitación a negociación | 2019-05-08 → 2016-10-17 (-933d) | 2022-10-11 → 2016-10-18 (-2184d) | 895d → 2d | 58d → 338d | none → 114 | was named Pagos |
| 116 | Negociación del contrato | 2016-10-14 → 2016-10-19 (+5d) | 2016-10-14 → 2016-10-25 (+11d) | 1d → 5d | 0d → 338d | 347FS+30d → 115 |  |
| 122 | **Pagos** | 2018-07-03 → 2016-11-17 (-593d) | 2021-10-18 → 2017-08-28 (-1512d) | 860d → 192d | 314d → 908d |  |  |
| 123 | Pago No.1 | 2017-08-04 → 2016-11-17 (-260d) | 2021-11-25 → 2016-11-18 (-1833d) | 1125d → 2d | 286d → 908d | none → 120 | was named SBCC_7. Contratación de firma consultora para la supervisión de diseños y obras |
| 124 | Pago No.2 | 2017-08-04 → 2016-12-19 (-228d) | 2021-11-25 → 2016-12-20 (-1801d) | 1125d → 2d | 286d → 908d | none → 123FS+20d | was named Ejecución del contrato |
| 125 | Pago No.3 | 2017-08-04 → 2017-02-22 (-163d) | 2021-11-25 → 2017-02-23 (-1736d) | 1125d → 2d | 286d → 908d | Pagos BIDSS → 124FS+40d | was named Pagos BID |
| 128 | Pago No.6 | 2018-07-03 → 2017-08-25 (-312d) | 2019-08-26 → 2017-08-28 (-728d) | 300d → 2d | 374d → 908d | Elaboración del diseño finalSS → 127FS+40d | was named Elaboración del diseño final |
| 129 | **Caracterización Socioeconómica y Elaboración e Implementación Planes de Acción de Reasentamiento (PAR) Proyecto Corredor Turístico Libramiento El Progreso (siempre que cumpla con los criterios de elegibilidad)** | 2017-08-04 → 2017-04-28 (-98d) | 2021-11-25 → 2019-01-07 (-1053d) | 1125d → 413d | 286d → 45d | 125SS → none | was named Pagos CL |
| 130 | **Proceso de Contratación (SBCC)** | 2018-07-03 → 2017-04-28 (-431d) | 2020-03-23 → 2017-11-30 (-844d) | 450d → 148d | 724d → 45d | Elaboración del diseño finalSS → none | was named Pagos BID |
| 131 | Elaboración Anuncio Expresión de Interés | 2018-07-03 → 2017-04-28 (-431d) | 2020-03-23 → 2017-05-12 (-1046d) | 450d → 10d | 724d → 45d | 130SS → none | was named Pagos BCIE; constraint none → start no earlier than 2017-04-28 |
| 132 | Solicitud de no objeción del BID | 2018-07-03 → 2017-05-15 (-414d) | 2020-03-23 → 2017-05-16 (-1042d) | 450d → 2d | 724d → 45d | 131SS → 131 | was named Pagos CL |
| 133 | No objeción del BID | 2018-07-03 → 2017-05-17 (-412d) | 2020-12-28 → 2017-05-23 (-1315d) | 650d → 5d | 524d → 45d | Elaboración del diseño finalSS → 132 | was named Pagos BID |
| 134 | Publicación anuncio con solicitud de expresiones de interés | 2018-07-03 → 2017-05-24 (-405d) | 2020-12-28 → 2017-05-24 (-1314d) | 650d → 1d | 524d → 45d | 133SS → 133 | was named Pagos BCIE |
| 135 | Recepcion de Expresiones de Interes | 2018-07-03 → 2017-05-25 (-404d) | 2020-12-28 → 2017-06-08 (-1299d) | 650d → 11d | 524d → 45d | 134SS → 134 | was named Pagos CL |
| 139 | No objeción del BID a la lista corta | 2017-08-04 → 2017-07-17 (-18d) | 2021-01-28 → 2017-07-21 (-1287d) | 910d → 5d | 501d → 934d | none → 138 | was named SBCC_6. Contratación de firma consultora para la supervisión de diseños y obras |
| 142 | No objeción del BID al SP y presupuesto | 2017-08-04 → 2017-06-26 (-39d) | 2021-01-28 → 2017-06-30 (-1308d) | 910d → 5d | 501d → 45d | none → 141 | was named Ejecución del contrato |
| 144 | Remisión de SP a integrantes de la lista corta | 2017-08-04 → 2017-07-10 (-25d) | 2021-01-28 → 2017-07-11 (-1297d) | 910d → 2d | 501d → 45d | 125SS → 143 | was named Pagos BID |
| 145 | Presentación de propuesta | 2017-08-04 → 2017-07-12 (-23d) | 2021-01-28 → 2017-08-24 (-1253d) | 910d → 32d | 501d → 45d | 144SS → 144 | was named Pagos CL |
| 146 | Evaluación de propuestas técnicas | 2018-07-03 → 2017-08-25 (-312d) | 2020-12-28 → 2017-09-14 (-1201d) | 650d → 15d | 524d → 45d | 58SS → 145 | was named Pagos BCIE |
| 147 | Solicitud de no objeción del BID | 2018-07-03 → 2017-09-18 (-288d) | 2020-12-28 → 2017-09-19 (-1196d) | 650d → 2d | 524d → 45d | 146SS → 146 | was named Pagos CL |
| 149 | Notificación de resultados a los participantes (Evaluación técnica) | 2018-07-03 → 2017-09-27 (-279d) | 2020-12-28 → 2017-09-28 (-1187d) | 650d → 2d | 524d → 45d | 66SS → 148 | was named Pagos BCIE |
| 150 | Apertura de propuestas de precios | 2018-07-03 → 2017-09-29 (-277d) | 2020-12-28 → 2017-10-10 (-1175d) | 650d → 3d | 524d → 45d | 149SS → 149 | was named Pagos CL |
| 152 | Negociación del contrato | 2018-07-03 → 2017-10-18 (-258d) | 2020-12-21 → 2017-10-24 (-1154d) | 645d → 5d | 529d → 45d | 55SS → 151 | was named Pagos BEI |
| 153 | Solicitud de No Objeción al BID a Evaluación combinada y a borrador del contrato negociado | 2018-07-03 → 2017-10-25 (-251d) | 2020-12-21 → 2017-10-26 (-1152d) | 645d → 2d | 529d → 45d | 152SS → 152 | was named Pagos CL |
| 154 | No objeción | 2017-08-04 → 2017-10-27 (+84d) | 2021-01-28 → 2017-11-02 (-1183d) | 910d → 5d | 501d → 45d | none → 153 | was named SBCC_6. Contratación de firma consultora para la supervisión de diseños y obras |
| 155 | Publicación de la adjudicación y notificacion al ganador | 2017-08-04 → 2017-11-03 (+91d) | 2021-01-28 → 2017-11-06 (-1179d) | 910d → 2d | 501d → 45d | none → 154 | was named Ejecución del contrato |
| 156 | Suscripción del contrato | 2017-08-04 → 2017-11-07 (+95d) | 2021-01-28 → 2017-11-09 (-1176d) | 910d → 3d | 501d → 45d | 144SS → 155 | was named Pagos BID |
| 157 | Presentación de garantía bancarias | 2017-08-04 → 2017-11-10 (+98d) | 2021-01-28 → 2017-11-30 (-1155d) | 910d → 15d | 501d → 846d | 156SS → 156 | was named Pagos CL |
| 161 | **Pagos** | 2017-08-04 → 2017-11-13 (+101d) | 2021-11-25 → 2019-01-07 (-1053d) | 1125d → 279d | 286d → 581d |  |  |
| 163 | Pago No.1 | 2019-04-09 → 2017-12-13 (-482d) | 2020-12-28 → 2017-12-14 (-1110d) | 450d → 2d | 524d → 581d | none → 162FS+20d | was named Pagos |
| 164 | Pago No.2 | 2019-04-09 → 2018-02-16 (-417d) | 2020-12-28 → 2018-02-19 (-1043d) | 450d → 2d | 524d → 581d | 27SS → 163FS+40d | was named Pagos BCIE |
| 165 | Pago No.3 | 2019-04-09 → 2018-03-20 (-385d) | 2020-12-28 → 2018-03-21 (-1013d) | 450d → 2d | 524d → 581d | 164SS → 164FS+20d | was named Pagos CL |
| 173 | **Proceso de contratación (CD)** | 2019-04-30 → 2016-10-31 (-911d) | 2020-12-21 → 2017-01-20 (-1431d) | 430d → 55d | 529d → 808d |  | was named Cuenca de Bernardino |
| 174 | Elaboración de especificaciones técnicas | 2019-04-30 → 2016-10-31 (-911d) | 2020-12-21 → 2016-11-11 (-1501d) | 430d → 10d | 529d → 808d | none → 112FS+20d | was named Pagos |
| 175 | Invitación a presentar ofertas | 2020-12-21 → 2016-11-14 (-1498d) | 2020-12-21 → 2016-11-15 (-1497d) | 0d → 2d | 529d → 808d | 423 → 174 | was named Conexiones domiciliarias construidas |
| 177 | Evaluación ofertas | 2017-08-04 → 2016-11-30 (-247d) | 2021-01-28 → 2016-12-08 (-1512d) | 910d → 7d | 501d → 808d | none → 176 | was named SBCC_6. Contratación de firma consultora para la supervisión de diseños y obras |
| 178 | Negociación | 2018-12-26 → 2016-12-09 (-747d) | 2019-06-11 → 2016-12-15 (-908d) | 120d → 5d | 598d → 808d | 215SS → 177 | was named Elaboración del diseño final |
| 179 | Solicitud de aprobación contrato a CD | 2017-08-04 → 2016-12-16 (-231d) | 2021-01-28 → 2017-01-12 (-1477d) | 910d → 15d | 501d → 808d | none → 178 | was named Ejecución del contrato |
| 180 | Suscripción de contrato | 2017-08-04 → 2017-01-13 (-203d) | 2021-01-28 → 2017-01-19 (-1470d) | 910d → 5d | 501d → 808d | Pagos BIDSS → 179 | was named Pagos CL |
| 183 | **Pagos** | 2018-07-03 → 2017-02-20 (-498d) | 2021-07-26 → 2017-11-30 (-1334d) | 800d → 192d | 374d → 846d |  |  |
| 186 | Pago 3 | 2017-11-14 → 2017-05-29 (-169d) | 2018-02-12 → 2017-05-30 (-258d) | 65d → 2d | 263d → 846d | Formalización del contratoFS+36d → 185FS+40d | was named Etapa previa |
| 187 | Pago 4 | 2018-02-13 → 2017-06-28 (-230d) | 2018-08-20 → 2017-06-29 (-417d) | 135d → 2d | 263d → 846d | 186 → 186FS+20d | was named Etapa de contratación |
| 188 | Pago 5 | 2018-12-26 → 2017-09-25 (-457d) | 2021-12-28 → 2017-09-26 (-1554d) | 785d → 2d | 263d → 846d | none → 187FS+60d | was named Ejecución del contrato |
| 189 | Pago 6 | 2018-12-26 → 2017-11-29 (-392d) | 2021-12-28 → 2017-11-30 (-1489d) | 785d → 2d | 263d → 846d | Elaboración del diseño finalSS → 188FS+40d | was named Pagos BID |
| 190 | **Fideicomiso de apoyo a implementación de Planes de Reasentamiento proyecto Corredor Turístico Libramiento El Progreso (siempre que cumpla con los criterios de elegibilidad)** | 2019-10-29 → 2017-07-12 (-839d) | 2019-10-29 → 2019-11-22 (+24d) | 0d → 580d | 828d → 362d | Elaboración del diseño final → none | was named Diseño de las colectoras elaborado |
| 191 | **Proceso de contratación (LPN)** | 2019-03-27 → 2017-07-12 (-623d) | 2021-12-28 → 2017-11-02 (-1517d) | 720d → 76d | 263d → 362d | Elaboración del diseño finalSS+65d → none | was named Construcción de las colectoras |
| 192 | Elaboración de especificaciones técnicas | 2021-12-28 → 2017-07-12 (-1630d) | 2021-12-28 → 2017-07-25 (-1617d) | 0d → 10d | 263d → 362d | 191 → 144 | was named Colectoras construidas |
| 193 | Preparación de LPN | 2018-08-21 → 2017-07-26 (-391d) | 2018-12-24 → 2017-08-01 (-510d) | 90d → 5d | 263d → 362d | 187 → 192 | was named Formalización del contrato |
| 194 | Solicitud de No Objeción del BID de LPN | 2018-12-26 → 2017-08-02 (-511d) | 2021-12-28 → 2017-08-03 (-1608d) | 785d → 2d | 263d → 362d | none → 193 | was named Ejecución del contrato |
| 195 | No Objeción | 2018-12-26 → 2017-08-04 (-509d) | 2019-10-29 → 2017-08-10 (-810d) | 220d → 5d | 263d → 362d | Elaboración del diseño finalSS → 194 | was named Elaboración del diseño final |
| 196 | Publicación LPN | 2019-10-29 → 2017-08-11 (-809d) | 2019-10-29 → 2017-08-14 (-806d) | 0d → 2d | 828d → 362d |  | was named Diseño de las redes elaborado |
| 197 | Recepción de ofertas | 2019-03-27 → 2017-08-15 (-589d) | 2021-12-28 → 2017-09-13 (-1567d) | 720d → 22d | 263d → 362d | 195SS+65d → 196 | was named Construcción de las colectoras |
| 198 | Evaluación ofertas | 2021-12-28 → 2017-09-14 (-1566d) | 2021-12-28 → 2017-10-12 (-1538d) | 0d → 15d | 263d → 362d |  | was named Redes construidas |
| 199 | Solicitud de No Objeción a informe de evaluación | 2018-12-26 → 2017-10-13 (-439d) | 2021-12-28 → 2017-10-16 (-1534d) | 785d → 2d | 263d → 362d | 520SS → 198 | was named Pagos BCIE |
| 200 | No Objeción | 2018-12-26 → 2017-10-17 (-435d) | 2021-12-28 → 2017-10-23 (-1527d) | 785d → 5d | 263d → 362d | 199SS → 199 | was named Pagos BEI |
| 202 | Envío de contrato firmado y formulario Sistem Prism al BID | 2018-12-26 → 2017-10-31 (-421d) | 2021-12-28 → 2017-11-01 (-1518d) | 785d → 2d | 263d → 362d | 200SS → 201 | was named Pagos CL |
| 203 | Orden de inicio | 2019-03-27 → 2017-11-02 (-510d) | 2021-12-28 → 2017-11-02 (-1517d) | 720d → 1d | 263d → 362d | none → 202 | was named Ejecución del contrato |
| 204 | Ejecución de consultoría | 2019-03-27 → 2017-11-03 (-509d) | 2021-12-28 → 2019-05-14 (-959d) | 720d → 370d | 263d → 496d | 197SS → 203 | was named Construcción de conexiones domiciliarias |
| 205 | **Pagos** | 2018-07-03 → 2018-01-05 (-179d) | 2020-03-23 → 2019-11-22 (-122d) | 450d → 464d | 724d → 362d |  |  |
| 206 | Pago 1 | 2019-03-13 → 2018-01-05 (-432d) | 2019-12-17 → 2018-01-08 (-708d) | 200d → 2d | 263d → 362d | 195SS+55d → 203FS+40d | was named Elaboración del diseño final |
| 207 | Pago 2 | 2019-12-17 → 2018-03-06 (-651d) | 2019-12-17 → 2018-03-07 (-650d) | 0d → 2d | 793d → 362d | 206 → 206FS+40d | was named Diseño de las redes elaborado |
| 208 | Pago 3 | 2019-12-18 → 2018-05-11 (-586d) | 2021-12-28 → 2018-05-14 (-1324d) | 530d → 2d | 263d → 362d | 206 → 207FS+40d | was named Construcción de las colectoras |
| 209 | Pago 4 | 2021-12-28 → 2018-07-10 (-1267d) | 2021-12-28 → 2018-07-11 (-1266d) | 0d → 2d | 263d → 362d | 208 → 208FS+40d | was named Redes construidas |
| 211 | Pago 6 | 2019-03-13 → 2018-11-12 (-121d) | 2019-12-17 → 2018-11-13 (-399d) | 200d → 2d | 263d → 362d | Elaboración del diseño finalSS+55d → 210FS+40d | was named Elaboración del diseño final |
| 212 | Pago 7 | 2019-12-17 → 2019-01-17 (-334d) | 2019-12-17 → 2019-01-18 (-333d) | 0d → 2d | 263d → 362d | 211 → 211FS+40d | was named Diseño de las colectoras elaborado |
| 213 | Pago 8 | 2019-12-18 → 2019-03-18 (-275d) | 2021-12-28 → 2019-03-19 (-1015d) | 530d → 2d | 263d → 362d | 212 → 212FS+40d | was named Construcción de las colectoras |
| 214 | Pago 9 | 2021-12-28 → 2019-05-23 (-950d) | 2021-12-28 → 2019-05-24 (-949d) | 0d → 2d | 263d → 362d | 213 → 213FS+40d | was named Colectoras construidas |
| 215 | Pago 10 | 2018-12-26 → 2019-07-22 (+208d) | 2019-06-11 → 2019-07-23 (+42d) | 120d → 2d | 428d → 362d | Elaboración del diseño finalSS → 214FS+40d | was named Elaboración del diseño final |
| 216 | Pago 11 | 2019-06-11 → 2019-09-18 (+99d) | 2019-06-11 → 2019-09-19 (+100d) | 0d → 2d | 928d → 362d | 215 → 215FS+40d | was named Diseño de las colectoras elaborado |
| 217 | Pago 12 | 2019-03-27 → 2019-11-21 (+239d) | 2020-06-30 → 2019-11-22 (-221d) | 330d → 2d | 653d → 362d | 215SS+65d → 216FS+40d | was named Construcción de las colectoras |

| ID | Task | Start | Finish | Duration | Total float | Predecessors | Other |
| --- | --- | --- | --- | --- | --- | --- | --- |
| 219 | Pago 1 | 2018-12-26 → 2017-04-20 (-615d) | 2020-09-15 → 2017-04-21 (-1243d) | 450d → 2d | 428d → 874d | none → 121SS+100d | was named Cuenca de Cruce y Puerto Caimito |
| 222 | Pago 4 | 2018-12-26 → 2018-12-04 (-22d) | 2020-09-15 → 2018-12-05 (-650d) | 450d → 2d | 598d → 182d | 215SS → 160FS+40d | was named Pagos BEI |
| 223 | Pago 5 | 2018-12-26 → 2019-02-08 (+44d) | 2020-09-15 → 2019-02-11 (-582d) | 450d → 2d | 598d → 182d | 222SS → 222FS+40d | was named Pagos CL |
| 225 | Pago 7 | 2019-08-26 → 2019-07-12 (-45d) | 2019-08-26 → 2019-07-15 (-42d) | 0d → 2d | 874d → 182d | 128 → 224FS+40d | was named Diseño del interceptor elaborado |
| 226 | Pago 8 | 2021-07-26 → 2019-09-10 (-685d) | 2021-07-26 → 2019-09-11 (-684d) | 0d → 2d | 374d → 182d | 227 → 225FS+40d | was named Interceptor construido |
| 227 | Pago 9 | 2018-09-25 → 2019-11-13 (+414d) | 2021-07-26 → 2019-11-14 (-620d) | 740d → 2d | 374d → 182d | Construcción de la PTARSS → 226FS+40d | was named Construcción del interceptor |
| 231 | **Supervisión** | 2016-03-28 → 2016-08-15 (+140d) | 2016-12-30 → 2020-07-28 (+1306d) | 200d → 964d | 0d → 199d | Etapa previa → none | was named Etapa de contratación |
| 232 | **Supervisión Construcción Carretera CA-5 Norte, La Barca- Pimienta (20 meses)** | 2017-09-25 → 2016-08-15 (-406d) | 2022-12-30 → 2019-04-30 (-1340d) | 1375d → 658d | 0d → 244d |  | was named Ejecución de contrato |
| 233 | **Proceso de Contratación** | 2018-01-03 → 2016-08-15 (-506d) | 2022-11-30 → 2017-05-25 (-2015d) | 1281d → 188d | 22d → 244d |  | was named LPI_3. Contratación de firma para el diseño y construcción de obras |
| 234 | Elaboración Anuncio Expresión de Interés | 2019-02-13 → 2016-08-15 (-912d) | 2022-10-11 → 2016-08-26 (-2237d) | 955d → 10d | 22d → 244d |  | was named Cuenca de Caimito I; constraint none → start no earlier than 2016-08-15 |
| 235 | Solicitud de revisión | 2019-02-13 → 2016-08-29 (-898d) | 2022-10-11 → 2016-08-30 (-2233d) | 955d → 2d | 58d → 524d | none → 234 | was named Pagos |
| 237 | Publicación anuncio con solicitud de expresiones de interés | 2019-02-13 → 2016-09-07 (-889d) | 2022-11-29 → 2016-09-07 (-2274d) | 990d → 1d | 22d → 524d | none → 236 | was named Cuenca de Caimito II |
| 238 | Recepcion de Expresiones de Interes | 2019-02-13 → 2016-09-08 (-888d) | 2022-11-29 → 2016-09-22 (-2259d) | 990d → 11d | 23d → 524d | none → 237 | was named Pagos |
| 240 | Elaboración de lista corta | 2021-05-12 → 2016-11-01 (-1653d) | 2022-11-30 → 2016-11-03 (-2218d) | 406d → 3d | 22d → 524d | none → 239 | was named Cuenca de Punta Piedras |
| 241 | Solicitud de revisión | 2021-05-12 → 2016-11-04 (-1650d) | 2022-11-29 → 2016-11-04 (-2216d) | 405d → 1d | 23d → 524d | none → 240 | was named Pagos |
| 263 | Ejecución de la supervisión | 2017-08-04 → 2017-05-08 (-88d) | 2022-12-30 → 2018-12-18 (-1473d) | 1411d → 400d | 0d → 589d | none → 262 | was named Producto 5: Conexiones domiciliarias construidas |
| 264 | **Pagos** | 2018-07-03 → 2017-05-08 (-421d) | 2020-12-28 → 2019-04-30 (-608d) | 650d → 484d | 524d → 505d |  |  |
| 265 | Pago No.1 | 2019-04-09 → 2017-05-08 (-701d) | 2020-12-28 → 2017-05-11 (-1327d) | 450d → 4d | 524d → 505d | none → 262 | was named Cuenca de Prudente |
| 266 | Pago No.2 | 2019-04-09 → 2017-06-09 (-669d) | 2020-12-28 → 2017-06-14 (-1293d) | 450d → 4d | 524d → 505d | none → 265FS+20d | was named Pagos |
| 267 | Pago No.3 | 2019-04-09 → 2017-07-13 (-635d) | 2020-12-28 → 2017-07-18 (-1259d) | 450d → 4d | 524d → 505d | 63SS → 266FS+20d | was named Pagos BCIE |
| 268 | Pago No.4 | 2019-04-09 → 2017-08-16 (-601d) | 2020-12-28 → 2017-08-21 (-1225d) | 450d → 4d | 524d → 505d | 267SS → 267FS+20d | was named Pagos CL |
| 269 | Pago No.5 | 2017-09-25 → 2017-09-20 (-5d) | 2022-01-28 → 2017-09-25 (-1586d) | 1135d → 4d | 240d → 505d | none → 268FS+20d | was named Conexiones domiciliarias construidas en las cuencas Martín Sánchez I, Martín Sánchez II, Rodeo y Puerto Caimito |
| 270 | Pago No.6 | 2019-03-27 → 2017-10-31 (-512d) | 2021-12-28 → 2017-11-03 (-1516d) | 720d → 4d | 263d → 505d | none → 269FS+20d | was named LPI_2. Contratación de firma constructora para la instalación de conexiones domiciliarias |
| 279 | Pago No.15 | 2017-02-06 → 2018-08-10 (+550d) | 2022-12-30 → 2018-08-15 (-1598d) | 1540d → 4d | 0d → 505d | none → 278FS+20d | was named Componente 2: Fortalecimiento Institucional |
| 280 | Pago No.16 | 2017-05-09 → 2018-09-13 (+492d) | 2022-12-26 → 2018-09-18 (-1560d) | 1470d → 4d | 4d → 505d | none → 279FS+20d | was named Producto 7: Actividades de capacitación en O&M e implementación del SIG desarrolladas |
| 281 | Pago No.17 | 2017-05-09 → 2018-10-24 (+533d) | 2017-12-04 → 2018-10-29 (+329d) | 150d → 4d | 4d → 505d | none → 280FS+20d | was named CCIN_20. Consultoría individual para la elaboración del Plan de Capacitación para la UCP |
| 282 | Pago No.18 | 2017-12-05 → 2018-11-27 (+357d) | 2020-04-13 → 2018-11-30 (-500d) | 615d → 4d | 709d → 505d | none → 281FS+20d | was named CP_24. Implementación del plan de capacitación para la UCP en temas de habilidades blandas y metodologías de gestión de proyectos |
| 283 | Pago No.19 | 2017-12-05 → 2019-01-08 (+399d) | 2022-12-26 → 2019-01-11 (-1445d) | 1320d → 4d | 4d → 505d | 417 → 282FS+20d | was named Desarrollo de otras actividades a definir |
| 284 | Pago No. 20 | 2017-02-06 → 2019-02-11 (+735d) | 2018-03-30 → 2019-02-14 (+321d) | 300d → 4d | 1240d → 505d | none → 283FS+20d | was named Producto 8: Instrumento reglamentario del Convenio IDAAN – UCP aprobado |
| 285 | Pago No. 21 | 2017-02-06 → 2019-03-15 (+767d) | 2018-03-30 → 2019-03-20 (+355d) | 300d → 4d | 1240d → 505d | none → 284FS+20d | was named SCC_9. Consultoría para la elaboración del instrumento reglamentario para la implementación del Convenio IDAAN/MINSA |
| 286 | Pago No. 22 | 2017-10-02 → 2019-04-25 (+570d) | 2018-03-30 → 2019-04-30 (+396d) | 130d → 4d | 1240d → 505d | 434SS → 285FS+20d | was named Recursos adicionales |
| 287 | **Supervisión Construcción de obras Corredor Turístico Libramiento El Progreso (siempre que cumpla con los criterios de elegibilidad)** | 2020-02-13 → 2018-01-08 (-766d) | 2022-11-30 → 2020-07-28 (-855d) | 730d → 626d | 22d → 59d |  | was named Producto 12: Plan de Fortalecimiento de DISAPAS implementado |
| 288 | **Proceso de Contratación** | 2020-02-13 → 2018-01-08 (-766d) | 2022-11-30 → 2018-10-09 (-1513d) | 730d → 186d | 22d → 59d |  | was named SBCC_10. Consultoría para la elaboración de un diagnóstico y de un plan de fortalecimiento para la DISAPAS, incluyendo la implementación |
| 289 | Elaboración Anuncio Expresión de Interés | 2020-11-19 → 2018-01-08 (-1046d) | 2022-11-30 → 2018-01-19 (-1776d) | 530d → 10d | 22d → 59d | 491SS → none | was named Recursos adicionales; constraint none → start no earlier than 2018-01-08 |
| 290 | Solicitud de no objeción del BID | 2017-12-21 → 2018-01-22 (+32d) | 2022-02-10 → 2018-01-23 (-1479d) | 1081d → 2d | 231d → 59d | none → 289 | was named Producto 13: Actividades para fortalecer la sostenibilidad del sistema de saneamiento, implementadas |
| 291 | No objeción del BID | 2018-03-23 → 2018-01-24 (-58d) | 2021-01-07 → 2018-01-30 (-1073d) | 730d → 5d | 231d → 59d | none → 290 | was named SBCC_11. Consultoría para la elaboración e implementación de un plan de fortalecimiento para el sector saneamiento |
| 292 | Publicación anuncio con solicitud de expresiones de interés | 2020-04-03 → 2018-01-31 (-793d) | 2022-02-10 → 2018-01-31 (-1471d) | 485d → 1d | 231d → 59d | none → 291 | was named CP_5. Realización de actividades complementarias del plan de fortalecimiento |
| 293 | Recepcion de Expresiones de Interes | 2017-12-21 → 2018-02-01 (+42d) | 2018-12-19 → 2018-02-15 (-307d) | 260d → 11d | 1052d → 59d | none → 292 | was named SCC_12. Elaboración de la propuesta de adecuación de la estructura y del nivel tarifario de los servicios de alcantarillado sanitario |
| 297 | No objeción del BID a la lista corta | 2019-06-03 → 2018-04-02 (-427d) | 2022-12-30 → 2018-04-06 (-1729d) | 935d → 5d | 0d → 59d | none → 296 | was named Producto 10: Programa de monitoreo de la calidad de agua de ríos y quebradas del PSACH |
| 298 | Elaboración de SP, TdeR y de presupuesto | 2019-06-03 → 2018-04-09 (-420d) | 2022-12-30 → 2018-04-20 (-1715d) | 935d → 10d | 0d → 59d | none → 297 | was named SBC_13. Consultoría para la realización de actividades del Programa de monitoreo de la calidad del agua |
| 299 | Solicitud de no objeción al BID SP y Presupuesto | 2020-03-09 → 2018-04-23 (-686d) | 2022-12-30 → 2018-04-23 (-1712d) | 735d → 1d | 0d → 59d | 465SS → 298 | was named Recusos adicionales |
| 300 | No objeción del BID al SP y presupuesto | 2017-06-14 → 2018-04-24 (+314d) | 2020-03-31 → 2018-04-30 (-701d) | 730d → 5d | 718d → 59d | none → 299 | was named Producto 9: Catastro técnico para verificación de los sistemas pluvial y sanitario existentes, realizada |
| 301 | Notificación de conformación de lista corta | 2017-08-04 → 2018-05-02 (+271d) | 2021-01-28 → 2018-05-08 (-996d) | 910d → 5d | 501d → 59d | none → 300 | was named Redes construidas en las cuencas de la muestra: Prudente, Aguacate y Bernardino |
| 302 | Remisión de SP a integrantes de la lista corta | 2018-07-03 → 2018-05-09 (-55d) | 2020-12-28 → 2018-05-10 (-963d) | 650d → 2d | 524d → 59d | none → 301 | was named LPI_1. Contratación de firma para el diseño y construcción de obras |
| 303 | Presentación de propuesta | 2018-07-03 → 2018-05-11 (-53d) | 2020-12-28 → 2018-06-11 (-931d) | 650d → 22d | 524d → 59d | none → 302 | was named Cuenca de Prudente |
| 304 | Evaluación de propuestas técnicas | 2018-07-03 → 2018-06-12 (-21d) | 2020-12-28 → 2018-07-11 (-901d) | 650d → 22d | 524d → 59d | none → 303 | was named Pagos |
| 306 | No objeción del BID | 2018-07-03 → 2018-07-16 (+13d) | 2020-12-28 → 2018-07-20 (-892d) | 650d → 5d | 524d → 59d | none → 305 | was named Cuenca de Aguacate |
| 307 | Notificación de resultados a los participantes (Evaluación técnica) | 2018-07-03 → 2018-07-23 (+20d) | 2020-12-28 → 2018-07-24 (-888d) | 650d → 2d | 524d → 59d | none → 306 | was named Pagos |
| 309 | Evaluación combinada de calidad y costo | 2018-07-03 → 2018-07-30 (+27d) | 2020-12-21 → 2018-08-03 (-871d) | 645d → 5d | 529d → 59d | none → 308 | was named Cuenca de Bernardino |
| 310 | Negociación del contrato | 2019-04-30 → 2018-08-06 (-267d) | 2020-12-21 → 2018-08-17 (-857d) | 430d → 10d | 529d → 59d | Construcción de las colectorasSS → 309 | was named Construcción de las redes |
| 312 | No objeción | 2017-09-25 → 2018-08-27 (+336d) | 2022-01-28 → 2018-08-31 (-1246d) | 1135d → 5d | 240d → 59d | none → 311 | was named Redes construidas en las cuencas de Martín Sánchez I y II, Rodeo y Puerto Caimito |
| 313 | Publicación de la adjudicación y notificacion al ganador | 2017-09-25 → 2018-09-03 (+343d) | 2022-01-28 → 2018-09-04 (-1242d) | 1135d → 2d | 240d → 59d | none → 312 | was named SBCC_7. Contratación de firma consultora para la supervisión de diseños y obras |
| 316 | Envío de contrato firmado al BID y formulario PRISM | 2017-09-25 → 2018-09-12 (+352d) | 2022-01-28 → 2018-09-13 (-1233d) | 1135d → 2d | 240d → 652d | none → 314 | was named Ejecución de contrato |
| 317 | Orden de Inicio | 2018-12-26 → 2018-10-09 (-78d) | 2021-12-28 → 2018-10-09 (-1176d) | 785d → 1d | 263d → 45d | none → 314, 160 | was named LPI_2. Contratación de firma para el diseño y construcción de obras |
| 318 | Ejecución de la supervisión | 2018-12-26 → 2018-10-10 (-77d) | 2021-12-28 → 2020-06-16 (-560d) | 785d → 410d | 263d → 229d | none → 317 | was named Cuenca de Martín Sánchez I |
| 319 | **Pagos** | 2018-12-26 → 2018-11-07 (-49d) | 2021-12-28 → 2020-07-28 (-518d) | 785d → 420d | 263d → 199d |  |  |
| 321 | Pago No.2 | 2019-03-13 → 2018-12-07 (-96d) | 2021-12-28 → 2018-12-10 (-1114d) | 730d → 2d | 263d → 199d | none → 320FS+20d | was named Cuenca de Martín Sánchez II |
| 322 | Pago No.3 | 2019-03-13 → 2019-01-16 (-56d) | 2021-12-28 → 2019-01-17 (-1076d) | 730d → 2d | 263d → 199d | none → 321FS+20d | was named Pagos |
| 324 | Pago No.5 | 2018-12-26 → 2019-03-19 (+83d) | 2021-05-11 → 2019-03-20 (-783d) | 620d → 2d | 428d → 199d | none → 323FS+20d | was named Cuenca de Rodeo |
| 325 | Pago No.6 | 2018-12-26 → 2019-04-25 (+120d) | 2021-05-11 → 2019-04-26 (-746d) | 620d → 2d | 428d → 199d | none → 324FS+20d | was named Pagos |
| 327 | Pago No.8 | 2017-09-25 → 2019-06-27 (+640d) | 2022-12-30 → 2019-06-28 (-1281d) | 1375d → 2d | 0d → 199d | none → 326FS+20d | was named Redes construidas en las cuencas de Caimito I y Caimito II |
| 342 | **Proceso de Contratación** | 2016-04-04 → 2018-02-05 (+672d) | 2017-04-05 → 2018-09-12 (+525d) | 263d → 152d | 0d → 484d |  | was named Actividades previas |
| 343 | Elaboración Anuncio | 2016-04-04 → 2018-02-05 (+672d) | 2016-04-08 → 2018-02-07 (+670d) | 5d → 3d | 0d → 484d | 39 → none | was named Misión de Identificación; constraint none → start no earlier than 2018-02-05 |
| 344 | Solicitud de no objeción del BID | 2016-06-06 → 2018-02-08 (+612d) | 2016-06-10 → 2018-02-08 (+608d) | 5d → 1d | 0d → 484d | 345FS+6d → 343 | was named Misión de Orientación |
| 345 | No objeción del BID | 2016-05-26 → 2018-02-09 (+624d) | 2016-05-26 → 2018-02-15 (+630d) | 1d → 5d | 0d → 484d | 343FS+33d → 344 | was named Disponibilidad del Perfil del Proyecto |
| 346 | Publicación anuncio con solicitud de expresiones de interés | 2016-08-16 → 2018-02-16 (+549d) | 2016-08-19 → 2018-02-19 (+549d) | 4d → 2d | 0d → 484d | 344FS+46d → 345 | was named Misión de Análisis |
| 347 | Recepcion de Expresiones de Interes | 2016-09-01 → 2018-02-20 (+537d) | 2016-09-01 → 2018-03-06 (+551d) | 1d → 11d | 0d → 484d | 346FS+8d → 346 | was named Propuesta de Préstamo al Directorio del BID |
| 349 | Elaboración de lista corta | 2016-12-01 → 2018-03-21 (+475d) | 2016-12-01 → 2018-03-22 (+476d) | 1d → 2d | 0d → 484d | 353FS+10d → 348 | was named Consejo de Gabinete |
| 350 | Elaboración de SP, TdeR y de presupuesto | 2017-01-03 → 2018-03-23 (+444d) | 2017-01-03 → 2018-04-26 (+478d) | 1d → 20d | 0d → 484d | 349FS+22d → 349 | was named Refrendo de la CGR |
| 351 | Solicitud de no objeción al BID de SP, Presupuesto y lista corta | 2017-01-04 → 2018-04-27 (+478d) | 2017-04-05 → 2018-04-27 (+387d) | 66d → 1d | 0d → 484d |  | was named Cumplimiento de Condiciones de Elegibilidad |

| ID | Task | Start | Finish | Duration | Total float | Predecessors | Other |
| --- | --- | --- | --- | --- | --- | --- | --- |
| 352 | No objeción del BID de SP, Presupuesto y lista corta | 2017-04-06 → 2018-04-30 (+389d) | 2017-04-06 → 2018-05-07 (+396d) | 0d → 5d | 0d → 484d | 351FS+1d → 351 | was named Inicio de la ejecución del PSACH Fase I |
| 353 | Notificación de conformación de lista corta | 2016-11-16 → 2018-05-08 (+538d) | 2016-11-16 → 2018-05-09 (+539d) | 1d → 2d | 0d → 484d | 116FS+22d → 352 | was named Consejo Económico Nacional |
| 358 | No objeción del BID | 2016-01-04 → 2018-07-06 (+914d) | 2022-12-30 → 2018-07-12 (-1632d) | 1825d → 5d | 0d → 484d | none → 357 | was named Componente 1. Inversiones prioritarias |
| 359 | Notificación de resultados a los participantes (Evaluación técnica) | 2017-04-10 → 2018-07-13 (+459d) | 2022-12-30 → 2018-07-16 (-1628d) | 1495d → 2d | 0d → 484d | 95SS → 358 | was named Coordinación de acciones el MEF e informar permanentemente sobre los resultados y avances logrados por el Programa |
| 360 | Apertura de propuestas de precios | 2017-04-10 → 2018-07-17 (+463d) | 2022-12-30 → 2018-07-19 (-1625d) | 1495d → 3d | 0d → 484d | 359SS → 359 | was named Reuniones de coordinación con las autoridades de la CGR para socializar aspectos importantes del proyecto y solicitar apoyo requeirdo por parte de la entidad |
| 364 | No objeción | 2017-04-10 → 2018-08-07 (+484d) | 2022-12-30 → 2018-08-13 (-1600d) | 1495d → 5d | 0d → 484d | none → 363 | was named Auditoría del Programa |
| 365 | Aprobacion del Contrato por el Consejo Directivo | 2017-04-10 → 2018-08-14 (+491d) | 2022-12-30 → 2018-09-03 (-1579d) | 1495d → 15d | 0d → 484d | none → 364 | was named SBCC_18. Contratación de firma para servicios de Auditoría Externa del Programa |
| 366 | Publicación de la adjudicación y notificacion al ganador | 2020-03-05 → 2018-09-04 (-548d) | 2022-12-28 → 2018-09-05 (-1575d) | 735d → 2d | 2d → 484d | none → 365 | was named Evaluaciones del Programa |
| 367 | Suscripción del contrato | 2020-03-05 → 2018-09-06 (-546d) | 2020-09-30 → 2018-09-10 (-751d) | 150d → 3d | 2d → 484d | none → 366 | was named CCIN_21. Consultoría individual para evaluación intermedia del Programa |
| 368 | Envío de contrato firmado al BID y formulario PRISM | 2021-12-30 → 2018-09-11 (-1206d) | 2022-12-28 → 2018-09-12 (-1568d) | 260d → 2d | 2d → 653d | none → 367 | was named SCC_19. Consultoría para la evaluación final del programa |
| 369 | Orden de Inicio | 2022-04-28 → 2018-09-11 (-1325d) | 2022-12-28 → 2018-09-11 (-1569d) | 175d → 1d | 2d → 484d | none → 367 | was named CCIN_22.Consultor individual para la evaluación ex post del Programa |
| 371 | **Pagos** | 2018-07-03 → 2018-09-12 (+71d) | 2020-12-21 → 2019-05-30 (-571d) | 645d → 170d | 529d → 484d |  |  |
| 372 | Pago 1 | 2021-10-22 → 2018-09-12 (-1136d) | 2022-10-21 → 2018-09-13 (-1499d) | 260d → 2d | 50d → 484d | none → 369 | was named LPI_1. Contratación de firma para la Operación y Mantenimiento de la PTAR Caimito |
| 373 | pago 2 | 2021-10-22 → 2018-11-16 (-1071d) | 2022-10-21 → 2018-11-19 (-1432d) | 260d → 2d | 50d → 484d | none → 372FS+40d | was named Ejecución del contrato |
| 374 | Pago 3 | 2021-10-22 → 2019-01-23 (-1003d) | 2021-10-22 → 2019-01-24 (-1002d) | 0d → 2d | 50d → 484d | PTAR Caimito construidaFS+4d → 373FS+40d | was named Traspaso de obra para O&M |
| 375 | Pago 4 | 2021-10-25 → 2019-03-22 (-948d) | 2022-10-21 → 2019-03-25 (-1306d) | 260d → 2d | 50d → 484d | 374 → 374FS+40d | was named Ejecución de la O&M |
| 377 | **Enfoque de Género** | 2019-04-30 → 2017-02-28 (-791d) | 2020-12-21 → 2019-07-10 (-530d) | 430d → 577d | 529d → 455d |  | was named Ejecución del contrato |
| 378 | **Proveedores de Servicios Tramo muestra** | 2019-12-18 → 2017-02-28 (-1023d) | 2021-12-28 → 2018-01-25 (-1433d) | 530d → 221d | 263d → 621d |  | was named Ejecución del contrato |
| 379 | **Proceso de contratación (LPN)** | 2019-12-18 → 2017-02-28 (-1023d) | 2021-12-28 → 2017-07-06 (-1636d) | 530d → 87d | 263d → 621d | 208SS → none | was named Construcción de conexiones domiciliarias |
| 380 | Elaboración especificaciones técnicas | 2022-10-11 → 2017-02-28 (-2051d) | 2022-10-11 → 2017-03-27 (-2024d) | 0d → 20d | 58d → 621d | 381 → 30SS-60d | was named Colectoras construidas |
| 381 | Elaboración documento de licitación | 2019-05-08 → 2017-03-28 (-771d) | 2022-10-11 → 2017-04-17 (-2003d) | 895d → 10d | 58d → 621d | Elaboración del diseño finalSS+60d → 380 | was named Construcción de las colectoras |
| 382 | Solicitud de No Objeción | 2019-02-13 → 2017-04-18 (-666d) | 2019-12-17 → 2017-04-19 (-972d) | 220d → 2d | 22d → 621d | Elaboración del diseño finalSS → 381 | was named Elaboración del diseño final |
| 386 | Evaluación y calificación de ofertas | 2021-05-12 → 2017-05-31 (-1442d) | 2021-10-26 → 2017-06-20 (-1589d) | 120d → 15d | 22d → 621d | 382SS+585d → 385 | was named Elaboración del diseño final |
| 387 | Solicitud de no objeción del BID | 2021-10-26 → 2017-06-21 (-1588d) | 2021-10-26 → 2017-06-22 (-1587d) | 0d → 2d | 308d → 621d |  | was named Diseño de las colectoras elaborado |
| 388 | No objeción del BID | 2021-10-27 → 2017-06-23 (-1587d) | 2022-11-30 → 2017-06-29 (-1980d) | 286d → 5d | 22d → 621d | 386 → 387 | was named Construcción de las colectoras |
| 389 | Suscripción de Contrato | 2022-11-30 → 2017-06-30 (-1979d) | 2022-11-30 → 2017-07-06 (-1973d) | 0d → 5d | 22d → 621d |  | was named Colectoras construidas |
| 390 | Ejecución | 2021-12-28 → 2017-07-07 (-1635d) | 2021-12-28 → 2018-01-23 (-1435d) | 0d → 132d | 263d → 811d | 379 → 389 | was named Conexiones domiciliarias construidas |
| 391 | **Pagos** | 2018-12-26 → 2017-07-21 (-523d) | 2021-12-28 → 2018-01-25 (-1433d) | 785d → 124d | 263d → 811d |  |  |
| 393 | Pago 2 | 2019-02-13 → 2017-10-25 (-476d) | 2022-10-11 → 2017-10-26 (-1811d) | 955d → 2d | 58d → 871d | none → 392FS+60d | was named Ejecución del contrato |
| 394 | Pago 3 | 2019-02-13 → 2018-01-24 (-385d) | 2019-12-17 → 2018-01-25 (-691d) | 220d → 2d | 58d → 811d | Elaboración del diseño finalSS → 390 | was named Elaboración del diseño final |
| 395 | **Proveedores de Servicios Tramo por definir** | 2022-10-11 → 2018-08-13 (-1520d) | 2022-10-11 → 2019-07-10 (-1189d) | 0d → 221d | 58d → 455d | 396 → none | was named Redes construidas |
| 396 | **Proceso de contratación (LPN)** | 2019-05-08 → 2018-08-13 (-268d) | 2022-10-11 → 2018-12-18 (-1393d) | 895d → 87d | 58d → 455d | 394SS+60d → none | was named Construcción de las colectoras |
| 397 | Elaboración especificaciones técnicas | 2019-02-13 → 2018-08-13 (-184d) | 2022-11-29 → 2018-09-07 (-1544d) | 990d → 20d | 23d → 455d | none → 89SS-60d | was named Ejecución del contrato |
| 398 | Elaboración documento de licitación | 2019-02-13 → 2018-09-10 (-156d) | 2019-12-17 → 2018-09-21 (-452d) | 220d → 10d | 793d → 455d | 382SS → 397 | was named Elaboración del diseño final |
| 399 | Solicitud de No Objeción | 2019-12-17 → 2018-09-24 (-449d) | 2019-12-17 → 2018-09-25 (-448d) | 0d → 2d | 793d → 455d |  | was named Diseño de las redes elaborado |
| 400 | No Objeción | 2019-05-08 → 2018-09-26 (-224d) | 2022-11-29 → 2018-10-09 (-1512d) | 930d → 5d | 23d → 455d | Construcción de las colectorasSS → 399 | was named Construcción de las colectoras |
| 401 | Publicación / Invitación Proceso | 2022-11-29 → 2018-10-10 (-1511d) | 2022-11-29 → 2018-10-10 (-1511d) | 0d → 1d | 23d → 455d |  | was named Redes construidas |
| 403 | Evaluación y calificación de ofertas | 2019-05-08 → 2018-11-12 (-177d) | 2022-10-11 → 2018-11-30 (-1411d) | 895d → 15d | 58d → 455d | none → 402 | was named Ejecución del contrato |
| 404 | Solicitud de no objeción del BID | 2022-10-11 → 2018-12-03 (-1408d) | 2022-10-11 → 2018-12-04 (-1407d) | 0d → 2d | 58d → 455d | 407 → 403 | was named Conexiones domiciliarias construidas |
| 405 | No objeción del BID | 2019-05-08 → 2018-12-05 (-154d) | 2022-11-29 → 2018-12-11 (-1449d) | 930d → 5d | 23d → 455d | 400SS → 404 | was named Construcción de conexiones domiciliarias |
| 407 | Ejecución | 2019-05-08 → 2018-12-19 (-140d) | 2022-10-11 → 2019-07-08 (-1191d) | 895d → 132d | 58d → 455d | 396SS → 406 | was named Construcción de conexiones domiciliarias |
| 408 | **Pagos** | 2019-03-13 → 2019-01-10 (-62d) | 2021-12-28 → 2019-07-10 (-902d) | 730d → 124d | 263d → 455d |  |  |
| 409 | Pago 1 | 2019-05-08 → 2019-01-10 (-118d) | 2022-11-29 → 2019-01-11 (-1418d) | 930d → 2d | 23d → 515d | none → 406FS+10d | was named Ejecución del contrato |
| 410 | Pago 2 | 2021-10-25 → 2019-04-08 (-931d) | 2022-10-21 → 2019-04-09 (-1291d) | 260d → 2d | 50d → 515d | 375SS → 409FS+60d | was named Pagos CL |
| 411 | Pago 3 | 2021-10-25 → 2019-07-09 (-839d) | 2022-10-21 → 2019-07-10 (-1199d) | 260d → 2d | 50d → 455d | none → 407 | was named Pagos |
| 412 | **Asistencia Técnica** | 2019-03-27 → 2017-09-18 (-555d) | 2021-05-11 → 2019-07-10 (-671d) | 555d → 440d | 428d → 455d | Construcción de las colectorasSS → none | was named Construcción de conexiones domiciliarias |
| 413 | **Proceso de contratación** | 2021-05-11 → 2017-09-18 (-1331d) | 2021-05-11 → 2017-11-23 (-1265d) | 0d → 44d | 428d → 621d | 412 → none | was named Conexiones domiciliarias construidas |
| 414 | Elaboración de TDRs y de presupuesto | 2017-05-09 → 2017-09-18 (+132d) | 2017-06-05 → 2017-09-20 (+107d) | 20d → 3d | 4d → 621d | 352FS+22d → 379FS+50d | was named Etapa previa |
| 415 | Solicitud de No Objeción | 2017-06-06 → 2017-09-21 (+107d) | 2017-08-07 → 2017-09-22 (+46d) | 45d → 2d | 4d → 621d |  | was named Etapa de contratación |
| 416 | No Objeción a TdeR | 2017-08-08 → 2017-09-25 (+48d) | 2017-09-04 → 2017-10-20 (+46d) | 20d → 15d | 4d → 621d |  | was named Formalización del contrato |
| 417 | Publicación / Invitación Proceso | 2017-09-05 → 2017-10-23 (+48d) | 2017-12-04 → 2017-10-23 (-42d) | 65d → 1d | 4d → 621d |  | was named Ejecución del contrato |
| 418 | Presentación de hojas de vida | 2017-12-05 → 2017-10-24 (-42d) | 2018-01-01 → 2017-10-30 (-63d) | 20d → 5d | 709d → 621d |  | was named Etapa previa |
| 419 | Evaluación y calificación de hojas de vida | 2018-01-02 → 2017-10-31 (-63d) | 2018-03-05 → 2017-11-06 (-119d) | 45d → 5d | 709d → 621d |  | was named Etapa de contratación |
| 420 | Solicitud de no objeción del BID | 2018-03-06 → 2017-11-07 (-119d) | 2018-04-02 → 2017-11-08 (-145d) | 20d → 2d | 709d → 621d |  | was named Formalización del contrato |
| 421 | No objeción del BID | 2019-06-12 → 2017-11-09 (-580d) | 2020-09-15 → 2017-11-15 (-1035d) | 330d → 5d | 598d → 621d | none → 420 | was named Ejecución del contrato |
| 422 | Negociación del contrato | 2019-12-17 → 2017-11-16 (-761d) | 2019-12-17 → 2017-11-16 (-761d) | 0d → 1d | 793d → 621d | Elaboración del diseño final → 421 | was named Diseño de las colectoras elaborado |
| 423 | Suscripción de Contrato | 2019-04-30 → 2017-11-17 (-529d) | 2020-12-21 → 2017-11-23 (-1124d) | 430d → 5d | 529d → 621d | 310SS → 422 | was named Construcción de las conexiones domiciliarias |
| 425 | **Pagos** | 2018-12-26 → 2018-01-24 (-336d) | 2020-09-15 → 2019-07-10 (-433d) | 450d → 358d | 598d → 455d |  |  |
| 426 | Pago 1 | 2018-04-03 → 2018-01-24 (-69d) | 2020-04-13 → 2018-01-25 (-809d) | 530d → 2d | 709d → 811d | 420 → 390 | was named Ejecución del contrato |
| 427 | Pago 2 | 2017-09-05 → 2019-07-09 (+672d) | 2017-12-04 → 2019-07-10 (+583d) | 65d → 2d | 1324d → 455d | none → 407 | was named Pagos |
| 430 | **Proceso de Contratación LPN** | 2017-02-06 → 2017-05-30 (+113d) | 2017-03-03 → 2017-09-28 (+209d) | 20d → 87d | 1240d → 824d | 352FS-44d → none | was named Etapa previa |
| 431 | Elaboración especificaciones técnicas | 2017-03-06 → 2017-05-30 (+85d) | 2017-04-14 → 2017-06-26 (+73d) | 30d → 20d | 1240d → 824d | 430 → 599FS+20d | was named Expresión de interés |
| 432 | Elaboración documento de licitación | 2017-10-02 → 2017-06-27 (-97d) | 2018-03-30 → 2017-07-10 (-263d) | 130d → 10d | 1240d → 824d | none → 431 | was named Pagos |
| 433 | Solicitud de No Objeción | 2017-10-02 → 2017-07-11 (-83d) | 2018-03-30 → 2017-07-12 (-261d) | 130d → 2d | 1240d → 824d | 439 → 432 | was named Ejecución del contrato |
| 434 | No Objeción | 2017-10-02 → 2017-07-13 (-81d) | 2018-03-30 → 2017-07-19 (-254d) | 130d → 5d | 1240d → 824d | 435SS → 433 | was named Pagos CL |
| 435 | Publicación / Invitación Proceso | 2017-10-02 → 2017-07-20 (-74d) | 2018-03-30 → 2017-07-20 (-253d) | 130d → 1d | 1240d → 824d | 433SS → 434 | was named Pagos BID |
| 436 | Presentación de ofertas | 2018-02-21 → 2017-07-21 (-215d) | 2018-03-20 → 2017-08-21 (-211d) | 20d → 22d | 718d → 824d | Etapa de contratación → 435 | was named Formalización del contrato |
| 437 | Evaluación y calificación de ofertas | 2018-03-21 → 2017-08-22 (-211d) | 2020-03-31 → 2017-09-11 (-932d) | 530d → 15d | 718d → 824d |  | was named Ejecución del contrato |
| 438 | Solicitud de no objeción del BID | 2017-04-17 → 2017-09-12 (+148d) | 2017-09-01 → 2017-09-13 (+12d) | 100d → 2d | 1240d → 824d | 431 → 437 | was named Etapa de contratación |
| 439 | No objeción del BID | 2017-09-04 → 2017-09-14 (+10d) | 2017-09-29 → 2017-09-21 (-8d) | 20d → 5d | 1240d → 824d |  | was named Formalización del contrato |

| ID | Task | Start | Finish | Duration | Total float | Predecessors | Other |
| --- | --- | --- | --- | --- | --- | --- | --- |
| 440 | Suscripción de Contrato | 2017-09-05 → 2017-09-22 (+17d) | 2017-12-04 → 2017-09-28 (-67d) | 65d → 5d | 1324d → 824d | Pagos BIDSS → 439 | was named Pagos CAF |
| 441 | Ejecución de contrato | 2017-08-04 → 2017-09-29 (+56d) | 2021-11-25 → 2017-12-06 (-1450d) | 1125d → 44d | 286d → 824d | 13FS+4d → 440 |  |
| 442 | Pagos | 2018-04-03 → 2018-01-05 (-88d) | 2020-04-13 → 2018-01-08 (-826d) | 530d → 2d | 709d → 824d | 426SS → 441SS+60d | was named Pagos BID |
| 443 | **Adquisición de equipo informático** | 2016-08-15 → 2017-09-05 (+386d) | 2016-10-14 → 2018-03-23 (+525d) | 45d → 133d | 50d → 770d | Etapa previa → none | was named Etapa de Expresión de interés |
| 444 | **Proceso de Contratación LPN** | 2017-07-12 → 2017-09-05 (+55d) | 2017-08-22 → 2018-01-18 (+149d) | 30d → 87d | 718d → 770d | 445 → none | was named Expresión de interés |
| 445 | Elaboración especificaciones técnicas | 2017-06-14 → 2017-09-05 (+83d) | 2017-07-11 → 2017-10-10 (+91d) |  | 718d → 770d | 352FS+48d → 599FS+90d | was named Etapa previa |
| 446 | Elaboración documento de licitación | 2018-03-21 → 2017-10-11 (-161d) | 2020-03-31 → 2017-10-24 (-889d) | 530d → 10d | 718d → 770d | 447SS → 445 | was named Pagos CAF |
| 447 | Solicitud de No Objeción | 2018-03-21 → 2017-10-25 (-147d) | 2020-03-31 → 2017-10-26 (-887d) | 530d → 2d | 718d → 770d | 437SS → 446 | was named Pagos BID |
| 450 | Presentación de ofertas | 2017-12-04 → 2017-11-06 (-28d) | 2017-12-04 → 2017-12-05 (+1d) | 0d → 22d | 1324d → 770d | 417 → 449 | was named Plan de capacitación elaborado |
| 451 | Evaluación y calificación de ofertas | 2022-12-26 → 2017-12-06 (-1846d) | 2022-12-26 → 2018-01-02 (-1819d) | 0d → 15d | 4d → 770d | 426, 283 → 450 | was named Actividades de capacitación implementadas |
| 453 | No objeción del BID | 2018-03-30 → 2018-01-05 (-84d) | 2018-03-30 → 2018-01-11 (-78d) | 0d → 5d | 1240d → 770d | 433 → 452 | was named Instrumento reglamentario elaborado |
| 454 | Suscripción de Contrato | 2020-03-31 → 2018-01-12 (-809d) | 2020-03-31 → 2018-01-18 (-803d) | 0d → 5d | 718d → 770d | 437 → 453 | was named Catastro técnico realizado- Año 3 |
| 455 | Ejecución de contrato | 2019-06-03 → 2018-01-19 (-500d) | 2019-06-28 → 2018-03-21 (-464d) | 20d → 44d | 0d → 770d | 352FS+561d → 454 | was named Etapa previa |
| 456 | Pagos | 2019-07-01 → 2018-03-22 (-466d) | 2019-08-09 → 2018-03-23 (-504d) | 30d → 2d | 0d → 770d |  | was named Expresión de interés |
| 458 | **Proceso de Contratación LPN** | 2019-08-12 → 2018-03-21 (-509d) | 2020-02-07 → 2018-07-27 (-560d) | 130d → 87d | 0d → 640d | 456 → none | was named Etapa de contratación |
| 459 | Elaboración especificaciones técnicas | 2020-02-10 → 2018-03-21 (-691d) | 2020-03-06 → 2018-04-24 (-682d) |  | 0d → 640d | 458 → 599FS+220d | was named Formalización del contrato |
| 460 | Elaboración documento de licitación | 2020-03-09 → 2018-04-25 (-684d) | 2022-12-30 → 2018-05-09 (-1696d) | 735d → 10d | 0d → 640d |  | was named Ejecución del contrato |
| 461 | Solicitud de No Objeción | 2020-03-09 → 2018-05-10 (-669d) | 2022-12-30 → 2018-05-11 (-1694d) | 735d → 2d | 0d → 640d | 462SS → 460 | was named Pagos CAF |
| 462 | No Objeción | 2020-03-09 → 2018-05-14 (-665d) | 2022-12-30 → 2018-05-18 (-1687d) | 735d → 5d | 0d → 640d | 460SS → 461 | was named Pagos BID |
| 463 | Publicación / Invitación Proceso | 2020-03-09 → 2018-05-21 (-658d) | 2022-12-30 → 2018-05-21 (-1684d) | 735d → 1d | 0d → 640d | none → 462 | was named Pagos |
| 465 | Evaluación y calificación de ofertas | 2020-03-09 → 2018-06-21 (-627d) | 2022-12-30 → 2018-07-11 (-1633d) | 735d → 15d | 0d → 640d | 461SS → 464 | was named Pagos CL |
| 466 | Solicitud de no objeción del BID | 2020-03-09 → 2018-07-12 (-606d) | 2020-03-09 → 2018-07-13 (-605d) | 0d → 2d | 475d → 640d | 460SS → 465 | was named Hito 1: Línea de base actualizada |
| 467 | No objeción del BID | 2021-03-05 → 2018-07-16 (-963d) | 2021-03-05 → 2018-07-20 (-959d) | 0d → 5d | 475d → 640d | 466FS+260d → 466 | was named Hito 2: Campaña de monitoreo realizada - Año 5 |
| 468 | Suscripción de Contrato | 2021-02-16 → 2018-07-23 (-939d) | 2021-02-16 → 2018-07-27 (-935d) | 0d → 5d | 224d → 640d | 474FS+264d → 467 | was named Hito 2: Programa de monitoreo diseñado |
| 469 | Ejecución de contrato | 2022-11-30 → 2018-07-30 (-1584d) | 2022-11-30 → 2018-09-27 (-1525d) | 0d → 44d | 22d → 640d | 475 → 468 | was named Hito 3: Campaña de monitoreo realizada - Año 6 |
| 470 | Pagos | 2020-11-19 → 2018-09-28 (-783d) | 2022-11-30 → 2018-10-08 (-1514d) | 530d → 2d | 22d → 640d | none → 469 |  |
| 471 | **Acondicionamiento de espacios de oficinas** | 2016-09-12 → 2018-03-21 (+555d) | 2016-11-11 → 2018-10-08 (+696d) | 45d → 133d | 240d → 640d | 107 → none | was named Etapa de Expresión de interés |
| 472 | **Proceso de Contratación LPN** | 2020-11-19 → 2018-03-21 (-974d) | 2022-11-30 → 2018-07-27 (-1587d) | 530d → 87d | 22d → 640d | 475SS → none | was named Pagos BID |
| 473 | Elaboración especificaciones técnicas | 2020-11-19 → 2018-03-21 (-974d) | 2022-11-30 → 2018-04-24 (-1681d) | 530d → 20d | 22d → 640d | 480SS → 599FS+220d | was named Pagos CL |
| 474 | Elaboración documento de licitación | 2020-02-13 → 2018-04-25 (-659d) | 2020-02-13 → 2018-05-09 (-645d) | 0d → 10d | 224d → 640d | 479SS → 473 | was named Hito 1: Actualización de grandes contaminantes de descargas de aguas residuales no domésticos realizada |
| 475 | Solicitud de No Objeción | 2020-11-19 → 2018-05-10 (-924d) | 2022-11-30 → 2018-05-11 (-1664d) | 530d → 2d | 22d → 640d | 476 → 474 | was named Ejecución del contrato |
| 476 | No Objeción | 2020-10-22 → 2018-05-14 (-892d) | 2020-11-18 → 2018-05-18 (-915d) | 20d → 5d | 22d → 640d | 477 → 475 | was named Formalización del contrato |
| 477 | Publicación / Invitación Proceso | 2020-04-23 → 2018-05-21 (-703d) | 2020-10-21 → 2018-05-21 (-884d) | 130d → 1d | 22d → 640d | 478 → 476 | was named Etapa de contratación |
| 478 | Presentación de ofertas | 2020-03-12 → 2018-05-22 (-660d) | 2020-04-22 → 2018-06-20 (-672d) | 30d → 22d | 22d → 640d | 479 → 477 | was named Expresión de interés |
| 479 | Evaluación y calificación de ofertas | 2020-02-13 → 2018-06-21 (-602d) | 2020-03-11 → 2018-07-11 (-609d) | 20d → 15d | 22d → 640d | 352FS+744d → 478 | was named Etapa previa |
| 480 | Solicitud de no objeción del BID | 2020-11-19 → 2018-07-12 (-861d) | 2022-11-30 → 2018-07-13 (-1601d) | 530d → 2d | 22d → 640d | 472SS → 479 | was named Pagos CAF |
| 481 | No objeción del BID | 2020-02-13 → 2018-07-16 (-577d) | 2020-03-11 → 2018-07-20 (-600d) | 20d → 5d | 22d → 640d | 479SS → 480 | was named Etapa previa |
| 482 | Suscripción de Contrato | 2020-03-12 → 2018-07-23 (-598d) | 2020-04-22 → 2018-07-27 (-635d) | 30d → 5d | 22d → 640d |  | was named Expresión de interés |
| 483 | Ejecución de contrato | 2020-04-23 → 2018-07-30 (-633d) | 2020-10-21 → 2018-09-27 (-755d) | 130d → 44d | 22d → 640d |  | was named Etapa de contratación |
| 484 | Pagos | 2020-10-22 → 2018-09-28 (-755d) | 2020-11-18 → 2018-10-08 (-772d) | 20d → 2d | 22d → 640d |  | was named Formalización del contrato |
| 485 | **Equipos de Transporte** | 2019-03-27 → 2018-03-21 (-371d) | 2021-05-11 → 2018-10-08 (-946d) | 555d → 133d | 428d → 640d | Elaboración del diseño finalSS+65d → none | was named Construcción de las colectoras |
| 491 | Publicación / Invitación Proceso | 2020-11-19 → 2018-05-21 (-913d) | 2022-11-30 → 2018-05-21 (-1654d) | 530d → 1d | 22d → 640d | 492SS → 490 | was named Pagos CL |
| 492 | Presentación de ofertas | 2020-11-19 → 2018-05-22 (-912d) | 2022-11-30 → 2018-06-20 (-1624d) | 530d → 22d | 22d → 640d | 497SS → 491 | was named Pagos BID |
| 493 | Evaluación y calificación de ofertas | 2020-11-19 → 2018-06-21 (-882d) | 2022-11-30 → 2018-07-11 (-1603d) | 530d → 15d | 22d → 640d | none → 492 | was named Pagos |
| 495 | No objeción del BID | 2020-12-22 → 2018-07-16 (-890d) | 2020-12-22 → 2018-07-20 (-886d) | 0d → 5d | 264d → 640d | 496FS+224d → 494 | was named Hito 2: Actividades del Plan desarrolladas - Año 4 |
| 496 | Suscripción de Contrato | 2020-02-13 → 2018-07-23 (-570d) | 2020-02-13 → 2018-07-27 (-566d) | 0d → 5d | 264d → 640d | 481SS → 495 | was named Hito 1: Diagnóstico y plan diseñados |
| 497 | Ejecución de contrato | 2020-11-19 → 2018-07-30 (-843d) | 2022-11-30 → 2018-09-27 (-1525d) | 530d → 44d | 22d → 640d | 484 → 496 | was named Ejecución del contrato |
| 499 | **OTROS GASTOS** | 2017-09-25 → 2017-08-16 (-40d) | 2022-01-28 → 2021-05-19 (-254d) | 1135d → 917d | 240d → 0d | Formalización del contrato → none | was named Ejecución del contrato |
| 501 | **Contratación de servicios de apoyo a la gestión del programa (Gerenciamiento)** | 2018-12-26 → 2017-08-16 (-497d) | 2021-05-11 → 2021-01-18 (-113d) | 620d → 830d | 428d → 87d | Elaboración del diseño finalSS → none | was named Pagos BID |
| 502 | Ejecución año 1 | 2018-12-26 → 2017-08-16 (-497d) | 2021-05-11 → 2018-01-31 (-1196d) | 620d → 110d | 428d → 87d | 501SS → 600FS+66d | was named Pagos CAF |
| 504 | Ejecución año 3 | 2018-12-26 → 2019-02-11 (+47d) | 2021-05-11 → 2020-01-21 (-476d) | 620d → 230d | 428d → 87d | 502SS → 503FS+10d | was named Pagos CL |
| 505 | Ejecución año 4 | 2017-09-25 → 2020-02-05 (+863d) | 2022-01-28 → 2021-01-18 (-375d) | 1135d → 230d | 240d → 87d | 506SS → 504FS+10d | was named Pagos CL |
| 506 | **Monitoreo y Evaluación** | 2017-09-25 → 2020-05-25 (+973d) | 2022-01-28 → 2021-01-11 (-382d) | 1135d → 154d | 240d → 92d | 499SS → none | was named Pagos BID |
| 507 | **Proceso de Contratación Evaluación Final y Monitoreo del programa** | 2017-09-25 → 2020-05-25 (+973d) | 2022-01-28 → 2020-09-22 (-493d) | 1135d → 86d | 240d → 92d | 506SS → none | was named Pagos BID |
| 508 | Elaboración de TdeR y de presupuesto | 2017-09-25 → 2020-05-25 (+973d) | 2022-01-28 → 2020-06-12 (-595d) | 1135d → 15d | 240d → 92d | 507SS → 30, 89, 53 | was named Pagos CL |
| 520 | Ejecucion de la Consultoría | 2018-12-26 → 2020-09-23 (+637d) | 2021-12-28 → 2021-01-07 (-355d) | 785d → 66d | 263d → 92d | 195SS → 519 | was named Pagos CAF |
| 521 | **Pagos** | 2018-12-26 → 2020-09-23 (+637d) | 2021-05-11 → 2021-01-11 (-120d) | 620d → 68d | 428d → 92d |  |  |
| 522 | Primer Pago | 2019-03-13 → 2020-09-23 (+560d) | 2021-12-28 → 2020-09-24 (-460d) | 730d → 2d | 263d → 158d | Pagos CAFSS → 519 | was named Pagos BCIE |
| 523 | Segundo Pago | 2019-03-13 → 2021-01-08 (+667d) | 2021-12-28 → 2021-01-11 (-351d) | 730d → 2d | 263d → 92d | 522SS → 520 | was named Pagos CL |
| 524 | **Auditoria** | 2018-12-26 → 2017-10-11 (-441d) | 2021-05-11 → 2021-05-19 (+8d) | 620d → 883d | 428d → 0d | Elaboración del diseño finalSS → none | was named Pagos CAF |
| 525 | **Proceso de contratación** | 2018-12-26 → 2017-10-11 (-441d) | 2021-05-11 → 2018-03-07 (-1161d) | 620d → 101d | 428d → 0d | 524SS → none | was named Pagos BCIE |
| 526 | Preparación de documentos de licitación | 2018-12-26 → 2017-10-11 (-441d) | 2021-05-11 → 2017-11-09 (-1279d) | 620d → 22d | 428d → 0d | 525SS → 600FS+100d | was named Pagos CL |
| 527 | Solicitud de No Objeción al BID | 2018-12-26 → 2017-11-10 (-411d) | 2020-09-15 → 2017-11-13 (-1037d) | 450d → 2d | 598d → 0d | none → 526 | was named Cuenca de Puerto Caimito |
| 528 | No Objeción del BID | 2018-12-26 → 2017-11-14 (-407d) | 2020-09-15 → 2017-11-20 (-1030d) | 450d → 5d | 598d → 0d | none → 527 | was named Pagos |
| 529 | Convocatoria pública a participar | 2018-12-26 → 2017-11-21 (-400d) | 2020-09-15 → 2017-11-22 (-1028d) | 450d → 2d | 598d → 0d | 178SS → 528 | was named Pagos CL |
| 532 | Evaluación de ofertas | 2017-08-04 → 2018-01-02 (+151d) | 2021-01-28 → 2018-01-22 (-1102d) | 910d → 15d | 501d → 0d | none → 531 | was named Conexiones domiciliarias construidas en las cuencas de Prudente, Aguacate y Bernardino |
| 541 | Auditoria anual 2017 | 2017-09-25 → 2018-04-12 (+199d) | 2022-12-30 → 2018-06-07 (-1667d) | 1375d → 40d |  | 11SS → 540FS+20d | was named Pagos BID |
| 542 | Auditoría intermedia 2018 | 2017-09-25 → 2018-08-03 (+312d) | 2022-12-30 → 2018-09-27 (-1555d) | 1375d → 40d |  | 541SS → 541FS+40d | was named Pagos CL |
| 548 | **Pagos** | 2017-09-25 → 2018-06-08 (+256d) | 2022-01-28 → 2021-05-19 (-254d) | 1135d → 722d | 240d → 0d |  |  |
| 549 | Auditoria anual 2017 | 2019-05-08 → 2018-06-08 (-334d) | 2022-10-11 → 2018-06-11 (-1583d) | 895d → 2d | 58d → 720d | 407SS → 541 | was named Pagos CL |

| ID | Task | Start | Finish | Duration | Total float | Predecessors | Other |
| --- | --- | --- | --- | --- | --- | --- | --- |
| 551 | Auditoria anual 2018 | 2019-05-08 → 2019-06-04 (+27d) | 2022-11-29 → 2019-06-05 (-1273d) | 930d → 2d | 23d → 480d | none → 543 | was named Cuenca de Caimito II |
| 552 | Auditoría intermedia 2019 | 2019-05-08 → 2019-10-14 (+159d) | 2022-11-29 → 2019-10-15 (-1141d) | 930d → 2d | 23d → 390d | none → 544 | was named Pagos |
| 553 | Auditoria anual 2019 | 2019-05-08 → 2020-06-12 (+401d) | 2022-11-29 → 2020-06-15 (-897d) | 930d → 2d | 23d → 230d | 405SS → 545 | was named Pagos CL |
| 555 | Auditoria anual 2020 | 2017-09-25 → 2021-05-18 (+1331d) | 2022-12-30 → 2021-05-19 (-590d) | 1375d → 2d |  | none → 547 | was named SBCC_8. Contratación de firma consultora para la supervisión de diseños y obras |
| 556 | **CONDICIONES CONTRACTUALES** | 2019-06-12 → 2017-05-16 (-757d) | 2020-09-15 → 2021-01-27 (+134d) | 330d → 903d | 598d → 80d |  | was named Cuenca de Puerto Caimito |
| 557 | **Informes Semestrales** | 2019-06-12 → 2017-06-01 (-741d) | 2020-09-15 → 2021-01-27 (+134d) | 330d → 891d | 598d → 80d |  | was named Pagos |
| 558 | Informe primer semestre 2017 | 2019-06-12 → 2017-06-01 (-741d) | 2020-09-15 → 2017-06-30 (-1173d) | 330d → 22d | 598d → 80d | Construcción de conexiones domiciliariasSS → none | was named Pagos CL; constraint none → start no earlier than 2017-06-01 |
| 560 | Informe primer semestre 2018 | 2017-09-25 → 2018-05-25 (+242d) | 2022-01-28 → 2018-06-25 (-1313d) | 1135d → 22d | 240d → 80d | none → 559FS+75d | was named SBCC_7. Contratación de firma consultora para la supervisión de diseños y obras |
| 561 | Informe segundo semestre 2018 | 2019-12-18 → 2018-12-18 (-365d) | 2021-12-28 → 2019-01-24 (-1069d) | 530d → 22d | 263d → 80d | none → 560FS+120d | was named Pagos |
| 562 | Informe primer semestre 2019 | 2019-12-18 → 2019-05-27 (-205d) | 2021-12-28 → 2019-06-25 (-917d) | 530d → 22d | 263d → 80d | 379SS → 561FS+80d | was named Pagos BCIE |
| 563 | Informe segundo semestre 2019 | 2019-12-18 → 2019-12-17 (-1d) | 2021-12-28 → 2020-01-24 (-704d) | 530d → 22d | 263d → 80d | 562SS → 562FS+120d | was named Pagos CL |
| 566 | **POA Anuales** | 2019-03-27 → 2017-05-16 (-680d) | 2021-05-11 → 2020-02-07 (-459d) | 555d → 669d | 428d → 314d |  | was named Cuenca de Rodeo |
| 567 | POA 2017 | 2019-03-27 → 2017-05-16 (-680d) | 2021-05-11 → 2017-05-29 (-1443d) | 555d → 10d | 428d → 973d | none → 600 | was named Pagos |
| 568 | POA 2018 | 2019-03-27 → 2018-02-01 (-419d) | 2021-05-11 → 2018-02-14 (-1182d) | 555d → 10d | 428d → 797d | 412SS → 559 | was named Pagos BCIE |
| 569 | POA 2019 | 2019-03-27 → 2019-01-25 (-61d) | 2021-12-28 → 2019-02-07 (-1055d) | 720d → 10d | 263d → 558d | none → 561 | was named Cuenca de Martín Sánchez I |
| 570 | POA 2020 | 2019-03-27 → 2020-01-27 (+306d) | 2021-12-28 → 2020-02-07 (-690d) | 720d → 10d | 263d → 314d | none → 563 | was named Pagos |
| 574 | Plan de adquisiciones actualizado 2019 | 2019-03-27 → 2019-01-25 (-61d) | 2021-12-28 → 2019-02-07 (-1055d) | 720d → 10d | 263d → 558d | 204SS → 561 | was named Pagos CL |
| 575 | Plan de adquisiciones actualizado 2020 | 2021-12-28 → 2020-01-27 (-701d) | 2021-12-28 → 2020-02-07 (-690d) | 0d → 10d | 263d → 314d | 204 → 563 | was named Conexiones domiciliarias construidas |
| 576 | **FORMALIZACIÓN DEL CONTRATO DE PRÉSTAMO HO-L1121** | 2019-12-18 → 2016-10-10 (-1164d) | 2021-12-28 → 2017-06-02 (-1670d) | 530d → 159d | 263d → 0d |  | was named Cuenca de Martín Sánchez II |
| 579 | Solicitud de autorización para firmar al Congreso | 2016-03-28 → 2016-11-24 (+241d) | 2016-06-17 → 2016-12-12 (+178d) | 60d → 13d | 1705d → 0d | Etapa previa → 578 | was named Expresión de interés |
| 580 | Firma del contrato de préstamo | 2017-09-25 → 2016-12-13 (-286d) | 2022-12-30 → 2016-12-14 (-2207d) | 1375d → 2d |  | Formalización del contrato → 579 | was named Pagos BID |
| 581 | Aprobación del Contrato de Préstamo por el Congreso Nacional | 2017-09-25 → 2016-12-15 (-284d) | 2022-12-30 → 2017-01-04 (-2186d) | 1375d → 10d |  | 580SS → 580 | was named Pagos CL |
| 582 | Envío de contrato firmado al Poder Ejecutivo | 2018-01-03 → 2017-01-05 (-363d) | 2018-04-03 → 2017-01-05 (-453d) | 65d → 1d | 22d → 0d | Formalización del contratoFS+72d → 581 | was named Etapa previa |
| 583 | Sanción del contrato por el Poder Ejecutivo | 2018-04-04 → 2017-01-06 (-453d) | 2018-10-09 → 2017-01-09 (-638d) | 135d → 2d | 22d → 0d |  | was named Etapa de contratación |
| 584 | Ratificación del contrato por el Poder Ejecutivo | 2019-02-13 → 2017-02-07 (-736d) | 2022-11-30 → 2017-03-01 (-2100d) | 991d → 17d | 22d → 0d | none → 583FS+20d | was named Ejecución del contrato |
| 585 | Envío de Contrato a publicación | 2019-02-13 → 2017-03-02 (-713d) | 2022-10-11 → 2017-03-03 (-2048d) | 955d → 2d | 58d → 0d | Elaboración del diseño finalSS → 584 | was named Pagos BID |
| 587 | Vigencia del Contrato de Préstamo | 2019-02-13 → 2017-03-07 (-708d) | 2021-02-23 → 2017-03-07 (-1449d) | 530d → 0d | 483d → 53d | 597SS → 586 | was named Pagos CL |
| 590 | **CONDICIONES PREVIAS AL PRIMER DESEMBOLSO** | 2019-02-13 → 2016-12-01 (-804d) | 2022-11-29 → 2017-06-02 (-2006d) | 990d → 121d | 23d → 64d |  | was named LPI_3. Contratación de firma para el diseño y construcción de obras |
| 594 | Entrega de información sobre cuenta bancaría para desembolsos | 2019-02-13 → 2017-04-18 (-666d) | 2022-10-11 → 2017-05-05 (-1985d) | 955d → 13d | 58d → 969d | none → 593 | was named Cuenca de Caimito I |
| 595 | Sistema de información y control financiero interno | 2019-02-13 → 2017-05-08 (-646d) | 2022-10-11 → 2017-06-02 (-1957d) | 955d → 20d | 58d → 969d | none → 594 | was named Pagos |
| 597 | Manual operativo | 2019-02-13 → 2016-12-01 (-804d) | 2022-10-11 → 2017-01-04 (-2106d) | 955d → 20d | 58d → 66d | 394SS → none | was named Pagos CL; constraint none → start no earlier than 2016-12-01 |
| 599 | No Objeción del Banco | 2019-02-13 → 2017-04-07 (-677d) | 2022-11-29 → 2017-04-28 (-2041d) | 990d → 11d | 23d → 0d | none → 598, 597 | was named Cuenca de Caimito II |
| 601 | Fecha ultimo desembolso BID | 2019-02-13 → 2021-03-05 (+751d) | 2021-02-23 → 2021-03-05 (+10d) | 530d → 0d | 483d → 53d | none → 587FS+973d | was named Pagos |
